# 3GPP_Release-2000

Schedule from MS Project, 2000-01-01 to 2010-03-12, A marks actual dates.

## Calendars

- Standard: Mon-Fri 08:00-12:00, 13:00-17:00; Sat-Sun off.

## Resources

| Resource |
| --- |
| NP |
| N1 |
| N2 |
| N3 |
| N4 |
| N5 |
| TP |
| T1 |
| T2 |
| T3 |
| RP |
| R1 |
| R2 |
| R3 |
| R4 |
| SP |
| S1 |
| S2 |
| S3 |
| S4 |
| S5 |
| PCG |
| GP |
| No |
| CN4 |
| ? |
| WG G2 |
| G2 |
| G1 |
| G4 |
| G3 |
| All |
| Generic |
| MLST |
| G5 |
| S3, G2 |
| WG T2 |
| GP,G1 |
| G4,G5 |
| OMA |
| GP-G2 |
| Yes |
| GP, |
| N4, |
| GP, N1 |
| CT5 |
| C5 |
| C1 |
| C4 |
| C3 |
| C6 |
| G1, |
| 4 |
| ct |
| c,s,r |
| CT,RAN,SA |
| G2, |
| G1, G3 |
| CT6 |
| CT1 |
| CT1, CT3, CT4 |
| C1, C3, C4 |
| CP |
| R5 |
| C |
| Rel-8 |
| GP, G2 |
| R1,R4 |
| S5,C1 |
| CT,RAN,SA,GERAN |
| S3,C1,C4 |
| 5 |
| S1,C1,C3,C4,S5 |
| S1,C1,C3,C5 |
| S1,C1,C3,C4 |
| S1,S5 |
| S2,S3 |
| RAN,SA |
| RP,S5 |
| S2,CT |
| S1,CT |
| S1,CT,GERAN |
| S1,C5 |
| S3,CT |
| S4,CT |
| C1,SA |
| S1,S2 |
| S1,S4 |
| S2,S2,S3,CT |
| S2,S3,CT |
| S1,CT,GX |
| S1,S4,CT |
| S2,S2,S3,S5,CT |
| S1,S2,CT |
| S1,S2,S3,CT |
| S1,S2,S3,S5CT |
| S1,S2,S3,S5,CT |
| S2,S5,CT |
| S4,S3 |
| S1,C1 |
| CP,C1 |
| C1,C3 |
| C1,C3,C4 |
| S1,S5,CT |
| C4,C3 |
| CP,RAN,SA,GERAN |
| S1,S2,S3,S5,CP |
| S2,S3,CP |
| S2,CP |
| S1,CP,GX |
| S1,CP |
| S1,S4,CP |
| S1,S2,CP |
| S1,S2,S3,CP |
| S2,S5,CP |
| S3,CP |
| S1,S5,CP |
| RAN,SA,GERAN |
| S1,S2,S3,S5,C1,C3,C4,C6 |
| S2,S3,C1,C3,C4 |
| S2,C4 |
| S2,C1,C3,C4 |
| S2,C1,C4 |
| S2,S3,C1,C4 |
| S1,C1,C4,G2 |
| C1,C4 |
| S1,C1,C3 |
| S1,S4,C1,C3,C4 |
| S1,S2,S3,C1,C3,C4 |
| S2,S5,C3 |
| S1,S2,C1,C4 |
| S2,C1 |
| S2,C1,C3 |
| S3,C1,C3,C4 |
| S1,S5,C1,C3,C4 |
| S2,C3,C4 |
| C3,C1 |
| R2,R4 |
| R2,R5 |
| RP,R5 |
| RP,S5,R5 |
| R1,R5 |
| S1,C1,R5 |
| S1,C1,S4,R5 |
| GERAN |
| G3new |
| G1, G3new |
| C4,C1,C3 |
| R1.R4 |
| R1, R4 |
| R2,R3 |
| C3,C4 |
| S4,C3 |
| S4,C3,C1,C4 |
| S1,S2,C1 |
| S1,S2<C1,C3,C4 |
| S1,S2,C1,C3,C4 |
| S5,C1,C3,C4 |
| GP,C4 |
| C4,C1 |
| S2,S1 |
| RP,SP,GP |
| RP,SP,CP,GP |
| CP,GP,RP,SP |
| GP,C4,S4 |
| S1,C1,C4 |
| S1,S2,C3,C1 |
| R2,R4,R3 |
| CP,GP, RP,SP |
| S2,S1,C1,S5 |
| S2,S1,C1 |
| S1,C1,S4 |
| S1,S2,GP,C4,R2 |
| S1,GP,R2 |
| S1,C6 |
| S1,S2,C1,S4 |
| S2,S3,S5,C1,C3,C4 |
| S2,S5,C1 |
| S2,S3,S5 |
| CP,GP, RP,SP,TP |
| S2,C4,C1 |
| S1,C1,C4,S3 |
| S2,S5 |
| S3,C1 |
| S3,C4 |
| S1,C4 |
| S2,S5,C3,C1 |
| S2,S1,S5,C1,C4 |
| S1,R1,C3 |
| S1,C1,R2 |
| S2,S1,C1,C4 |
| S1,C1,C6 |
| GP,S4,C4,C1,C3 |
| C3,C1,C4 |
| S1,C4,C1 |
| S1,S3 |
| S1,S2,S5,C3,C4 |
| R4,G1 |
| G1,R4 |
| RP,GP |
| R4,GP |
| R3,R2 |
| C6,RP,SP |
| R5,C6 |
| CP,RP,SP |
| RP,SP,CP |
| R3,S5 |
| S1,S2,RP |
| S1,S2,S5,RP |
| S2,S1,RP |
| Rel-9 |

## Schedule

| ID | WBS | Task | Type | Duration | Start | Finish | Complete | Remaining | Baseline start | Baseline finish | Baseline duration | Total slack | Constraint | Resources | Work | Actual work | Text6 | Text1 | Text4 | Text5 | Text7 | Text8 | Text2 | Text3 | Text12 |
| --- | --- | --- | --- | --- | --- | --- | --- | --- | --- | --- | --- | --- | --- | --- | --- | --- | --- | --- | --- | --- | --- | --- | --- | --- | --- |
| 1 | 1 | **Version 2008 Dec 05** |  | 2660d? | 2000-01-01 A | 2010-03-12 | 89% | 290.36d? | 2000-01-03 | 2000-01-03 | 1d | 0d |  |  | 5204314h | 4443353h |  |  |  |  |  |  |  |  |  |
| 2 | 1.1 | "CTRL + a" to display all the 3GPP fields |  | 1d | 2000-01-03 | 2000-01-03 |  |  | 2000-01-03 | 2000-01-03 | 1d | 2659d | start no earlier than 2000-01-01 |  |  |  |  |  |  |  |  |  |  |  |  |
| 4 | 1.2 | Gantt: dark blue=done; light blue=to be done; grey: previous values; black=summary |  | 1d? | 2000-01-03 | 2000-01-03 |  |  | 2000-01-03 | 2000-01-03 | 1d? | 2659d | start no earlier than 2000-01-01 |  |  |  |  |  |  |  |  |  |  |  |  |
| 6 | 1.3 | Release 9 Features | milestone | 0d? | 2000-01-01 | 2000-01-01 |  |  | 2000-01-01 | 2000-01-01 | 0d? | 2660d |  | CP,GP,RP,SP |  |  | Rel-9 |  |  |  |  |  |  |  |  |
| 7 | 1.4 | **Services Alignment and Migration** |  | 467d? | 2006-12-06 A | 2008-09-18 A | 100% |  | 2006-12-06 | 2008-09-18 | 467d? |  |  | S1 | 7472h | 7472h | Rel-9 | ServAl | China Mobile | fenglingjuan@chinamobile.com | SP-33 | Alain |  |  |  |
| 8 | 1.4.1 | Stage 1 for ServAl |  | 467d? | 2006-12-06 A | 2008-09-18 A | 100% |  | 2006-12-06 | 2008-09-18 | 467d? |  | finish no earlier than 2008-12-11 | S1 | 3736h | 3736h | Rel-9 | ServAl | China Mobile | fenglingjuan@chinamobile.com | SP-33 | Alain | PCG-21 | 22.182 |  |
| 9 | 1.5 | **Registration in Densely-populated area (RED)** |  | 591d? | 2007-03-12 A | 2009-06-15 | 50% | 292.9d? | 2007-03-12 | 2009-06-15 | 591d? | 194d |  | S1,S2 | 8360h | 1864h | Rel-9 | RED | NTT DoCoMo | takakurat@s1.nttdocomo.co.jp | SP-35 | Alain |  | WID identifies also impacted CT1 24.008, RAN2 25.331 |  |
| 10 | 1.5.1 | Stage 1 for RED |  | 4d? | 2007-03-12 A | 2007-03-15 A | 100% |  | 2007-03-12 | 2007-03-15 | 4d? |  | start no earlier than 2007-03-12 | S1 | 32h | 32h | Rel-9 | RED | NTT DoCoMo | takakurat@s1.nttdocomo.co.jp | SP-35 | Alain |  | 22.101 (CR#0207) |  |
| 11 | 1.5.2 | Stage 2 for RED |  | 450d? | 2007-09-25 A | 2009-06-15 | 50% | 225d? | 2007-09-25 | 2009-06-15 | 450d? | 194d | finish no earlier than 2009-06-15 | S2 | 3600h | 1800h | Rel-9 | RED | NTT DoCoMo | tanakai@nttdocomo.co.jp | SP-37 | Maurice |  | 23.880, 23.002, 23.060, 23.221, 23.236 |  |
| 12 | 1.6 | **Deleted - End-User Identity** |  | 334d? | 2007-09-03 A | 2008-12-11 A | 100% |  | 2007-09-03 | 2008-12-11 | 334d? |  |  | S1 | 5344h | 5344h | Rel-9 | EUI | Nokia Siemens Networks | Joerg.Swetina@Siemens.com | SP-38 | Alain |  |  | SP-42 |
| 13 | 1.6.1 | Deleted - Stage 1 for EUI |  | 334d? | 2007-09-03 A | 2008-12-11 A | 100% |  | 2007-09-03 | 2008-12-11 | 334d? |  | finish no earlier than 2008-12-11 | S1 | 2672h | 2672h | Rel-9 | EUI | Nokia Siemens Networks | Joerg.Swetina@Siemens.com | SP-38 | Alain | PCG-21 | 21.905 | SP-42 |
| 14 | 1.7 | **Customized Ringing Signal** |  | 266d? | 2007-12-06 A | 2008-12-11 A | 100% |  | 2007-12-06 | 2008-12-11 | 266d? |  |  | S1 | 4256h | 4256h | Rel-9 | CRS | SK Telecom, China Mobile | Donghee Shim (SK Telecom), Jianping Zheng (China Mobile) | SP-38 | Alain | PCG-21 |  |  |
| 15 | 1.7.1 | Stage 1 for CRS |  | 266d? | 2007-12-06 A | 2008-12-11 A | 100% |  | 2007-12-06 | 2008-12-11 | 266d? |  | finish no earlier than 2008-12-11 | S1 | 2128h | 2128h | Rel-9 | CRS | SK Telecom, China Mobile | Donghee Shim (SK Telecom), Jianping Zheng (China Mobile) | SP-38 | Alain | PCG-21 | 22.183, 22.173 |  |
| 16 | 1.8 | **Public Warning System** |  | 266d? | 2007-12-06 A | 2008-12-11 A | 100% |  | 2007-12-06 | 2008-12-11 | 266d? |  |  | S1 | 4256h | 4256h | Rel-9 | PWS | T-Mobile | Mark.Younge@t-mobile.com | SP-38 | Alain | PCG-21 |  |  |
| 17 | 1.8.1 | Stage 1 for PWS |  | 266d? | 2007-12-06 A | 2008-12-11 A | 100% |  | 2007-12-06 | 2008-12-11 | 266d? |  | finish no earlier than 2008-12-11 | S1 | 2128h | 2128h | Rel-9 | PWS | T-Mobile | Mark.Younge@t-mobile.com | SP-38 | Alain | PCG-21 | 22.268 |  |
| 18 | 1.9 | **Network Selection for non-3GPP Access (move to Rel-10 SA#42 decision needed)** |  | 266d? | 2007-12-06 | 2008-12-11 |  |  | 2007-12-06 | 2008-12-11 | 266d? | 326d |  | S1,C6 | 5532.8h |  | Rel-10 | N3GtoNSP | Telefonica O2 | chris.friel@O2.com | SP-38 | Alain | PCG-21 |  |  |
| 19 | 1.9.1 | Stage 1 for N3GtoNSP |  | 266d? | 2007-12-06 | 2008-12-11 |  |  | 2007-12-06 | 2008-12-11 | 266d? | 326d | finish no earlier than 2008-12-11 | S1 | 2128h |  | Rel-10 | N3GtoNSP | Telefonica O2 | chris.friel@O2.com | SP-38 | Alain | PCG-21 | 22.011 |  |
| 20 | 1.9.2 | CT6 issues for N3GtoNSP |  | 266d? | 2007-12-06 | 2008-12-11 |  |  | 2007-12-06 | 2008-12-11 | 266d? | 326d | finish no earlier than 2008-12-11 | C6 | 2128h |  | Rel-10 | N3GtoNSP | Telefonica O2 | chris.friel@O2.com | SP-38 | Alain | PCG-21 | 22.234, 21.111, 31.101, 31.102, 31.103 |  |
| 21 | 1.10 | **Enhancements to Multimedia Priority Service** |  | 584d? | 2006-03-13 A | 2008-06-05 A | 100% |  | 2006-03-13 | 2008-06-05 | 584d? |  |  | S1 | 4672h | 4672h | Rel-9 | ePRIOR | Telcordia | jgarraha@telcordia.com | SP-39 | Alain | PCG-21 |  |  |
| 22 | 1.10.1 | Stage 1 for ePRIOR |  | 584d? | 2006-03-13 A | 2008-06-05 A | 100% |  | 2006-03-13 | 2008-06-05 | 584d? |  | start no earlier than 2006-03-12 | S1 | 4672h | 4672h | Rel-9 | ePRIOR | Telcordia | jgarraha@telcordia.com | SP-39 | Alain | PCG-21 | 22.153, 22.278 |  |
| 23 | 1.11 | **Support of Personal Area Networks and Enhancements to Personal Network Management** |  | 0d? | 2008-06-05 A | 2008-06-05 A | 100% |  | 2008-06-05 | 2008-06-05 | 0d? |  |  | S1 |  |  | Rel-9 | PANEPN | Vodafone | armin.toepfer@vodafone.com | SP-40 | Alain | PCG-21 |  |  |
| 24 | 1.11.1 | Stage 1 for PANEPN | milestone | 0d? | 2008-06-05 A | 2008-06-05 A | 100% |  | 2008-06-05 | 2008-06-05 | 0d? |  | finish no earlier than 2008-06-05 | S1 |  |  | Rel-9 | PANEPN | Vodafone | armin.toepfer@vodafone.com | SP-40 | Alain | PCG-21 | 22.259 |  |
| 25 | 1.12 | **Multi-Media Telephony Service enhancements** |  | 136d? | 2008-06-05 A | 2008-12-11 A | 100% |  | 2008-06-05 | 2009-03-12 | 201d? |  |  | S1 | 2176h | 2176h | Rel-9 | eMMTel | France Telecom | Philippe Lottin | SP-40 | Alain | PCG-21 |  |  |
| 26 | 1.12.1 | Stage 1 for eMMTel |  | 136d? | 2008-06-05 A | 2008-12-11 A | 100% |  | 2008-06-05 | 2009-03-12 | 201d? |  | start no earlier than 2008-06-05 | S1 | 1088h | 1088h | Rel-9 | eMMTel | France Telecom | Philippe Lottin | SP-40 | Alain | PCG-21 | 22.173 |  |

Notes:
- 7: SA#41 Stage 1 completed. Triggered by Study UID_370086 (FSServAl).
- 8: SA#41 completed
- 9: SA#35 Stage 1 completed. SA#40 SA2 moved to Rel-9.
- 10: SA#35 completed
- 11: SA#40 moved to Rel-9. SA#42 Target completion 09/08=>12/08=>06/09
- 12: SA#42 stopped (Reason: lack of interest)
- 13: SA#42 stopped (Reason: lack of interest)
- 14: SA#42 Stage 1 completed. SA#41 WID updated SP-070875=>SP-080502
- 15: SA#42 completed.
- 16: SA#42 Stage 1 completed. Larger scope than Rel-8 Feature UID_370051 (ETWS). Triggered by TR 22.968 Study UID_320025 (FS_PWS).
- 17: SA#42 completed.
- 18: SA#42 moved to Rel-10. Triggered by TR 22.912 Study UID_340033 (FS_N3GtoNSP) and TR 22.937 Study UID_340035 (FS_SMLSWLAN).
- 19: SA#42 moved to Rel-10
- 20: SA#42 moved to Rel-10
- 21: SA#40 Stage 1 completed. Continuation of Rel-8 Feature PRIOR UID_340044.
- 22: SA#39 WID approved. SA#40 completed
- 23: SA#40 WID approved & Stage 1 completed
- 24: SA#40 Stage 1 completed
- 25: SA#42 Stage 1 completed. SA#41 WID updated SP-080324=>SP-080503
- 26: SA#42 completed. SA#41 WID updated SP-080324=>SP-080503

| ID | WBS | Task | Duration | Start | Finish | Complete | Remaining | Baseline start | Baseline finish | Baseline duration | Total slack | Constraint | Resources | Work | Actual work | Text1 | Text2 | Text4 | Text5 | Text6 | Text7 | Text8 |
| --- | --- | --- | --- | --- | --- | --- | --- | --- | --- | --- | --- | --- | --- | --- | --- | --- | --- | --- | --- | --- | --- | --- |
| 27 | 1.13 | **User Data Convergence** | 201d? | 2008-06-05 A | 2009-03-12 A | 100% |  | 2008-06-05 | 2009-03-12 | 201d? |  |  | S1 | 3216h | 3216h | UDC | PCG-21 | China Mobile | lansizhong@chinamobile.com | Rel-9 | SP-40 | Alain |
| 28 | 1.13.1 | Stage 1 for UDC | 201d? | 2008-06-05 A | 2009-03-12 A | 100% |  | 2008-06-05 | 2009-03-12 | 201d? |  | start no earlier than 2008-06-05 | S1 | 1608h | 1608h | UDC | PCG-21 | China Mobile | lansizhong@chinamobile.com | Rel-9 | SP-40 | Alain |
| 29 | 1.14 | **Enhanced Home NodeB / eNodeB** | 399d? | 2008-06-05 A | 2009-12-15 | 11% | 353.92d? | 2008-06-05 | 2009-12-15 | 399d? | 63d |  | S1,S2,S5,RP | 11080h | 1251.84h | EHNB | PCG-21 | T-Mobile | Michael Kurz | Rel-9 | SP-40 | Alain |
| 30 | 1.14.1 | Stage 1 for EHNB | 136d? | 2008-06-05 A | 2008-12-11 | 70% | 40.8d? | 2008-06-05 | 2008-12-11 | 136d? | 326d | finish no earlier than 2008-12-11 | S1 | 1088h | 761.6h | EHNB | PCG-21 | T-Mobile | Michael Kurz | Rel-9 | SP-40 | Alain |
| 31 | 1.14.2 | Architecture aspects of EHNB | 324d? | 2008-09-18 A | 2009-12-15 | 5% | 307.8d? | 2008-09-18 | 2009-12-15 | 324d? | 63d | finish no earlier than 2009-12-15 | S2 | 2592h | 129.6h | EHNB | PCG-21 | T-Mobile | Sebastian Speicher | Rel-9 | SP-41 | Maurice |
| 32 | 1.14.3 | Home NodeB Gateway OAM | 261d? | 2008-12-11 | 2009-12-10 |  |  | 2008-12-11 | 2009-12-10 | 261d? | 66d | finish no earlier than 2009-12-10 | S5 | 2088h |  | EHNB-OAM_GW |  |  |  | Rel-9 |  | Dionisio |
| 33 | 1.14.4 | LTE FDD Home eNodeB RF Requirements | 265d? | 2008-12-05 | 2009-12-10 |  |  | 2008-12-05 | 2009-12-10 | 265d? | 66d | finish no earlier than 2009-12-10 | R4 | 2120h |  | EHNB-RF |  | Motorola | Ying Cai | Rel-9 |  |  |
| 34 | 1.15 | **Protection against Unsolicited Communication for IMS (PUCI)** | 196d? | 2008-09-18 A | 2009-06-18 | 28% | 142d? | 2008-09-18 | 2009-06-18 | 196d? | 191d |  | S1,S3 | 3624h | 998.36h | PUCI | PCG-21 | NEC | Anand R. Prasad | Rel-9 | SP-41 | Alain |
| 35 | 1.15.1 | Stage 1 for PUCI | 61d? | 2008-09-18 A | 2008-12-11 A | 100% |  | 2008-09-18 | 2009-06-18 | 196d? |  | finish no earlier than 2009-06-18 | S1 | 488h | 488h | PUCI | PCG-21 | NEC | Anand R. Prasad ( anand@bq.jp.nec.com) | Rel-9 | SP-41 | Alain |
| 36 | 1.15.2 | SA3 work on PUCI | 196d? | 2008-09-18 A | 2009-06-18 | 5% | 186.2d? | 2008-09-18 | 2009-06-18 | 196d? | 191d | finish no earlier than 2009-06-18 | S3 | 1568h | 78.4h | PUCI | PCG-21 | NEC | Anand R. Prasad ( anand@bq.jp.nec.com) | Rel-9 | SP-41 |  |
| 37 | 1.16 | **Network Improvements for Machine-type Communications (move to Rel-10 SA#42 decision needed)** | 196d? | 2008-09-18 A | 2009-06-18 | 25% | 147d? | 2008-09-18 | 2009-06-18 | 196d? | 191d |  | S1 | 3136h | 784h | NIMTC | PCG-21 | KPN | Toon Norp (toon.norp AT tno.nl) | Rel-10 | SP-41 | Alain |
| 38 | 1.16.1 | Stage 1 for NIMTC | 196d? | 2008-09-18 A | 2009-06-18 | 25% | 147d? | 2008-09-18 | 2009-06-18 | 196d? | 191d | finish no earlier than 2009-06-18 | S1 | 1568h | 392h | NIMTC | PCG-21 | KPN | Toon Norp (toon.norp AT tno.nl) | Rel-10 | SP-41 | Alain |
| 39 | 1.17 | **IMS Services Centralization and Continuity** | 196d? | 2008-09-18 A | 2009-06-18 | 35% | 127.21d? | 2008-09-18 | 2009-06-18 | 196d? | 191d |  | S1,S2 | 5192h | 1822.36h | IMSSCC | PCG-21 | NEC | Joerg Swetina (joerg.swetina@nw.neclab.eu) | Rel-9 | SP-41 | Alain |
| 40 | 1.17.1 | Inter-Device Transfer – Requirements | 61d? | 2008-09-18 A | 2008-12-11 A | 100% |  | 2008-09-18 | 2009-06-18 | 196d? |  | finish no earlier than 2009-06-18 | S1 | 488h | 488h | IMSSCC-IDT | PCG-21 | NEC | Joerg Swetina (joerg.swetina@nw.neclab.eu) | Rel-9 | SP-41 | Alain |
| 41 | 1.17.2 | IMS Service Continuity Enhancements: Service, Policy and Interactions | 196d? | 2008-09-18 A | 2009-06-18 | 20% | 156.8d? | 2008-09-18 | 2009-06-18 | 196d? | 191d | finish no earlier than 2009-06-18 | S2 | 1568h | 313.6h | IMSSCC-SPI | PCG-21 | Huawei | HengLiang Zhang (hl_zhang@huawei.com) | Rel-9 | SP-41 | Maurice |
| 42 | 1.17.3 | IMS Centralized Services | 196d? | 2008-09-18 A | 2009-06-18 | 30% | 137.2d? | 2008-09-18 | 2009-06-18 | 196d? | 191d | finish no earlier than 2009-06-18 | S2 | 1568h | 470.4h | IMSSCC-ICS | PCG-21 | Alcatel-Lucent | Andy Bennett (andybennett@alcatel-lucent.com) | Rel-9 | SP-41 | Maurice |
| 43 | 1.18 | **Enhancements of IMS Customized Alerting Tone (CAT) Service** | 261d? | 2008-12-05 | 2009-12-04 |  |  | 2008-12-05 | 2009-12-04 | 261d? | 70d |  | S1,C1 | 4176h |  | eCAT |  |  |  | Rel-9 |  | Alain |
| 44 | 1.18.1 | Stage 3 Enhancements of IMS CAT Supplementary Service | 261d? | 2008-12-05 | 2009-12-04 |  |  | 2008-12-05 | 2009-12-04 | 261d? | 70d | finish no earlier than 2009-12-04 | C1 | 2088h |  | eCAT-SS |  | China Mobile | Jiang Yi | Rel-9 |  | Frederic |
| 45 | 1.19 | **Service Specific Access Control in EPS** | 1d? | 2008-12-11 A | 2008-12-11 A | 100% |  |  |  |  |  |  | S1 | 16h | 16h | SSAC |  |  |  | Rel-9 |  |  |
| 46 | 1.19.1 | Stage 1 for SSAC | 1d? | 2008-12-11 A | 2008-12-11 A | 100% |  |  |  |  |  | start no earlier than 2008-12-11 | S1 | 8h | 8h | SSAC |  |  |  | Rel-9 |  |  |
| 47 | 1.20 | **Support for IMS Emergency Calls over GPRS and EPS** | 500d? | 2008-01-14 A | 2009-12-11 | 45% | 276.08d? | 2008-01-14 | 2009-12-11 | 500d? | 65d |  | S2,S1,RP | 13080h | 5596h | IMS_EMER_GPRS_EPS | PCG-21 | Alcatel-Lucent | Deborah Barclay | Rel-9 | SP-38 | Maurice |
| 48 | 1.20.1 | Stage 1 of IMS_EMER_GPRS_EPS | 239d? | 2008-01-14 A | 2008-12-11 | 80% | 47.8d? | 2008-01-14 | 2008-12-11 | 239d? | 326d | finish no earlier than 2008-12-11 | S1 | 1912h | 1529.6h | IMS_EMER_GPRS_EPS | PCG-21 | Alcatel-Lucent | Deborah Barclay | Rel-9 | SP-38 | Alain |
| 49 | 1.20.2 | Stage 2 of IMS_EMER_GPRS_EPS | 371d? | 2008-01-14 A | 2009-06-15 | 75% | 92.75d? | 2008-01-14 | 2009-06-15 | 371d? | 194d | finish no earlier than 2009-06-15 | S2 | 2968h | 2226h | IMS_EMER_GPRS_EPS | PCG-21 | Alcatel-Lucent | Deborah Barclay | Rel-9 | SP-38 | Maurice |
| 50 | 1.20.3 | SRVCC support for IMS Emergency Calls | 259d? | 2008-09-18 A | 2009-09-15 | 15% | 220.15d? | 2008-09-18 | 2009-09-15 | 259d? | 128d | finish no earlier than 2009-09-15 | S2 | 2072h | 310.8h | IMS_EMER_GPRS_EPS-SRVCC | PCG-21 | China Mobile | Yu Qing (Yuqing@chinamobile.com) | Rel-9 | SP-41 | Maurice |
| 51 | 1.20.4 | Positioning Support for LTE | 266d? | 2008-12-05 | 2009-12-11 |  |  | 2008-12-05 | 2009-12-11 | 266d? | 65d | finish no earlier than 2009-12-11 | R2,R4 | 2128h |  | IMS_EMER_EPS |  | Qualcomm | Nathan Tenny | Rel-9 |  |  |

Notes:
- 27: SA#42 Stage 1 completed. Triggered by SA5 Study Common Profile Storage (CPS) UID_320006 (OAM7-CPS) TR 32.808. Linked to End-User Identity (EUI) UID_370027
- 28: SA#42 completed / Text3: 22.985, 22.101
- 29: SA#42 SA1 Rel-9 extension to 03/09. Continuation of Rel-8 Feature Home NodeB / eNodeB (HomeNB) UID_380065.
- 30: SA#42 Rel-9 extension to 03/09 / Text3: 22.220, 22.011
- 31: SA#42 completion target 06/09=>12/09 / Text3: 23.8xy (Architecture Aspec of HNB/HeNB), 23.401, 23.402, 23.060
- 33: Text3: 36.104, 36.141
- 34: SA#42 Stage 1 completed. SA#41 SA3 WID approved (Stage 1 commitment in SA1 LS in SP-080523). Check related work in OMA Categorization Based Content Screening
- 35: SA#42 completed / Text3: 22.228
- 36: Text3: 33.8xx (Study of Mechanisms to prevent unsolicited Communication)
- 37: SA#42 moved to Rel-10
- 38: SA#42 moved to Rel-10 / Text3: 22.368
- 39: SA#42 Stage 1 completed.
- 40: SA#42 completed / Text3: 22.101, 22.228
- 41: Text3: 23.838 (IMS Service Continuity Enhancemen: Service, Policy and Interactions), 23.237, 23.292, 23.216
- 42: Text3: 23.8xy (Study on Service Data Synchronization for IMS Cenalized Services), 23.292
- 43: CT#42 umbrella Feature created to host CT1 CAT WI (Stage 1 in 22.182)
- 44: Enhance IMS CAT Supplementary Service as defined in 22.182 and TR 23.872 / Text3: 24.182
- 45: SA#42 Stage 1 completed. Triggered by Study UID_400036 on Service Specific Access Control in EPS (SSAC)
- 46: SA#42 completed
- 47: SA#40 updated WID SP-070820=>SP-080352. SA#41 Target completion 09/08=>12/08
- 48: SA#41 completion target 09/08=>12/08. SA#41 record created to cover SA1 Stage 1 work / Text3: 22.101
- 49: SA#42 completion target 09/08=>12/08=>06/09. SA#41 record created to cover SA2 work. / Text3: 23.869, 23.060, 23.167, 23.228, 23.271, 23.203, 23.401, 23.402, 23.221
- 50: SA#42 completion target 06/09=>09/09 / Text3: 23.8bc (Solutions of SRVCC support for IMS Emergency Calls), 23.216, 23.237
- 51: UID_400038 (LCS Control Plane Solution for EPS) depends on this WI / Text3: 36.300, 36.331, 36.413, 36.133 (Add performance requirements for downlink terrestrial positioning), 36.214, possibly 3 new TS 36.xxx (UE positioning in E-UTRAN/ LTE Positioning Protocol/ RAN4 Requirements for Support of A-GNSS)

| ID | WBS | Task | Duration | Start | Finish | Complete | Remaining | Baseline start | Baseline finish | Baseline duration | Total slack | Constraint | Resources | Work | Actual work | Text1 | Text2 | Text4 | Text5 | Text6 | Text7 | Text8 |
| --- | --- | --- | --- | --- | --- | --- | --- | --- | --- | --- | --- | --- | --- | --- | --- | --- | --- | --- | --- | --- | --- | --- |
| 52 | 1.21 | **LCS Control Plane Solution for EPS** | 266d? | 2008-06-05 A | 2009-06-11 | 25% | 199.5d? | 2008-06-05 | 2009-06-11 | 266d? | 196d |  | S2 | 4256h | 1064h | LCS_CPS_EPS | PCG-21 | Polaris Wireless | Robert Gross | Rel-9 | SP-40 | Maurice |
| 53 | 1.21.1 | Stage 2 for LCS_CPS_EPS | 266d? | 2008-06-05 A | 2009-06-11 | 25% | 199.5d? | 2008-06-05 | 2009-06-11 | 266d? | 196d | finish no earlier than 2009-06-11 | S2 | 2128h | 532h | LCS_CPS_EPS | PCG-21 | Polaris Wireless | Robert Gross | Rel-9 | SP-40 | Maurice |
| 54 | 1.22 | Harmonization of Gq'/Rx for Common IMS | 502d? | 2008-01-14 A | 2009-12-15 | 25% | 376.5d? | 2008-01-14 | 2009-12-15 | 502d? | 63d | finish no earlier than 2009-12-15 | S2 | 4016h | 1004h | IMS_Comm_GqRx_Harm | PCG-21 | Alcatel-Lucent | geoffrey.cristallo@alcatel-lucent.be | Rel-9 | SP-38 | Maurice |
| 55 | 1.23 | **MBMS support in EPS** | 266d? | 2008-06-05 | 2009-06-11 |  |  | 2008-06-05 | 2009-06-11 | 266d? | 196d |  | S2 | 4256h |  | MBMS_EPS | PCG-21 | China Mobile | Liu Hong (liuhongyfw@chinamobile.com) | Rel-9 | SP-40 | Maurice |
| 56 | 1.23.1 | Stage 2 for MBMS_EPS | 266d? | 2008-06-05 | 2009-06-11 |  |  | 2008-06-05 | 2009-06-11 | 266d? | 196d | finish no earlier than 2009-06-11 | S2 | 2128h |  | MBMS_EPS | PCG-21 | China Mobile | Liu Hong (liuhongyfw@chinamobile.com) | Rel-9 | SP-40 | Maurice |
| 57 | 1.24 | Access Security Enhancements | 509d? | 2007-07-02 A | 2009-06-11 | 60% | 205.8d? | 2007-07-02 | 2009-06-11 | 509d? | 196d | finish no earlier than 2009-06-11 | S3 | 4072h | 2425.6h | ACCSEC2 |  | Ericsson | Bengt.Sahlin@ericsson.com | Rel-9 |  | Dionisio |
| 58 | 1.25 | **OAM&P 9** | 1d? | 2000-01-03 A | 2000-01-03 |  | 1d? | 2000-01-03 | 2000-01-03 | 1d? | 2659d |  | S5 | 40h | 8h | OAM9 |  |  |  | Rel-9 |  | Dionisio |
| 59 | 1.25.1 | **Network Infrastructure Management** | 1d? | 2000-01-03 A | 2000-01-03 |  | 1d? | 2000-01-03 | 2000-01-03 | 1d? | 2659d |  | S5 | 16h | 8h | OAM9-NIM |  |  |  | Rel-9 |  |  |
| 60 | 1.25.1.1 | Software Management | 1d? | 2000-01-03 | 2000-01-03 |  |  | 2000-01-03 | 2000-01-03 | 1d? | 2659d |  | S5 | 8h |  |  |  |  |  | Rel-9 |  |  |
| 61 | 1.25.2 | Performance Management | 1d? | 2000-01-03 | 2000-01-03 |  |  | 2000-01-03 | 2000-01-03 | 1d? | 2659d |  | S5 | 8h |  | OAM9-PM |  |  |  | Rel-9 |  |  |
| 62 | 1.25.3 | Trace | 1d? | 2000-01-03 | 2000-01-03 |  |  | 2000-01-03 | 2000-01-03 | 1d? | 2659d |  | S5 | 8h |  | OAM9-Trace |  |  |  | Rel-9 |  |  |
| 63 | 1.26 | Definition of 3GPP UICC services over the new high-speed interface | 525d? | 2007-12-10 A | 2009-12-11 | 15% | 446.25d? | 2007-12-10 | 2009-12-11 | 525d? | 65d | finish no earlier than 2009-12-11 | C6 | 4200h | 630h | UICCHS | PCG-21 | Gemalto | jacques.seif@gemalto.com | Rel-9 | CP-38 | Xavier |
| 64 | 1.27 | LTE enhancements | 206d? | 2000-01-03 | 2000-10-16 |  |  | 2008-12-05 | 2009-09-18 | 206d? | 2454d |  | RP,SP,CP | 1648h |  | eLTE |  |  |  | Rel-9 |  |  |
| 65 | 1.28 | **LTE – Terminal Conformance Test Specification** | 266d? | 2008-12-05 | 2009-12-11 |  |  | 2008-12-05 | 2009-12-11 | 266d? | 65d |  | R5 | 3904h |  | LTE-UEConTest |  |  |  | Rel-9 |  | Ingbert |
| 66 | 1.28.1 | Conformance Test Aspects – LTE 3500 | 266d? | 2008-12-05 | 2009-12-11 |  |  | 2008-12-05 | 2009-12-11 | 266d? | 65d | finish no earlier than 2009-12-11 | R5 | 2128h |  | LTE_UEConTest_LTE3500 |  | Ericsson | fredrik.sundstrom@ericsson.com | Rel-9 |  |  |
| 67 | 1.29 | **Rel-9 Improvements of the Radio Interface** | 391d? | 2008-09-12 A | 2010-03-12 | 6% | 367.73d? | 2008-09-12 | 2010-03-12 | 391d? | 0d |  | RP,GP | 14851.6h | 796.04h | RInImp9 | PCG-21 |  |  | Rel-9 | RP-41 | Juergen |
| 68 | 1.29.1 | LCR TDD UE OTA Performance Requirements | 131d? | 2008-09-12 A | 2009-03-13 | 5% | 124.45d? | 2008-09-12 | 2009-03-13 | 131d? | 260d | finish no earlier than 2009-03-13 | R4 | 1048h | 52.4h | RInImp9-RFLCROTA | PCG-21 | RITT | Wu Xiang wuxiang@chinattl.com | Rel-9 | RP-41 |  |
| 69 | 1.29.2 | UMTS 1880 MHz TDD | 195d? | 2008-09-12 A | 2009-06-11 | 20% | 156d? | 2008-09-12 | 2009-06-11 | 195d? | 196d | start no earlier than 2008-09-12 | R4 | 1560h | 312h | RInImp9-UMTS1880TDD | PCG-21 | CATT | Yuexia Song (songyuexia@datangmobile.cn) | Rel-9 | RP-41 |  |
| 70 | 1.29.3 | **RF requirements for Multicarrier and Multi-RAT BS** | 391d? | 2008-09-12 A | 2010-03-12 | 3% | 379.28d? | 2008-09-12 | 2010-03-12 | 391d? | 0d |  | R4,G1 | 8187.6h | 245.5h | RInImp9-RFmulti | PCG-21 | Ericsson | Johan Sköld | Rel-9 | RP-41 |  |
| 71 | 1.29.3.1 | RAN4 part of RF requirements for Multicarrier and Multi RAT BS | 391d? | 2008-09-12 A | 2010-03-12 | 5% | 371.45d? | 2008-09-12 | 2010-03-12 | 391d? | 0d | finish no earlier than 2010-03-12 | R4 | 3128h | 156.4h | RInImp9-RFmulti |  | Ericsson | Johan Sköld | Rel-9 |  |  |
| 72 | 1.29.3.2 | GERAN part of RF requirements for Multicarrier and Multi RAT BS | 261d? | 2008-11-21 | 2009-11-20 |  |  | 2008-11-21 | 2009-11-20 | 261d? | 80d | finish no earlier than 2009-11-20 | G1 | 2088h |  | RInImp9-Rfmulti-GERAN |  | Ericsson | Mats Samuelsson | Rel-9 |  |  |
| 73 | 1.29.4 | Extended UMTS/LTE 800 | 116d? | 2008-12-05 | 2009-05-15 |  |  | 2008-12-05 | 2009-05-15 | 116d? | 215d | finish no earlier than 2009-05-15 | R4 | 928h |  | RInImp9-UMTSLTE800 |  | NTT DoCoMo | Shingo Suwa | Rel-9 |  |  |
| 74 | 1.30 | **Rel-9 RAN improvements** | 266d? | 2008-12-05 | 2009-12-11 |  |  | 2008-12-05 | 2009-12-11 | 266d? | 65d |  | RP | 4256h |  | RANimp |  |  |  | Rel-9 |  | Ingbert |
| 75 | 1.30.1 | UTRAN 2 ms TTI uplink range improvement | 266d? | 2008-12-05 | 2009-12-11 |  |  | 2008-12-05 | 2009-12-11 | 266d? | 65d | finish no earlier than 2009-12-11 | R1 | 2128h |  | RANimp-UplinkTTI |  | Nokia Siemens Networks | karri.ranta-aho@nsn.com | Rel-9 |  |  |

Notes:
- 52: Triggered by abandoned Study UID_380068 (FS_LCS_EPS). Linked to Feature IMS_EMER_GPRS_EPS UID_380064.
- 53: SA#40 WID approved. / Text3: 23.891, 23.271, 23.401, 23.402
- 54: WID approved SA#38. per OPs & ETSI GA 39. This is a joint effort of SA2 and TISPAN2. SA#40 moved to Rel-9. SA#41: Lack of input/work stagnating. SA#42 Target completion 09/08=>12/08=>12/09 / Text3: 23.822, 23.203
- 55: SA#40 WID approved.
- 56: SA#40 WID approved. / Text3: 23.246
- 57: SA#42 moved to Rel-9. SA#26 approved WID (about improved GERAN security). SA#38 moved to Rel-8. SA#41: Low priority target completion Jun 2009. / Text3: 33.102, 43.020
- 58: SA#42 umbrella Feature created to host OAM WIs
- 59: SA#42 umbrella BB created to host OAM WIs
- 61: SA#42 umbrella BB created to host OAM WIs
- 62: SA#42 umbrella BB created to host OAM WIs
- 63: CT#42 moved to Rel-9 / Text3: 31.XYZ
- 65: Testing for Feature UID_20068 (LTE)
- 66: RP#42 WID approved. Testing for UID_380073 / Text3: 36.508, 36.521-1, 36.521-2, 36.521-3
- 67: RP#41 umbrella Feature created to host Rel-9 WIs
- 68: SR in RP-081086 / Text3: 25.8xy (LCR TDD UE OTA performance requiremen)
- 69: SR in RP-080801 / Text3: 25.102, 25.105, 25.113, 25.123, 25.142, 34.124, 25.307
- 70: SR in RP-080802. RP#42 WID updated RP-080758=>RP-081098
- 71: SR in RP-080802. RP#42 WID updated RP-080758=>RP-081098 / Text3: 25.104, 25.105, 36.104, 45.005, XX.YYa (E-UA, UA and GSM/EDGE; Multi-Standard Radio (MSR) BS radio transmission and reception), XX.Yybb (BS conformance testing), XX.Yyc (RF requirements for Multicarrier and Multi-RAT BS)
- 72: GP#40 WID approved / Text3: 45.005, 51.021
- 73: Text3: 25.101, 25.104, 25.113, 25.133, 25.141, 34.124, 25.306, 25.307, 25.331, 25.461, 25.466, 36.101, 36.104, 36.113, 36.124, 36.133, 36.141, 36.331
- 74: 05/08: Linked to Feature UID_20029 (RANimp)
- 75: Text3: 25.212, 25.214, 25.321, 25.331, 25.133

| ID | WBS | Task | Type | Duration | Start | Finish | Complete | Remaining | Baseline start | Baseline finish | Baseline duration | Total slack | Constraint | Resources | Work | Actual work | Text1 | Text6 | Text8 | Text2 | Text4 | Text7 | Text12 |
| --- | --- | --- | --- | --- | --- | --- | --- | --- | --- | --- | --- | --- | --- | --- | --- | --- | --- | --- | --- | --- | --- | --- | --- |
| 76 | 1.31 | **Rel-9 RAN improvements - UE Conformance Testing** |  | 326d? | 2008-09-12 A | 2009-12-11 | 1% | 322.43d? | 2008-09-12 | 2009-12-11 | 326d? | 65d |  | R5 | 7339.6h | 52.4h | RANimp-UEConTest | Rel-9 | Ingbert |  |  |  |  |
| 77 | 1.31.1 | Conformance Test Aspects – Combination of 64QAM and MIMO for HSDPA (FDD) |  | 131d? | 2008-09-12 A | 2009-03-13 | 5% | 124.45d? | 2008-09-12 | 2009-03-13 | 131d? | 260d | start no earlier than 2008-09-12 | R5 | 1048h | 52.4h | RANimp-UEConTest_64QamMimoHsdpa | Rel-9 | Ingbert | PCG-21 | Ericsson | RP-41 |  |
| 78 | 1.31.2 | Conformance Test Aspects – UMTS 3500 |  | 266d? | 2008-12-05 | 2009-12-11 |  |  | 2008-12-05 | 2009-12-11 | 266d? | 65d | finish no earlier than 2009-12-11 | R5 | 2128h |  | RANimp-UEConTest_UMTS3500 | Rel-9 |  |  | Nokia |  |  |
| 79 | 1.31.3 | Conformance Test Aspects – Dual-Cell HSDPA operation on adjacent carriers |  | 201d? | 2008-12-05 | 2009-09-11 |  |  | 2008-12-05 | 2009-09-11 | 201d? | 130d | finish no earlier than 2009-09-11 | R5 | 1608h |  | RANimp-UEConTest_DCHSDPA | Rel-9 |  |  | Qualcomm |  |  |
| 80 | 1.32 | **Self-Organizing Networks (SON)** |  | 471d? | 2008-02-22 A | 2009-12-11 | 26% | 350.6d? | 2008-02-22 | 2009-12-11 | 471d? | 65d |  | R3,S5 | 9664h | 2470.42h | SON | Rel-9 | Dionisio |  |  |  |  |
| 81 | 1.32.1 | SON Features |  | 266d? | 2008-12-05 | 2009-12-11 |  |  | 2008-12-05 | 2009-12-11 | 266d? | 65d | start no earlier than 2008-12-05 | R3 | 2128h |  | SON | Rel-9 |  |  | Nokia Siemens Networks |  |  |
| 82 | 1.32.2 | SON Self-Optimization & Self-Healing handling |  | 471d? | 2008-02-22 A | 2009-12-11 | 40% | 282.6d? | 2008-02-22 | 2009-12-11 | 471d? | 65d |  | S5 | 3768h | 1507.2h | LTE_SON-OAM | Rel-9 | Dionisio | PCG-21 | Huawei | SP-39 |  |
| 83 | 1.33 | **Voice services over Adaptive Multi-user channels on One Slot** |  | 261d? | 2008-11-21 | 2009-11-20 |  |  | 2008-11-21 | 2009-11-20 | 261d? | 80d |  | GP | 6952h |  | VAMOS | Rel-9 | Paolo |  | Nokia Siemens Networks, China Mobile |  |  |
| 84 | 1.33.1 | VAMOS Stage 2 |  | 126d? | 2008-11-21 | 2009-05-15 |  |  | 2008-11-21 | 2009-05-15 | 126d? | 215d | finish no earlier than 2009-05-15 | GP | 1008h |  | VAMOS | Rel-9 |  |  | Nokia Siemens Networks, China Mobile |  |  |
| 85 | 1.33.2 | VAMOS Stage 3 |  | 221d? | 2008-11-21 | 2009-09-25 |  |  | 2008-11-21 | 2009-09-25 | 221d? | 120d | finish no earlier than 2009-09-25 | GP | 1768h |  | VAMOS | Rel-9 |  |  | Nokia Siemens Networks, China Mobile |  |  |
| 86 | 1.33.3 | VAMOS Radio Performance Requirements |  | 261d? | 2008-11-21 | 2009-11-20 |  |  | 2008-11-21 | 2009-11-20 | 261d? | 80d | finish no earlier than 2009-11-20 | GP | 2088h |  | VAMOS | Rel-9 |  |  | Nokia Siemens Networks, China Mobile |  |  |
| 87 | 1.34 | (Small) Technical Enhancements and Improvements for Rel-9 |  | 391d? | 2008-09-12 | 2010-03-12 |  |  | 2008-09-12 | 2010-03-12 | 391d? | 0d | finish no earlier than 2010-03-12 | All | 3128h |  | TEI9 | Rel-8 |  | N/A | ALL | N/A |  |
| 88 | 1.35 | **Deleted - SAES Enhancements (non RAN aspects)** |  | 381d? | 2007-06-25 A | 2008-12-08 A | 100% |  | 2007-06-25 | 2008-12-08 | 381d? |  |  | S2 | 11664h | 11664h | SAES_Ph2 | Rel-9 | Maurice | PCG-21 | Nokia Siemens Networks | SP-39 | SP-39 |
| 89 | 1.35.1 | Deleted - Functions and procedures for SAE to support LTE MBMS |  | 381d? | 2007-06-25 A | 2008-12-08 A | 100% |  | 2007-06-25 | 2008-12-08 | 381d? |  | finish no earlier than 2008-12-08 | S2 | 3048h | 3048h | SAES_Ph2 | Rel-9 | Maurice |  |  |  | SP-39 |
| 90 | 1.35.2 | Deleted - CS over EPS |  | 194d? | 2008-03-12 A | 2008-12-08 A | 100% |  | 2008-03-12 | 2008-12-08 | 194d? |  | finish no earlier than 2008-12-08 | S2 | 1552h | 1552h | SAES_Ph2 | Rel-9 | Maurice | PCG-21 |  | SP-39 | SP-39 |
| 91 | 1.35.3 | **Deleted - SAE for generic support for non-3GPP accesses** |  | 251d? | 2007-06-25 A | 2008-06-09 A | 100% |  | 2007-06-25 | 2008-06-09 | 251d? |  |  | S2 | 4016h | 4016h | SAES_Ph2 | Rel-9 | Maurice | PCG-21 |  | SP-39 | SP-39 |
| 92 | 1.35.3.1 | Deleted - Single Radio Aspects of SAE for Optimized Handover with WiMAX |  | 251d? | 2007-06-25 A | 2008-06-09 A | 100% |  | 2007-06-25 | 2008-06-09 | 251d? |  | finish no earlier than 2008-06-09 | S2 | 2008h | 2008h | SAES_Ph2 | Rel-9 | Maurice | PCG-21 |  | SP-39 | SP-39 |
| 93 | 1.36 | Deleted - Support of WiMAX - LTE Mobility |  | 406d? | 2008-06-06 A | 2009-12-25 A | 100% |  | 2008-06-06 | 2009-12-25 | 406d? |  | start no earlier than 2008-06-06 | R2 | 3248h | 3248h | WiMAX_LTE_Mobility | Rel-9 | Joern | PCG-21 | Samsung | RP-38 | SP-39 |
| 94 | 1.37 | Deleted - Support of WiMAX - UMTS Mobility |  | 406d? | 2008-06-06 A | 2009-12-25 A | 100% |  | 2008-06-06 | 2009-12-25 | 406d? |  | start no earlier than 2008-06-06 | R2 | 3248h | 3248h | WiMAX_UMTS_Mobility | Rel-9 | Joern | PCG-21 | Intel | RP-38 | SP-39 |
| 95 | 1.38 | Release 9 Feasibility Studies | milestone | 0d? | 2008-03-20 | 2008-03-20 |  |  | 2008-03-20 | 2008-03-20 | 0d? | 516d | finish no earlier than 2008-03-20 | CP,GP,RP,SP |  |  |  | Rel-9 |  |  |  |  |  |
| 96 | 1.39 | **Study on enhanced voice service requirements for the EPS** |  | 459d? | 2007-09-03 A | 2009-06-04 | 51% | 225.39d? | 2007-09-03 | 2009-06-04 | 459d? | 201d |  | S1,S4 | 10016h | 5097.68h | FS_EV_EPS | Rel-9 | Alain |  | Orange | SP-37 |  |
| 97 | 1.39.1 | Use cases definition and service and system requirements |  | 334d? | 2007-09-03 A | 2008-12-11 A | 100% |  | 2007-09-03 | 2008-12-11 | 334d? |  | finish no earlier than 2008-12-11 | S1 | 2672h | 2672h | FS_EV_EPS-S1 | Rel-9 | Alain |  | Orange | SP-37 |  |
| 98 | 1.39.2 | Codec specific part of FSEV_EPS |  | 459d? | 2007-09-03 A | 2009-06-04 | 15% | 389.4d? | 2007-09-03 | 2009-06-04 | 459d? | 201d | finish no earlier than 2009-06-04 | S4 | 3672h | 556.8h | FS_EV_EPS-S4 | Rel-9 | Paolo |  | Orange | SP-37 |  |
| 99 | 1.40 | Study on advanced requirements for IP interconnect |  | 333d? | 2007-12-04 A | 2009-03-12 | 8% | 306.36d? | 2007-12-04 | 2009-03-12 | 333d? | 261d | finish no earlier than 2009-03-12 | S1 | 2664h | 213.12h | FS_IPXS | Rel-9 | Alain | PCG-21 | Telefonica O2 | SP-38 |  |
| 100 | 1.41 | Study on Service Specific Access Control in EPS |  | 136d? | 2008-06-05 A | 2008-12-11 A | 100% |  | 2008-06-05 | 2009-03-12 | 201d? |  | start no earlier than 2008-06-05 | S1 | 1088h | 1088h | FS_SSAC | Rel-9 | Alain | PCG-21 | NTT DoCoMo | SP-40 |  |
| 101 | 1.42 | Study on Unauthenticated PS Emergency Calls |  | 201d? | 2008-06-05 A | 2009-03-12 | 20% | 160.8d? | 2008-06-05 | 2009-03-12 | 201d? | 261d | start no earlier than 2008-06-05 | S1 | 1608h | 321.6h | FS_UAPSEC | Rel-9 | Alain | PCG-21 | Nokia Siemens Networks | SP-40 |  |
| 102 | 1.43 | Study on Personal Broadcast Service |  | 126d? | 2008-09-18 A | 2009-03-12 | 30% | 88.2d? | 2008-09-18 | 2009-03-12 | 126d? | 261d | finish no earlier than 2009-03-12 | S1 | 1008h | 302.4h | FS_PBS | Rel-9 |  | PCG-21 | ETRI | SP-41 |  |
| 103 | 1.44 | Study on LCS support in SAE for non-3GPP accesses |  | 126d? | 2008-09-18 A | 2009-03-12 | 10% | 113.4d? | 2008-09-18 | 2009-03-12 | 126d? | 261d | finish no earlier than 2009-03-12 | S1 | 1008h | 100.8h | FS_LCS_n3GPP | Rel-9 |  | PCG-21 | SK Telecom | SP-41 |  |
| 104 | 1.45 | Study on CS Domain Services over EPS access |  | 493d? | 2007-04-25 A | 2009-03-13 | 70% | 147.9d? | 2007-04-25 | 2009-03-13 | 493d? | 260d | finish no earlier than 2009-03-13 | S2 | 3944h | 2760.8h | FS_CSoPS | Rel-9 | Maurice |  | T-Mobile | SP-35 |  |
| 105 | 1.46 | Study on Extended Support of IMS Emergency Calls |  | 319d? | 2007-09-24 A | 2008-12-11 A | 100% |  | 2007-09-24 | 2008-12-11 | 319d? |  | finish no earlier than 2009-06-18 | S2 | 2552h | 2552h | FS_IMS-eCall | Rel-9 | Maurice |  | Qualcomm | SP-37 |  |
| 106 | 1.47 | Study on System enhancements for the use of IMS services in local breakout and optimal routing of media |  | 512d? | 2007-10-01 A | 2009-09-15 | 30% | 358.4d? | 2007-10-01 | 2009-09-15 | 512d? | 128d | finish no earlier than 2009-09-15 | S2 | 4096h | 1228.8h | FS_IMS_LBO_ORM | Rel-9 | Maurice |  | Telecom Italia, BT | SP-37 |  |
| 107 | 1.48 | Study on Intra Domain Connection of RAN Nodes to Multiple CN Nodes |  | 329d? | 2008-03-12 A | 2009-06-15 | 30% | 230.3d? | 2008-03-12 | 2009-06-15 | 329d? | 194d | finish no earlier than 2009-06-15 | S2 | 2632h | 789.6h | FS_IDC | Rel-9 | Maurice | PCG-21 | China Mobile | SP-39 |  |
| 108 | 1.49 | Study on IMS Evolution |  | 261d? | 2008-09-18 A | 2009-09-17 | 15% | 221.85d? | 2008-09-18 | 2009-09-17 | 261d? | 126d | finish no earlier than 2009-09-17 | S2 | 2088h | 313.2h | FS_eIMS | Rel-9 |  | PCG-21 | China Mobile | SP-41 |  |
| 109 | 1.50 | Study on enhancements to IMS border functions for IMS Interconnection of services |  | 196d? | 2008-09-18 A | 2009-06-18 | 15% | 166.6d? | 2008-09-18 | 2009-06-18 | 196d? | 191d | finish no earlier than 2009-06-18 | S2 | 1568h | 235.2h | FS_eIMS_IBCF | Rel-9 |  | PCG-21 | Telefónica | SP-41 |  |
| 110 | 1.51 | Study on Multi Access PDN connectivity and IP flow mobility |  | 196d? | 2008-09-18 A | 2009-06-18 | 40% | 117.6d? | 2008-09-18 | 2009-06-18 | 196d? | 191d | finish no earlier than 2009-06-18 | S2,S1 | 1568h | 627.2h | FS_MAPIM | Rel-9 |  | PCG-21 | Qualcomm | SP-41 |  |
| 111 | 1.52 | Study on Service Continuity for Emergency Voice Calls |  | 721d? | 2006-06-08 A | 2009-03-12 | 85% | 108.15d? | 2006-06-08 | 2009-03-12 | 721d? | 261d | finish no earlier than 2009-03-12 | S2 | 5768h | 4902.8h | FS_VCCEm | Rel-9 | Maurice |  | Nortel |  |  |
| 112 | 1.53 | Study on Protection against SMS and MMS spam |  | 652d? | 2006-06-08 A | 2008-12-05 | 30% | 456.4d? | 2006-06-08 | 2008-12-05 | 652d? | 330d | finish no earlier than 2008-12-05 | S3 | 5216h | 1564.8h | FS_CPSMal | Rel-9 | Dionisio |  | Orange |  |  |
| 113 | 1.54 | Study on Remote management of USIM application on M2M Equipment |  | 387d? | 2007-09-19 A | 2009-03-12 | 65% | 135.45d? | 2007-09-19 | 2009-03-12 | 387d? | 261d | finish no earlier than 2009-03-12 | S3 | 3096h | 2012.4h | FS_UM2M | Rel-9 | Dionisio |  | Ericsson | SP-37 |  |
| 114 | 1.55 | Study on UTRAN key management enhancements |  | 321d? | 2007-12-20 A | 2009-03-12 | 20% | 256.8d? | 2007-12-20 | 2009-03-12 | 321d? | 261d | finish no earlier than 2009-03-12 | S3 | 2568h | 513.6h | FS_UKM | Rel-9 | Dionisio | PCG-21 | Ericsson | SP-38 |  |
| 115 | 1.56 | Study on Home (e)NodeB Security |  | 321d? | 2007-12-20 A | 2009-03-12 | 75% | 80.25d? | 2007-12-20 | 2009-03-12 | 321d? | 261d | finish no earlier than 2009-03-12 | S3 | 2568h | 1926h | FS_HNB_Sec | Rel-9 | Dionisio | PCG-21 | Huawei | SP-38 |  |
| 116 | 1.57 | Study on System Maintenance over Itf-N |  | 657d? | 2007-06-07 A | 2009-12-11 | 70% | 197.1d? | 2007-06-07 | 2009-12-11 | 657d? | 65d | finish no earlier than 2009-12-11 | S5 | 5256h | 3679.2h | FS_OAM-Maint-Itf-N | Rel-9 | Dionisio |  | ZTE |  |  |
| 117 | 1.58 | Study on Self-Organizing Networks (SON) related OAM interfaces for Home NodeB |  | 657d? | 2007-06-07 A | 2009-12-11 | 70% | 197.1d? | 2007-06-07 | 2009-12-11 | 657d? | 65d | finish no earlier than 2009-12-11 | S5 | 5256h | 3679.2h | FS_OAM-SON-HNB | Rel-9 | Dionisio |  | Huawei |  |  |
| 118 | 1.59 | Study on Self-healing of Self-Organizing Networks (SON) |  | 471d? | 2008-02-22 A | 2009-12-11 | 40% | 282.6d? | 2008-02-22 | 2009-12-11 | 471d? | 65d | finish no earlier than 2009-12-11 | S5 | 3768h | 1507.2h | FS_OAM-SON-SH | Rel-9 | Dionisio | PCG-21 | ZTE | SP-39 |  |
| 119 | 1.60 | Study on Service Oriented Architecture (SOA) for IRP |  | 397d? | 2008-06-05 A | 2009-12-11 | 15% | 337.45d? | 2008-06-05 | 2009-12-11 | 397d? | 65d | finish no earlier than 2009-12-11 | S5 | 3176h | 476.4h | FS_OAM_SOA_IRP | Rel-9 | Dionisio | PCG-21 | Ericsson | SP-40 |  |
| 120 | 1.61 | Study on Rc Reference Point Functionalities and Message Flows |  | 322d? | 2008-09-18 A | 2009-12-11 | 20% | 257.6d? | 2008-09-18 | 2009-12-11 | 322d? | 65d | finish no earlier than 2009-12-11 | S5 | 2576h | 515.2h | FS_OAM_Rc | Rel-9 |  | PCG-21 | Huawei | SP-41 |  |
| 121 | 1.62 | Study on UE Management |  | 262d? | 2008-12-11 | 2009-12-11 |  |  | 2008-12-11 | 2009-12-11 | 262d? | 65d | finish no earlier than 2009-12-11 | S5 | 2096h |  | FS_UE_mgmt | Rel-9 |  |  |  |  |  |
| 122 | 1.63 | Study on Evaluation of the inclusion of Path Loss Based Technology in the UTRAN |  | 325d? | 2007-12-17 A | 2009-03-13 | 25% | 243.75d? | 2007-12-17 | 2009-03-13 | 325d? | 260d | finish no earlier than 2009-03-13 | R4 | 2600h | 650h | FS_RAN-Pathloss | Rel-9 | Stefania | PCG-21 | Polaris Wireless | RP-38 |  |
| 123 | 1.64 | Study on LTE-Advanced |  | 326d? | 2008-06-13 A | 2009-09-11 | 30% | 228.2d? | 2008-06-13 | 2009-09-11 | 326d? | 130d | finish no earlier than 2009-09-11 | R1 | 2608h | 782.4h | FS_RAN_LTEA | Rel-9 | Patrick | PCG-21 | NTT DoCoMo | RP-39 |  |
| 124 | 1.65 | Study on 1.28 Mcps TDD Home NodeB |  | 251d? | 2008-02-20 A | 2009-05-29 | 20% | 200.8d? | 2008-02-20 | 2009-05-29 | 251d? | 205d | finish no earlier than 2009-05-29 | R4 | 2008h | 401.6h | FS_RAN-HNBLCRTDD | Rel-9 | Patrick | PCG-21 | TD Tech | RP-41 |  |
| 125 | 1.66 | Study on E-UTRAN Mobility Evaluation and Enhancement |  | 126d? | 2008-12-05 | 2009-05-29 |  |  | 2008-12-05 | 2009-05-29 | 126d? | 205d | finish no earlier than 2009-05-29 | R1 | 1008h |  | FS_EUTRAN_mob | Rel-9 |  |  | Qualcomm |  |  |
| 126 | 1.67 | Release 8 Features | milestone | 0d? | 2000-01-03 | 2000-01-03 |  |  | 2000-01-03 | 2000-01-03 | 0d? | 2659d | start no earlier than 2000-01-03 | CP,GP,RP,SP |  |  |  | Rel-8 |  |  |  |  |  |

Notes:
- 76: 05/08: Linked to Feature UID_20029 (RANimp)
- 77: SR in RP-080824 / Text3: 34.108, 34.121-1, 34.121-2, 34.123-1, 34.123-2, 34.123-3 / Text5: leif.mattisson@ericsson.com
- 78: Testing for UID_380073 / Text3: 34.108, 34.121-1, 34.121-2 / Text5: jukka.vikstedt@nokia.com
- 79: Testing for UID_400052 / Text3: 34.108, 34.121-1, 34.121-2, 34.123-1, 34.123-2, 34.123-3 / Text5: Shubhang Vora (svora@qualcomm.com)
- 81: Text3: 36.902, 36.300, 36.423 / Text5: krzysztof.kordybach@nsn.com
- 82: SA#42 moved to Rel-9 (target completion 12/08=>12/09) / Text3: 32.521 / Text5: WANG, Xuelong
- 83: GP#40 WID approved / Text5: juergen.hofmann@nsn.com, liuxiaoyu@chinamobile.com
- 84: GP#40 WID approved / Text3: 45.001 (Overview of VAMOS solution) / Text5: juergen.hofmann@nsn.com, liuxiaoyu@chinamobile.com
- 85: GP#40 WID approved / Text3: 24.008, 44.018, 45.002, 45.003, 45.004, 45.008, 48.008, 48.058 / Text5: juergen.hofmann@nsn.com, liuxiaoyu@chinamobile.com
- 86: GP#40 WID approved / Text3: 45.005 (Test Scenarios for VAMOS Performance requiremen) / Text5: juergen.hofmann@nsn.com, liuxiaoyu@chinamobile.com
- 88: SA#39 created to host Rel-9 Wis. BUT no agreed WID
- 89: SA#39 SAE functionality moved to Rel-9. WID returned to SA2 for re-consideration & remove MBMS for EPS from Rel 8
- 90: SA#39 SAE functionality moved to Rel-9. BUT no agreed WID
- 91: SA#39 SAE functionality moved to Rel-9. BUT no agreed WID
- 92: SA#39 SAE functionality moved to Rel-9. BUT no agreed WID
- 93: RP#39: No agreed WID / Text3: 36.306, 36.331, 36.413, 36.300, 36.214, 36.133, 36.304
- 94: RP#39: No agreed WID / Text3: 25.306, 25.331, 25.413
- 96: SA#42 SA1 part completed / Text5: tim.haysom@orange-ftgroup.com
- 97: SA#42 completed / Text3: 22.813 / Text5: tim.haysom@orange-ftgroup.com
- 98: Text5: tim.haysom@orange-ftgroup.com
- 99: Text3: 22.893 / Text5: chris.friel@O2.com
- 100: SA#42 completed / Text3: 22.986 / Text5: Frederic Thepot (thepot@docomolab-euro.com)
- 101: Text3: 22.984 / Text5: Juergen Merkel
- 102: Text3: 22.947 / Text5: Jaihyung Cho
- 103: Text3: 22.8xy / Text5: Donghee Shim
- 104: Text3: 23.879 / Text5: Sabine.Demel@T-Mobile.at
- 105: SA#42 completed / Text3: 23.868 / Text5: Stephen Edge
- 106: SA#41 SID updated SP-070838=>SP-080091=>SP-080556. SA#42 Target completion 12/08=>06/09=>09/09 / Text3: 23.894 / Text5: mario.madella@telecomitalia.it, victor.kueh@bt.com
- 107: Linked to 23.236. SA#42 completion target 03/09=>06/09 / Text3: 23.8xy / Text5: LIU HONG (liuhongyfw@chinamobile.com)
- 108: Text3: 23.812 / Text5: Li Gang (ligangyf@chinamobile.com), Yu Qing (yuqing@chinamobile.com)
- 109: Text3: 22.8xy / Text5: Telefónica
- 110: Text3: 23.8xy / Text5: Lorenzo Casaccia (lorenzo@qualcomm.com)
- 111: SA#41 SID updated SP-060290=>SP-080555 (SI title changed: Study on VCC support for Emergency Calls => Study on Service Continuity for Emergency Voice Calls) / Text3: 23.826 / Text5: Ricky Kaura (rkaura@nortel.com)
- 112: SA#42 moved to Rel-9 / Text3: 33.9xx / Text5: eric.gauthier@orange.ch
- 113: Triggered by SA1 Study UID_7027 (FS_M2M) TR 22.868. SA#37 SID updated SP-070635=>SP-070702. / Text3: 33.812 / Text5: vesa.lehtovirta@ericsson.com
- 114: Text3: 33.8xy / Text5: Karl Norrman
- 115: Text3: 33.820 / Text5: yangyanmei@huawei.com
- 116: SA#42 target completion 12/08=>12/09 / Text3: 32.822 / Text5: HUANG, Shuqiang
- 117: SA#42 target completion 03/09=>12/09. SA#41 SID updated SP-070308=>SP-080461. / Text3: 32.821 / Text5: Zou Lan (zlan@huawei.com)
- 118: SA#42 target completion 03/09=>12/09 / Text3: 32.823 / Text5: zhu.weihong@zte.com.cn
- 119: SA#42 target completion 03/09=>12/09 / Text3: 32.824 / Text5: TSE, Edwin
- 120: SA#42 target completion 03/09=>12/09 / Text3: 32.825 / Text5: Mingjun Shan, Huawei [shan.mingjun@huawei.com]
- 122: SR in RP-080827. / Text3: 25.9xx / Text5: Norman Shaw (nshaw@polariswireless.com)
- 123: SR in RP-081091. RP#41 updated SID RP-080137=>RP-080599. / Text3: 36.913, 36.814 / Text5: Takehiro Nakamura
- 124: SR in RP-080829 / Text3: 25.8xy / Text5: Li Rong (lirong@td-tech.com)
- 125: Text3: TR (E-UTRAN handover procedure and performance) / Text5: Rajat Prakash

| ID | WBS | Task | Duration | Start | Finish | Complete | Remaining | Baseline start | Baseline finish | Baseline duration | Total slack | Constraint | Resources | Work | Actual work | Text1 | Text4 | Text5 | Text6 | Text8 | Text7 | Text2 |
| --- | --- | --- | --- | --- | --- | --- | --- | --- | --- | --- | --- | --- | --- | --- | --- | --- | --- | --- | --- | --- | --- | --- |
| 127 | 1.68 | **3GPP System Architecture Evolution Specification - Evolved Packet System (non RAN aspects)** | 898d? | 2006-04-12 A | 2009-09-18 | 93% | 64.06d? | 2006-04-12 | 2009-03-12 | 762d? | 125d |  | S1,S2,S3,S5,C1,C3,C4,C6 | 252436h | 208266h | SAES | T-Mobile | michael.kurz@t-mobile.at | Rel-8 | Maurice |  |  |
| 128 | 1.68.1 | Requirements for evolution of the 3GPP system architecture | 395d? | 2006-06-08 A | 2007-12-12 A | 100% |  | 2006-06-08 | 2007-12-12 | 395d? |  | finish no earlier than 2007-11-30 | S1 | 3160h | 3160h | AIPN-SAE | T-Mobile | michael.kurz@t-mobile.at | Rel-8 | Alain |  |  |
| 129 | 1.68.2 | **High level and common (for all accesses) functions** | 569d? | 2007-01-02 A | 2009-03-06 | 95% | 29.97d? | 2007-01-02 | 2009-03-06 | 569d? | 265d |  | S2,S3,C1,C3,C4 | 40576h | 34318.4h | EPS-ComF | Nokia Siemens Networks | Balazs Bertenyi | Rel-8 | Maurice | SP-37 |  |
| 130 | 1.68.2.1 | Stage 2 for High level functions | 370d? | 2007-01-02 A | 2008-06-02 A | 100% |  | 2007-01-02 | 2008-06-02 | 370d? |  | finish no earlier than 2008-06-02 | S2 | 2960h | 2960h | SAES-SA-HLF | Motorola | Irfan Ali | Rel-8 | Maurice |  |  |
| 131 | 1.68.2.2 | Stage 2 Security Architecture | 197d? | 2008-03-12 A | 2008-12-11 A | 100% |  | 2008-03-12 | 2008-12-11 | 197d? |  | finish no earlier than 2008-12-11 | S3 | 1576h | 1576h | SAES | Nokia Siemens Networks | marc.blommaert.ext@nsn.com | Rel-8 | Dionisio | SP-39 | PCG-21 |
| 132 | 1.68.2.3 | Stage 3 (CT1) for SAE impact on services, network functions and capabilities | 545d? | 2007-02-05 A | 2009-03-06 | 80% | 109d? | 2007-02-05 | 2009-03-06 | 545d? | 265d | finish no earlier than 2009-03-06 | C1 | 4360h | 3488h | SAES | Nokia Siemens Networks | robert.zaus@nsn.com | Rel-8 | Frederic |  |  |
| 133 | 1.68.2.4 | Stage 3 SAE impact on existing capabilities | 480d? | 2007-02-05 A | 2008-12-05 A | 100% |  | 2007-02-05 | 2008-12-05 | 480d? |  | finish no earlier than 2008-12-12 | C3 | 3840h | 3840h | SAES | Huawei | Wei Weihua (weiwh@huawei.com) | Rel-8 | Gwiho |  |  |
| 134 | 1.68.2.5 | Stage 3 (CT4) of SAE impact on existing capabilities | 545d? | 2007-02-05 A | 2009-03-06 | 95% | 27.25d? | 2007-02-05 | 2009-03-06 | 545d? | 265d | finish no earlier than 2009-03-06 | C4 | 4360h | 4142h | SAES | Huawei | shahab.lavasani@huawei.com | Rel-8 | Kimmo |  |  |
| 135 | 1.68.2.6 | Stage 2/3 for Network selection procedures | 480d? | 2007-02-05 A | 2008-12-05 A | 100% |  | 2007-02-05 | 2008-12-05 | 480d? |  | finish no earlier than 2009-03-06 | C1 | 3840h | 3840h | SAES | Nokia Siemens Networks | robert.zaus@nsn.com | Rel-8 | Frederic |  |  |
| 136 | 1.68.2.7 | Stage 3 EPC interworking with external PDNs (SGi) | 480d? | 2007-02-05 A | 2008-12-05 | 96% | 19.2d? | 2007-02-05 | 2008-12-05 | 480d? | 330d | finish no earlier than 2008-12-05 | C3 | 3840h | 3686.4h | SAES-St3-intwk | Huawei | Wei Weihua (weiwh@huawei.com) | Rel-8 | Gwiho |  |  |
| 137 | 1.68.2.8 | Stage 3 PCC within SAE | 545d? | 2007-02-05 A | 2009-03-06 | 90% | 54.5d? | 2007-02-05 | 2009-03-06 | 545d? | 265d | finish no earlier than 2009-03-06 | C3 | 4360h | 3924h | SAES-St3-PCC | Ericsson | j.javier.pastor@ericsson.com | Rel-8 | Gwiho |  |  |
| 138 | 1.68.2.9 | Stage 3 for SAE / LTE identities | 545d? | 2007-02-05 A | 2009-03-06 | 95% | 27.25d? | 2007-02-05 | 2009-03-06 | 545d? | 265d | finish no earlier than 2009-03-06 | C4 | 4360h | 4142h | SAES | Huawei | shahab.lavasani@huawei.com | Rel-8 | Kimmo |  |  |
| 139 | 1.68.2.10 | Unified guidelines for Diameter usage within 3GPP | 316d? | 2007-09-21 A | 2008-12-05 A | 100% |  | 2007-09-21 | 2008-12-05 | 316d? |  | finish no earlier than 2008-12-05 | C3 | 2528h | 2528h | SAES-DIAM | Huawei | Javier Gonzalez Gallego | Rel-8 | Gwiho | CP-37 |  |
| 140 | 1.68.3 | **SAE for LTE access** | 569d? | 2007-01-02 A | 2009-03-06 | 92% | 44.93d? | 2007-01-02 | 2009-03-06 | 569d? | 265d |  | S2,C1,C3,C4 | 57824h | 42024h | SAES-LTE | Motorola | Irfan.Ali@motorola.com | Rel-8 | Maurice |  |  |
| 141 | 1.68.3.1 | CT4 Stage 3 for protocol between EPCs | 545d? | 2007-02-05 A | 2009-03-06 | 90% | 54.5d? | 2007-02-05 | 2009-03-06 | 545d? | 265d | finish no earlier than 2009-03-06 | C4 | 4360h | 3924h | SAES | Huawei | shahab.lavasani@huawei.com | Rel-8 | Kimmo |  |  |
| 142 | 7.2.2.1 | **SAES-SA-FP_LTE with GTP variant** | 569d? | 2007-01-02 A | 2009-03-06 | 88% | 67.56d? | 2007-01-02 | 2009-03-06 | 569d? | 265d |  | S2,C4 | 11896h | 7048h | SAES-SA-FP_LTE-GTP | Nokia Siemens Networks | Balazs Bertenyi | Rel-8 | Maurice |  |  |
| 143 | 1.68.3.2.1 | Stage 2 for SAES-SA-FP_LTE with GTP variant | 373d? | 2007-01-02 A | 2008-06-05 A | 100% |  | 2007-01-02 | 2008-06-05 | 373d? |  | finish no earlier than 2008-06-02 | S2 | 2984h | 2984h | SAES-SA-FP_LTE-GTP-St2 | Nokia Siemens Networks | Balazs Bertenyi | Rel-8 | Maurice |  |  |
| 144 | 1.68.3.2.2 | CT4 Stage 3 for GTP v2 protocol | 545d? | 2007-02-05 A | 2009-03-06 | 80% | 109d? | 2007-02-05 | 2009-03-06 | 545d? | 265d | finish no earlier than 2009-03-06 | C4 | 4360h | 3488h | SAES | Huawei | shahab.lavasani@huawei.com | Rel-8 | Kimmo |  |  |
| 145 | 7.2.2.2 | **SAES-SA-FP_LTE with PMIP variant** | 569d? | 2007-01-02 A | 2009-03-06 | 98% | 11.09d? | 2007-01-02 | 2009-03-06 | 569d? | 265d |  | S2,C4 | 15736h | 11542h | SAES-SA-FP_LTE-IETF | Nokia Siemens Networks | Balazs Bertenyi | Rel-8 | Maurice |  |  |
| 146 | 1.68.3.3.1 | Stage 2 for SAES-SA-FP_LTE with PMIP variant | 373d? | 2007-01-02 A | 2008-06-05 A | 100% |  | 2007-01-02 | 2008-06-05 | 373d? |  | finish no earlier than 2008-06-02 | S2 | 2984h | 2984h | SAES-SA-FP_LTE-IETF-St2 | Nokia Siemens Networks | Balazs Bertenyi | Rel-8 | Maurice |  |  |
| 147 | 1.68.3.3.2 | CT4 Stage 3 for PMIP protocol within EPC | 545d? | 2007-02-05 A | 2009-03-06 | 95% | 27.25d? | 2007-02-05 | 2009-03-06 | 545d? | 265d | finish no earlier than 2009-03-06 | C4 | 4360h | 4142h | SAES | Huawei | shahab.lavasani@huawei.com | Rel-8 | Kimmo |  |  |
| 148 | 1.68.3.3.3 | Mobile IPv4 (MIPv4) based Mobility protocols | 480d? | 2007-02-05 A | 2008-12-05 A | 100% |  | 2007-02-05 | 2008-12-05 | 480d? |  | finish no earlier than 2008-12-05 | C4 | 3840h | 3840h | SAES | Motorola | Lewis Milton | Rel-8 | Kimmo |  |  |
| 149 | 1.68.3.4 | Stage 3 for UE NAS mobility procedures in idle and active mode | 545d? | 2007-02-05 A | 2009-03-06 | 90% | 54.5d? | 2007-02-05 | 2009-03-06 | 545d? | 265d | finish no earlier than 2009-03-06 | C1 | 4360h | 3924h | SAES | Nokia Siemens Networks | robert.zaus@nsn.com | Rel-8 | Frederic |  |  |
| 150 | 1.68.3.5 | Stage 3 for Session management, bearer control and QoS aspects | 545d? | 2007-02-05 A | 2009-03-06 | 90% | 54.5d? | 2007-02-05 | 2009-03-06 | 545d? | 265d | finish no earlier than 2009-03-06 | C1 | 4360h | 3924h | SAES | Nokia Siemens Networks | robert.zaus@nsn.com | Rel-8 | Frederic |  |  |
| 151 | 1.68.3.6 | Stage 3 for security aspects of LTE Access | 545d? | 2007-02-05 A | 2009-03-06 | 80% | 109d? | 2007-02-05 | 2009-03-06 | 545d? | 265d | finish no earlier than 2009-03-06 | C1 | 4360h | 3488h | SAES | Nokia Siemens Networks | robert.zaus@nsn.com | Rel-8 | Frederic |  |  |
| 152 | 1.68.3.7 | Stage 3 for QoS mechanisms | 480d? | 2007-02-05 A | 2008-12-05 A | 100% |  | 2007-02-05 | 2008-12-05 | 480d? |  | finish no earlier than 2008-12-12 | C3 | 3840h | 3840h | SAES | Ericsson | j.javier.pastor@ericsson.com | Rel-8 | Gwiho |  |  |
| 153 | 1.68.3.8 | Stage 3 for EPC - HSS interface | 545d? | 2007-02-05 A | 2009-03-06 | 95% | 27.25d? | 2007-02-05 | 2009-03-06 | 545d? | 265d | finish no earlier than 2009-03-06 | C4 | 4360h | 4142h | SAES | Huawei | shahab.lavasani@huawei.com | Rel-8 | Kimmo |  |  |

Notes:
- 127: SA#39 WID updated SP-070933=>SP-080132.
- 128: SA#38 completed / Text3: 22.278, 22.011, 22.246
- 129: SA#39 WID updated SP-070933=>SP-080132.
- 130: SA#40 completed / Text3: 23.402
- 131: SA#42 completed. SA#39 WID updated SP-070933=>SP-080132 / Text3: 33.401, 33.210, 33.310
- 132: CT#42 Rel-8 extension to 03/09. CT#41 WID updated CP-080075=>CP-080493. / Text3: 24.229, 24.305, 27.007
- 133: CT#42 completed. WID updated CP-080056=>CP-080772 / Text3: 29.061
- 134: CT#42 Rel-8 extension to 03/09. WID updated CP-080026=>CP-080279=>CP-080446=>CP-080724 / Text3: 29.274, 29.275
- 135: CT#42 completed. CT#41 WID updated CP-080075=>CP-080493. / Text3: 23.122, 24.302
- 136: WID updated CP-080056=>CP-080772 / Text3: 29.061
- 137: CT#42 Rel-8 extension to 03/09. CT#41 updated WID CP-080057=>CP-080576. / Text3: 29.212, 29.213, 29.214, 29.215
- 138: CT#42 Rel-8 extension to 03/09. WID updated CP-080026=>CP-080279=>CP-080446=>CP-080724 / Text3: 23.003
- 139: CT#42 completed / Text3: 29.909
- 140: SA#39: WID updated SP-070933=>SP-080132. / Text3: 23.401, 23.060, 23.002, 23.246, 23.203, 23.107, 23.234, 23.271
- 141: CT#42 Rel-8 extension to 03/09. WID updated CP-080026=>CP-080279=>CP-080446=>CP-080724 / Text3: 29.274, 29.275
- 142: SA#39: WID updated SP-070933=>SP-080132.
- 143: SA#40 completed / Text3: 23.401, 23.060, 23.002, 23.246, 23.203, 23.107, 23.234, 23.271
- 144: CT#42 Rel-8 extension to 03/09. WID updated CP-080026=>CP-080279=>CP-080446=>CP-080724 / Text3: 29.274
- 145: SA#39: WID updated SP-070933=>SP-080132.
- 146: SA#40 completed. Multiple PDN related alignments, 23.060-derived changes.
- 147: CT#42 Rel-8 extension to 03/09. WID updated CP-080026=>CP-080279=>CP-080446=>CP-080724 / Text3: 29.275
- 148: CT#42 completd. WID updated CP-080026=>CP-080279=>CP-080446=>CP-080724 / Text3: 29.279
- 149: CT#42 Rel-8 extension to 03/09. CT#41 WID updated CP-080075=>CP-080493. / Text3: 24.007, 24.301
- 150: CT#42 Rel-8 extension to 03/09. CT#41 WID updated CP-080075=>CP-080493. / Text3: 24.007, 24.301
- 151: CT#42 Rel-8 extension to 03/09. CT#41 WID updated CP-080075=>CP-080493 / Text3: 24.008, 24.301
- 152: CT#42 completed. CT#41 updated WID CP-080057=>CP-080576. / Text3: 29.213
- 153: CT#42 Rel-8 extension to 03/09. WID updated CP-080026=>CP-080279=>CP-080446=>CP-080724 / Text3: 29.272

| ID | WBS | Task | Type | Duration | Start | Finish | Complete | Remaining | Baseline start | Baseline finish | Baseline duration | Total slack | Constraint | Resources | Work | Actual work | Text1 | Text4 | Text5 | Text6 | Text8 | Text3 | Text7 | Text2 | Text12 |
| --- | --- | --- | --- | --- | --- | --- | --- | --- | --- | --- | --- | --- | --- | --- | --- | --- | --- | --- | --- | --- | --- | --- | --- | --- | --- |
| 154 | 1.68.4 | **SAE for Interoperation between LTE and legacy cellular PS accesses** |  | 545d? | 2007-02-05 A | 2009-03-06 | 91% | 49.79d? | 2007-02-05 | 2009-03-06 | 545d? | 265d |  | S2,C1,C4 | 40152h | 32716h | SAES-SA-FP_3GPP | Motorola | Irfan.Ali@motorola.com | Rel-8 | Maurice |  |  |  |  |
| 155 | 1.68.4.1 | Stage 2 for Interoperation between LTE and 2G/3G |  | 424d? | 2007-02-05 A | 2008-09-18 A | 100% |  | 2007-02-05 | 2008-09-18 | 424d? |  | finish no earlier than 2008-09-11 | S2 | 3392h | 3392h | EPSto2_3G | Motorola | Irfan Ali | Rel-8 | Maurice | 23.401, 23.402 | SP-37 |  |  |
| 156 | 1.68.4.2 | Stage 3 for Inter-system mobility between E-UTRAN and 2G/3G |  | 545d? | 2007-02-05 A | 2009-03-06 | 75% | 136.25d? | 2007-02-05 | 2009-03-06 | 545d? | 265d | finish no earlier than 2009-03-06 | C1 | 4360h | 3270h | SAES | Nokia Siemens Networks | robert.zaus@nsn.com | Rel-8 | Frederic | 24.008, 24.301 | CP-38 | PCG-21 |  |
| 157 | 1.68.4.3 | Stage 2 GPRS enhancements for LTE access |  | 272d? | 2007-09-04 A | 2008-09-18 A | 100% |  | 2007-09-04 | 2008-09-18 | 272d? |  | start no earlier than 2007-09-04 | S2 | 2176h | 2176h | SAES-GPRS_LTE | Vodafone | chris.pudney@vodafone.com | Rel-8 | Maurice | 23.401 |  |  |  |
| 158 | 1.68.4.4 | Stage 2 GPRS for EPC (23.060, etc.) |  | 179d? | 2008-01-14 A | 2008-09-18 A | 100% |  | 2008-01-14 | 2008-09-18 | 179d? |  | finish no earlier than 2008-09-18 | S2 | 1432h | 1432h | SAES | Nokia Siemens Networks | Balazs Bertenyi | Rel-8 | Maurice | 23.060 | SP-39 | PCG-21 |  |
| 159 | 1.68.4.5 | Stage 3 for EPC - GPRS |  | 545d? | 2007-02-05 A | 2009-03-06 | 85% | 81.75d? | 2007-02-05 | 2009-03-06 | 545d? | 265d | finish no earlier than 2009-03-06 | C4 | 4360h | 3706h | SAES | Huawei | shahab.lavasani@huawei.com | Rel-8 | Kimmo | 29.274, 29.275, 29.281 |  |  |  |
| 160 | 1.68.4.6 | Stage 3 for EPC to UTRAN |  | 545d? | 2007-02-05 A | 2009-03-06 | 85% | 81.75d? | 2007-02-05 | 2009-03-06 | 545d? | 265d | finish no earlier than 2009-03-06 | C4 | 4360h | 3706h | SAES | Huawei | shahab.lavasani@huawei.com | Rel-8 | Kimmo | 29.274, 29.275, 29.281 | CP-38 | PCG-21 |  |
| 161 | 1.68.4.7 | Stage 3 for EPC to 3GPP2 |  | 545d? | 2007-02-05 A | 2009-03-06 | 95% | 27.25d? | 2007-02-05 | 2009-03-06 | 545d? | 265d | finish no earlier than 2009-03-06 | C4 | 4360h | 4142h | SAES | Huawei | shahab.lavasani@huawei.com | Rel-8 | Kimmo | 29.277, 29.276 | CP-38 | PCG-21 |  |
| 162 | 1.68.4.8 | Stage 2 for Interoperation between LTE and CDMA2000 |  | 329d? | 2007-06-18 A | 2008-09-18 A | 100% |  | 2007-06-18 | 2008-09-18 | 329d? |  | finish no earlier than 2008-04-25 | S2 | 2632h | 2632h | EPStoC2k | Motorola, Vodafone | Irfan Ali, chris.pudney@vodafone.com | Rel-8 | Maurice | 23.401, 23.402 | CP-37 |  |  |
| 163 | 1.68.4.9 | Stage 3 for Inter-system mobility between E-UTRAN and CDMA2000 |  | 545d? | 2007-02-05 A | 2009-03-06 | 90% | 54.5d? | 2007-02-05 | 2009-03-06 | 545d? | 265d | finish no earlier than 2009-03-06 | C1 | 4360h | 3924h | SAES | Nokia Siemens Networks | robert.zaus@nsn.com | Rel-8 | Frederic | 24.301, 24.302 |  |  |  |
| 164 | 1.68.4.10 | Stage 3 for MME - SGSN "signalling free" protocol |  | 545d? | 2007-02-05 A | 2009-03-06 | 95% | 27.25d? | 2007-02-05 | 2009-03-06 | 545d? | 265d | finish no earlier than 2009-03-06 | C4 | 4360h | 4142h | SAES | Huawei | shahab.lavasani@huawei.com | Rel-8 | Kimmo | 29.272, 29.274 |  |  |  |
| 165 | 1.68.5 | **SAE for support for non-3GPP accesses** |  | 569d? | 2007-01-02 A | 2009-03-06 | 97% | 19.37d? | 2007-01-02 | 2009-03-06 | 569d? | 265d |  | S2,S3,C1,C4 | 53872h | 48026.8h | SAES-SA-FP_n3GPP | Motorola | Irfan.Ali@motorola.com | Rel-8 | Maurice |  |  |  |  |
| 166 | 7.2.4.1 | Stage 2 for Host-based Mobility aspects |  | 373d? | 2007-01-02 A | 2008-06-05 A | 100% |  | 2007-01-02 | 2008-06-05 | 373d? |  | finish no earlier than 2008-04-11 | S2 | 2984h | 2984h | SAES-SA-FP_n3GPP-HBMob | Motorola | Irfan Ali | Rel-8 | Maurice | 23.402 |  |  |  |
| 167 | 7.2.4.2 | Stage 2 for Network-based Mobility aspects |  | 448d? | 2007-01-02 A | 2008-09-18 A | 100% |  | 2007-01-02 | 2008-09-18 | 448d? |  | finish no earlier than 2008-09-18 | S2 | 3584h | 3584h | SAES-SA-FP_n3GPP-NBMob | Motorola | Irfan Ali | Rel-8 | Maurice | 23.402 |  |  |  |
| 168 | 1.68.5.3 | Stage 3 for Mobility management based on DSMIP v6 |  | 480d? | 2007-02-05 A | 2008-12-05 A | 100% |  | 2007-02-05 | 2008-12-05 | 480d? |  | finish no earlier than 2008-12-05 | C1 | 3840h | 3840h | SAES | Nokia Siemens Networks | robert.zaus@nsn.com | Rel-8 | Frederic | 24.303 |  |  |  |
| 169 | 1.68.5.4 | Stage 3 for Mobility management based on MIP v4 |  | 480d? | 2007-02-05 A | 2008-12-05 A | 100% |  | 2007-02-05 | 2008-12-05 | 480d? |  | start no earlier than 2007-02-05 | C1 | 3840h | 3840h | SAES | Nokia Siemens Networks | robert.zaus@nsn.com | Rel-8 | Frederic | 24.304 | CP-39 | PCG-21 |  |
| 170 | 1.68.5.5 | Stage 3 for Inter-system mobility between E-UTRAN and non 3GPP accesses |  | 545d? | 2007-02-05 A | 2009-03-06 | 80% | 109d? | 2007-02-05 | 2009-03-06 | 545d? | 265d | finish no earlier than 2009-03-06 | C1 | 4360h | 3488h | SAES | Nokia Siemens Networks | robert.zaus@nsn.com | Rel-8 | Frederic | 24.008, 24.301 | CP-38 | PCG-21 |  |
| 171 | 1.68.5.6 | Stage 2 for Optimized Dual-Radio Handover with WiMAX |  | 249d? | 2007-06-25 A | 2008-06-05 A | 100% |  | 2007-06-25 | 2008-06-05 | 249d? |  | finish no earlier than 2008-06-09 | S2 | 1992h | 1992h | SAES-SA-FP_n3GPP-OptWIMAX | Motorola | Irfan Ali | Rel-8 | Maurice | 23.402 |  |  |  |
| 172 | 1.68.5.7 | Stage 2 Security aspects for non-3GPP Access |  | 197d? | 2008-03-12 A | 2008-12-11 A | 100% |  | 2008-03-12 | 2008-12-11 | 197d? |  | finish no earlier than 2008-12-11 | S3 | 1576h | 1576h | SAES | Nokia Siemens Networks | marc.blommaert.ext@nsn.com | Rel-8 | Dionisio | 33.402, 33.210, 33.310 | SP-39 | PCG-21 |  |
| 173 | 1.68.5.8 | Stage 3 security aspects for DSMIP v6 Access |  | 480d? | 2007-02-05 A | 2008-12-05 A | 100% |  | 2007-02-05 | 2008-12-05 | 480d? |  | finish no earlier than 2008-12-05 | C1 | 3840h | 3840h | SAES | Nokia Siemens Networks | robert.zaus@nsn.com | Rel-8 | Frederic | 24.303 | CP-37 |  |  |
| 174 | 1.68.5.9 | Stage 3 security aspects for MIPv4 Access |  | 480d? | 2007-02-05 A | 2008-12-05 A | 100% |  | 2007-02-05 | 2008-12-05 | 480d? |  | finish no earlier than 2008-12-05 | C1 | 3840h | 3840h | SAES | Nokia Siemens Networks | robert.zaus@nsn.com | Rel-8 | Frederic | 24.304 | CP-39 | PCG-21 |  |
| 175 | 1.68.5.10 | Stage 3 for Access to the EPC via non-3GPP access networks |  | 545d? | 2007-02-05 A | 2009-03-06 | 90% | 54.5d? | 2007-02-05 | 2009-03-06 | 545d? | 265d | finish no earlier than 2009-03-06 | C1 | 4360h | 3924h | SAES | Nokia Siemens Networks | robert.zaus@nsn.com | Rel-8 | Frederic | 24.302, 24.312 |  |  |  |
| 176 | 1.68.5.11 | Stage 3 for interfaces within EPC |  | 383d? | 2007-09-19 A | 2009-03-06 | 95% | 19.15d? | 2007-09-19 | 2009-03-06 | 383d? | 265d | finish no earlier than 2009-03-06 | C4 | 3064h | 2910.8h | SAES | Huawei | shahab.lavasani@huawei.com | Rel-8 | Kimmo | 29.274, 29.281 | CP-37 |  |  |
| 177 | 1.68.5.12 | Stage 3 for Interfaces EPC - non-3GPP IP access |  | 545d? | 2007-02-05 A | 2009-03-06 | 95% | 27.25d? | 2007-02-05 | 2009-03-06 | 545d? | 265d | finish no earlier than 2009-03-06 | C4 | 4360h | 4142h | SAES | Huawei | shahab.lavasani@huawei.com | Rel-8 | Kimmo | 29.273, 29.275 |  |  |  |
| 178 | 1.68.5.13 | Stage 3 for AAA/HSS related |  | 480d? | 2007-02-05 A | 2008-12-05 A | 100% |  | 2007-02-05 | 2008-12-05 | 480d? |  | finish no earlier than 2008-12-05 | C4 | 3840h | 3840h | SAES | Huawei | shahab.lavasani@huawei.com | Rel-8 | Kimmo | 29.273 |  |  |  |
| 179 | 1.68.5.14 | Stage 3 for EPC - AAA interface |  | 480d? | 2007-02-05 A | 2008-12-05 A | 100% |  | 2007-02-05 | 2008-12-05 | 480d? |  | finish no earlier than 2008-12-05 | C4 | 3840h | 3840h | SAES | Huawei | shahab.lavasani@huawei.com | Rel-8 | Kimmo | 29.273 |  |  |  |
| 180 | 1.68.5.15 | Deleted (already covered) SAES-SA-FP_n3GPP Optimized Handover with CDMA | milestone | 0d? | 2007-06-25 A | 2007-06-25 A | 100% |  | 2007-06-25 | 2007-06-25 | 0d? |  | finish no earlier than 2007-06-25 | S2 |  |  | SAES-SA-FP_n3GPP-OptCDMA | Nokia Siemens Networks |  | Rel-8 | Maurice |  |  |  | SP-37 |

Notes:
- 154: SA#39: WID updated SP-070933=>SP-080132.
- 155: SA#41 completed. SA#40 extension to Sep 2008 (default bearer issue).
- 156: CT#42 Rel-8 extension to 03/09. CT#41 WID updated CP-080075=>CP-080493.
- 157: SA#41 completed. 25/03/08 claimed as SA#34 stopped. Resurrected. WID updated SP-060926 => SP-080132
- 158: SA#41 completed. SA#40 extension to Sep 2008 (QoS mapping related changes, Interoperation between Gn/Gp and S4 SGSN).
- 159: CT#42 Rel-8 extension to 03/09. WID updated CP-080026=>CP-080279=>CP-080446=>CP-080724
- 160: CT#42 Rel-8 extension to 03/09. WID updated CP-080026=>CP-080279=>CP-080446=>CP-080724
- 161: CT#42 Rel-8 extension to 03/09. WID updated CP-080026=>CP-080279=>CP-080446=>CP-080724
- 162: SA#40 extension to Sep 2008 (Handover of multiple PDNs, Handling of multiple BBERFs). SA#41 completed (except: Handover of multiple PDNs=>Rel-9)
- 163: CT#42 Rel-8 extension to 03/09. CT#41 WID updated CP-080075=>CP-080493.
- 164: CT#42 Rel-8 extension to 03/09. WID updated CP-080026=>CP-080279=>CP-080446=>CP-080724
- 165: SA#39 retained in Rel-8 (in addition to the essential functionality defined in SP-070699). Replaces UID_340037
- 166: SA#40 completed
- 167: SA#40 extension to Sep 2008 (Multiple PDN connections to the same APN using PMIP). SA#41 completed
- 168: CT#41 WID updated CP-080075=>CP-080493. CT#42 completed
- 169: CT#41 WID updated CP-080075=>CP-080493. CT#42 completed
- 170: CT#42 Rel-8 extension to 03/09. CT#41 WID updated CP-080075=>CP-080493.
- 171: SA#40 completed
- 172: SA#42 completed. SA#39 WID updated SP-070933=>SP-080132. WP record created. SA#41 extension granted to Stage 2 UE-ANDSF security (Access Network Discovery and Selection Function)
- 173: CT#42 completed. post-CT#39: split into DSMIP v6 and MIPv4 Access. CT#41 WID updated CP-080075=>CP-080493.
- 174: CT#42 completed. post-CT#39: split into DSMIP v6 and MIPv4 Access. UID_390072->390172. CT#41 WID updated CP-080075=>CP-080493.
- 175: CT#42 Rel-8 extension to 03/09. CT#41 WID updated CP-080075=>CP-080493.
- 176: CT#42 Rel-8 extension to 03/09. WID updated CP-080026=>CP-080279=>CP-080446=>CP-080724
- 177: CT#42 Rel-8 extension to 03/09. WID updated CP-080026=>CP-080279=>CP-080446=>CP-080724
- 178: CT#42 completd. WID updated CP-080026=>CP-080279=>CP-080446=>CP-080724
- 179: CT#42 completd. WID updated CP-080026=>CP-080279=>CP-080446=>CP-080724
- 180: SA#37 stopped

| ID | WBS | Task | Type | Duration | Start | Finish | Complete | Remaining | Baseline start | Baseline finish | Baseline duration | Total slack | Constraint | Resources | Work | Actual work | Text1 | Text4 | Text5 | Text6 | Text8 | Text2 | Text7 | Text12 |
| --- | --- | --- | --- | --- | --- | --- | --- | --- | --- | --- | --- | --- | --- | --- | --- | --- | --- | --- | --- | --- | --- | --- | --- | --- |
| 181 | 1.68.6 | **Single Radio Voice Call Continuity for 3GPP (SRVCC)** |  | 569d? | 2007-01-02 A | 2009-03-06 | 89% | 60.9d? | 2007-01-02 | 2009-03-06 | 569d? | 265d |  | S2,C1,C4 | 10752h | 8480.4h | SAES-SRVCC | Nokia Siemens Networks | Curt Wong | Rel-8 | Maurice |  |  |  |
| 182 | 1.68.6.1 | Stage 2 for 2G/3G SRVCC |  | 448d? | 2007-01-02 A | 2008-09-18 A | 100% |  | 2007-01-02 | 2008-09-18 | 448d? |  | finish no earlier than 2008-09-15 | S2 | 3584h | 3584h | SAES-SRVCC | Nokia Siemens Networks | Curt Wong | Rel-8 | Maurice |  |  |  |
| 183 | 1.68.6.2 | Stage 3 for SRVCC in EPS |  | 201d? | 2008-05-30 A | 2009-03-06 | 65% | 70.35d? | 2008-05-30 | 2009-03-06 | 201d? | 265d | finish no earlier than 2009-03-06 | C1 | 1608h | 1045.2h | SAES-SRVCC | Nokia Siemens Networks | robert.zaus@nsn.com | Rel-8 |  | PCG-21 | CP-41 |  |
| 184 | 1.68.6.3 | MME to MSC interface for SRVCC |  | 126d? | 2008-09-12 A | 2009-03-06 | 90% | 12.6d? | 2008-09-12 | 2009-03-06 | 126d? | 265d | finish no earlier than 2009-03-06 | C4 | 1008h | 907.2h | SAES-SRVCC | Nokia Siemens Networks | Giorgi Gulbani | Rel-8 |  | PCG-21 | CP-41 |  |
| 185 | 1.68.7 | Voice Call Continuity for CDMA2000 1X |  | 249d? | 2007-06-25 A | 2008-06-05 A | 100% |  | 2007-06-25 | 2008-06-05 | 249d? |  | finish no earlier than 2008-06-13 | S2 | 1992h | 1992h | SAES-VCC_1X | Nokia Siemens Networks | Balazs Bertenyi | Rel-8 | Maurice |  |  |  |
| 186 | 1.68.8 | SAE impacts on IMS |  | 373d? | 2007-01-02 A | 2008-06-05 A | 100% |  | 2007-01-02 | 2008-06-05 | 373d? |  | finish no earlier than 2008-06-13 | S2 | 2984h | 2984h | SAES-SA_IMS | Nokia Siemens Networks | Balazs Bertenyi | Rel-8 | Maurice |  |  |  |
| 187 | 1.68.9 | **CS Fallback in EPS** |  | 258d? | 2008-03-12 A | 2009-03-06 | 92% | 19.5d? | 2008-03-12 | 2009-03-06 | 258d? | 265d |  | S2,C1,C4 | 4800h | 2950.8h | SAES-CSFB | T-Mobile, Vodafone | sabine.demel@t-mobile.at, chris.pudney@vodafone.com | Rel-8 | Maurice | PCG-21 | SP-39 |  |
| 188 | 1.68.9.1 | Stage 2 for CS Fallback in EPS |  | 62d? | 2008-03-12 A | 2008-06-05 A | 100% |  | 2008-03-12 | 2008-06-05 | 62d? |  | finish no earlier than 2008-12-05 | S2 | 496h | 496h | SAES-CSFB | T-Mobile, Vodafone | sabine.demel@t-mobile.at, chris.pudney@vodafone.com | Rel-8 | Maurice | PCG-21 | SP-40 |  |
| 189 | 1.68.9.2 | Stage 3 for CS Fallback in EPS |  | 201d? | 2008-05-30 A | 2009-03-06 | 85% | 30.15d? | 2008-05-30 | 2009-03-06 | 201d? | 265d | finish no earlier than 2009-03-06 | C1 | 1608h | 1366.8h | SAES-CSFB | NEC | yannick.lair@nectech.fr | Rel-8 | Frederic | PCG-21 | CP-40 |  |
| 190 | 1.68.9.3 | Stage 3 for CS Fallback in EPS |  | 136d? | 2008-05-30 A | 2008-12-05 A | 100% |  | 2008-05-30 | 2008-12-05 | 136d? |  | finish no earlier than 2008-12-05 | C4 | 1088h | 1088h | SAES-CSFB | NEC | yannick.lair@nectech.fr | Rel-8 | Kimmo | PCG-21 | CP-40 |  |
| 191 | 1.68.10 | System enhancements for the use of IMS services in local breakout |  | 62d? | 2008-03-12 A | 2008-06-05 A | 100% |  | 2008-03-12 | 2008-06-05 | 62d? |  | finish no earlier than 2008-06-05 | S2 | 496h | 496h | SAES-IMS_LBO | Telecom Italia | mario.madella@telecomitalia.it | Rel-8 | Maurice | PCG-21 | SP-39 |  |
| 192 | 1.68.11 | **EPC Data Definitions** |  | 309d? | 2008-01-07 A | 2009-03-12 | 75% | 76.35d? | 2008-01-07 | 2009-03-12 | 309d? | 261d |  | S5 | 7144h | 5378.8h | EPC-OAM |  |  | Rel-8 | Dionisio | PCG-21 | SP-39 |  |
| 193 | 1.68.11.1 | EPC Network Resource Model (NRM) Integration Reference Point (IRP) |  | 309d? | 2008-01-07 A | 2009-03-12 | 80% | 61.8d? | 2008-01-07 | 2009-03-12 | 309d? | 261d | finish no earlier than 2009-03-12 | S5 | 2472h | 1977.6h | EPC-OAM | Huawei | WANG, Xuelong | Rel-8 | Dionisio | PCG-21 | SP-38 |  |
| 194 | 1.68.11.2 | Performance measurements for EPC |  | 275d? | 2008-02-22 A | 2009-03-12 | 70% | 82.5d? | 2008-02-22 | 2009-03-12 | 275d? | 261d | finish no earlier than 2009-03-12 | S5 | 2200h | 1540h | EPC-OAM | China Mobile | Li Jian, Liang Shuangchun | Rel-8 | Dionisio | PCG-21 | SP-39 |  |
| 195 | 1.68.12 | EPC Charging |  | 309d? | 2008-01-07 A | 2009-03-12 | 80% | 61.8d? | 2008-01-07 | 2009-03-12 | 309d? | 261d | finish no earlier than 2009-03-12 | S5 | 2472h | 1977.6h | EPC-CH | Nokia Siemens Networks | GÖRMER, Gerald | Rel-8 | Dionisio | PCG-21 | SP-38 |  |
| 196 | 1.68.13 | Issues for CT1 TR 24.801 |  | 420d? | 2007-01-04 A | 2008-12-05 | 95% | 21d? | 2007-01-04 | 2008-12-05 | 420d? | 330d | finish no earlier than 2008-12-05 | C1 | 3360h | 3192h | SAES | Nokia Siemens Networks | robert.zaus@nsn.com | Rel-8 | Frederic | PCG-21 | CP-39 |  |
| 197 | 1.68.14 | Issues for CT3 TR 29.804 |  | 420d? | 2007-02-05 A | 2008-09-12 A | 100% |  | 2007-02-05 | 2008-09-12 | 420d? |  | finish no earlier than 2008-12-12 | C3 | 3360h | 3360h | SAES | Ericsson | j.javier.pastor@ericsson.com | Rel-8 | Gwiho | PCG-21 | CP-39 |  |
| 198 | 1.68.15 | Deleted - Issues for CT4 TR 29.803 |  | 420d? | 2007-01-04 A | 2008-09-12 A | 100% |  | 2007-01-04 | 2008-12-11 | 484d? |  | finish no earlier than 2008-12-11 | C4 | 3360h | 3360h | SAES | Huawei |  | Rel-8 | Kimmo | PCG-21 | CP-39 | CP-41 |
| 199 | 1.68.16 | Domain Name System Procedures for Evolved Packet System (DEPS) |  | 179.75d? | 2008-05-30 A | 2009-03-06 | 95% | 8.99d? | 2008-05-30 | 2009-03-06 | 179.75d? | 265d | finish no earlier than 2009-03-06 | C4 | 1438h | 1366.1h | SAES-DEPS | TeliaSonera | jouni.korhonen@teliasonera.com | Rel-8 | Kimmo | PCG-21 | CP-40 |  |
| 200 | 1.68.17 | InterWorking Function (IWF) between MAP based and Diameter based interfaces |  | 126d? | 2008-09-12 A | 2009-03-06 | 95% | 6.3d? | 2008-09-12 | 2009-03-06 | 126d? | 265d | finish no earlier than 2009-03-06 | C4 | 1008h | 957.6h | SAES-MAP2Diam | Huawei | liming49985@huawei.com | Rel-8 | Kimmo | PCG-21 | CP-41 |  |
| 201 | 1.68.18 | **CT6 aspects of SAE** |  | 206d? | 2008-12-05 A | 2009-09-18 |  | 206d? | 2007-02-05 | 2009-03-06 | 545d? | 125d |  | C6 | 3296h | 1648h | SAES | Nokia | Peter.vestergaard@nokia.com | Rel-8 | Xavier | PCG-21 | SP-39 |  |
| 202 | 1.68.18.1 | Test interworking of LTE Terminals with the USIM |  | 206d? | 2008-12-05 | 2009-09-18 |  |  | 2008-12-05 | 2009-09-18 | 206d? | 125d | finish no earlier than 2009-09-18 | C6 | 1648h |  | SAES-USIM_LTE-Test | Comprion | Udo Willenbrink | Rel-8 |  |  |  |  |
| 203 | 1.68.19 | Deleted (covered by 380068): Functions and procedures for SAE to support LCS | milestone | 0d? | 2008-03-03 A | 2008-03-03 A | 100% |  | 2008-03-03 | 2008-03-03 | 0d? |  | finish no earlier than 2008-03-03 | S2 |  |  | SAES-SA-FP_LCS | Nokia Siemens Networks |  | Rel-8 | Maurice |  |  | SP-37 |
| 204 | 1.68.20 | Deleted (covered by 380064): SAE aspects of Emergency Calls | milestone | 0d? | 2008-03-03 A | 2008-03-03 A | 100% |  | 2008-03-03 | 2008-03-03 | 0d? |  | start no earlier than 2008-03-03 | S2 |  |  | SAES-SA-EmCall | Nokia Siemens Networks |  | Rel-8 | Maurice |  |  | SP-37 |
| 205 | 1.68.21 | Deleted - CT1 aspects of SAES |  | 16.7d? | 2007-09-04 A | 2007-09-27 A | 100% |  | 2007-09-04 | 2007-09-27 | 16.7d? |  | start no earlier than 2007-09-04 | CP,C1 | 133.62h | 133.62h | SAES-St3 |  |  | Rel-8 | Frederic |  |  | SP-37 |
| 206 | 1.68.22 | Deleted - CT1 aspects of SAES | milestone | 0d? | 2007-09-04 A | 2007-09-04 A | 100% |  | 2007-09-04 | 2007-09-04 | 0d? |  | start no earlier than 2007-09-04 | C1 |  |  | SAES-St3 |  |  | Rel-8 | Frederic |  |  | SP-37 |
| 207 | 1.68.23 | Deleted - Interoperability | milestone | 0d? | 2008-03-14 A | 2008-03-14 A | 100% |  | 2008-03-14 | 2008-03-14 | 0d? |  | start no earlier than 2008-03-14 | C1 |  |  | SAES-St3-interop |  |  | Rel-8 | Frederic |  |  | SP-37 |
| 208 | 1.68.24 | Deleted - CT3 aspects of SAES | milestone | 0d? | 2007-09-04 A | 2007-09-04 A | 100% |  | 2007-09-04 | 2007-09-04 | 0d? |  | start no earlier than 2007-09-04 | C3 |  |  | SAES-St3 |  |  | Rel-8 | Gwiho |  |  | SP-37 |
| 209 | 1.68.25 | Deleted - CT4 aspects of SAES | milestone | 0d? | 2007-09-04 A | 2007-09-04 A | 100% |  | 2007-09-04 | 2007-09-04 | 0d? |  | start no earlier than 2007-09-04 | C4 |  |  | SAES-St3 |  |  | Rel-8 | Kimmo |  |  | SP-37 |
| 210 | 1.68.26 | Deleted - UE to EPC NAS signalling (incl. MBMS and QoS aspects) | milestone | 0d? | 2008-03-14 A | 2008-03-14 A | 100% |  | 2008-03-14 | 2008-03-14 | 0d? |  | start no earlier than 2008-03-14 | C1 |  |  | SAES-St3-sig |  |  | Rel-8 | Frederic |  |  | SP-37 |
| 211 | 1.68.27 | Deleted -User and Control plane protocols | milestone | 0d? | 2007-09-21 A | 2007-09-21 A | 100% |  | 2007-09-21 | 2007-09-21 | 0d? |  | start no earlier than 2007-09-21 | C4 |  |  | SAES-St3-prot |  |  | Rel-8 | Kimmo |  |  | SP-37 |
| 212 | 1.68.28 | Deleted - Architecture enhancements for non-3GPP accesses | milestone | 0d? | 2007-09-04 A | 2007-09-04 A | 100% |  | 2007-09-04 | 2007-09-04 | 0d? |  | start no earlier than 2007-09-04 | S2 |  |  | SAES-non_3GPP | Motorola | Irfan.Ali@motorola.com | Rel-8 | Maurice |  |  | SP-34 |
| 213 | 1.68.29 | Deleted: Stage 2 of architecture for the 3GPP System Architecture Evolution | milestone | 0d? | 2007-10-02 A | 2007-10-02 A | 100% |  | 2007-10-02 | 2007-10-02 | 0d? |  | start no earlier than 2007-10-02 | S2 |  |  | SAES-St2 | Vodafone | chris.pudney@vodafone.com | Rel-8 | Maurice |  |  | SP-34 |
| 214 | 1.68.30 | Deleted - SA aspects of System Architecture Evolution |  | 384d? | 2006-04-12 A | 2007-10-02 A | 100% |  | 2006-04-12 | 2007-10-02 | 384d? |  | finish no earlier than 2007-10-02 | S2 | 3072h | 3072h | SAES-SA |  |  | Rel-8 | Maurice |  |  | SP-34 |

Notes:
- 181: CT#42 Rel-8 extension to 03/09. SA#41 Stage 2 completed. SA#38 WID approved (extract from SAE WID SP-070817).
- 182: SA#41 completed. SA#38 WID approved. SA#40 extension to Sep 2008 for Single Radio VCC: incorporating of results of the RAN HSPA VoIP to CS alignment work. / Text3: 23.216
- 183: CT#42 Rel-8 extension to 03/09. WID updated CP-080497=>CP-080793 / Text3: 23.009, 24.008, 24.301
- 184: CT#42 Rel-8 extension to 03/09. WID updated CP-080446=>CP-080793 / Text3: 29.274, 29.277, 23.003, 23.008, 29.280
- 185: SA#40 completed
- 186: SA#40 completed
- 187: CT#42 Rel-8 extension to 03/09. SA#40 Stage 2 completed.
- 188: SA#40 completed / Text3: 23.272, 23.401
- 189: CT#42 Rel-8 extension to 03/09. WID updated CP-080321=>CP-080495=>CP-080791 / Text3: 24.301, 24.801, 24.007, 24.008, 24.011, 29.018, 29.118 [Mobility Management Entity (MME) – Visitor Location Register (VLR) SGs interface specification]
- 190: CT#42 completed. WID updated CP-080321=>CP-080495=>CP-080791 / Text3: 23.007, 23.008, 29.274, 29.277
- 191: SA#40 completed / Text3: 23.228, 23.221, 23.203
- 193: SA#42 Rel-8 extension to 03/09 / Text3: 32.751, 32.752, 32.753, 32.755
- 194: SA#42 Rel-8 extension to 03/09 / Text3: 32.426
- 195: SA#42 Rel-8 extension to 03/09 / Text3: 32.240/296/251/252/298/299
- 196: CT#41 TR content moved to TS-family: 24.301, 24.302, 24.303, 24.304, 29.xyz (SGs interfacev for CS fallback), 24.abc (MO for ANDSF). TR 24.801 approved. / Text3: 24.801
- 197: CT#41 completed / Text3: 29.804
- 198: CT#41 Work stopped and continued in Normative specifications / Text3: 29.803
- 199: CT#42 Rel-8 extension to 03/09 / Text3: 23.003, 29.303
- 200: CT#42 Rel-8 extension to 03/09. Triggered by UID_ 380023 (FS_MAP2Diam) / Text3: 29.305
- 201: CT#42 Rel-8 extension to 03/09. / Text3: 31.102, 31.111
- 202: Testing for UID_390021 (BB: CT6 aspects of SAE) / Text3: 31.xyz (USIM application interworking with E-UTRA/EPC test specification)
- 203: SA#37 stopped
- 204: SA#37 stopped
- 205: SA#37 stopped
- 206: SA#37 stopped
- 207: SA#37 stopped
- 208: SA#37 stopped
- 209: SA#37 stopped / Text3: 29.803
- 210: SA#37 stopped
- 211: SA#37 stopped
- 212: SA#34 stopped. Replaced by UID_350027 and its children / Text3: 23.402
- 213: SA#34 stopped. Replaced by UIDs 340018 and 340037. (SA#34 report discussion of SP-060917.) / Text3: 23.002, 23.060, 23.107, 23.203, 23.228, 23.234, 23.246, 23.271, 23.279
- 214: SA#34 stopped

| ID | WBS | Task | Duration | Start | Finish | Complete | Remaining | Baseline start | Baseline finish | Baseline duration | Total slack | Constraint | Resources | Work | Actual work | Text1 | Text4 | Text5 | Text6 | Text7 | Text8 | Text2 | Text12 |
| --- | --- | --- | --- | --- | --- | --- | --- | --- | --- | --- | --- | --- | --- | --- | --- | --- | --- | --- | --- | --- | --- | --- | --- |
| 215 | 1.69 | **IMS Centralized Service Control (ICSRA)** | 395d? | 2007-09-03 A | 2009-03-06 | 98% | 7.24d? | 2007-09-03 | 2009-03-06 | 395d? | 265d |  | S1,S2,C1,C3,C4 | 9072h | 6887.36h | ICSRA | AT&T | Randy Wohlert | Rel-8 | SP-37 | Alain |  |  |
| 216 | 1.69.1 | Stage 1 for ICSRA | 138d? | 2007-09-03 A | 2008-03-12 A | 100% |  | 2007-09-03 | 2008-03-12 | 138d? |  | finish no earlier than 2007-12-14 | S1 | 1104h | 1104h | ICSRA | AT&T | Randy Wohlert | Rel-8 | SP-38 | Alain | PCG-21 |  |
| 217 | 1.69.2 | Stage 2 for ICSRA | 125d? | 2007-12-14 A | 2008-06-05 A | 100% |  | 2007-12-14 | 2008-06-05 | 125d? |  | start no earlier than 2007-12-14 | S2 | 1000h | 1000h | ICSRA-St2 | Alcatel-Lucent |  | Rel-8 | SP-38 | Maurice | PCG-21 |  |
| 218 | 1.69.3 | Stage 3 for ICSRA – Protocol, Addressing, Subscriber Data | 201d? | 2008-05-30 A | 2009-03-06 | 95% | 10.05d? | 2008-05-30 | 2009-03-06 | 201d? | 265d | finish no earlier than 2009-03-06 | C1 | 1608h | 1527.6h | ICSRA | Ericsson | Sean Schneyer | Rel-8 | CP-40 | Frederic | PCG-21 |  |
| 219 | 1.69.4 | Deleted - Stage 3 for ICSRA – I1 interface | 76d? | 2008-05-30 A | 2008-09-12 A | 100% |  | 2008-05-30 | 2008-09-12 | 76d? |  | finish no earlier than 2008-09-12 | C1 | 608h | 608h | ICSRA | Huawei | Peili Xu | Rel-8 | CP-40 | Frederic | PCG-21 | CP-41 |
| 220 | 1.69.5 | Stage 3 for ICSRA – Protocol, Addressing, Subscriber Data | 201d? | 2008-05-30 A | 2009-03-06 | 97% | 6.03d? | 2008-05-30 | 2009-03-06 | 201d? | 265d | finish no earlier than 2009-03-06 | C3 | 1608h | 1559.76h | ICSRA | Mavenir | Brett Wallis | Rel-8 | CP-40 | Gwiho | PCG-21 |  |
| 221 | 1.69.6 | Stage 3 for ICSRA – Protocol, Addressing, Subscriber Data | 136d? | 2008-05-30 A | 2008-12-05 A | 100% |  | 2008-05-30 | 2008-12-05 | 136d? |  | start no earlier than 2008-05-30 | C4 | 1088h | 1088h | ICSRA | Ericsson | Sean Schneyer | Rel-8 | CP-40 | Kimmo | PCG-21 |  |
| 222 | 1.70 | **IMS Multimedia Telephony and Supplementary Services** | 487d? | 2007-05-02 A | 2009-03-12 | 90% | 47.58d? | 2007-05-02 | 2009-03-12 | 487d? | 261d |  | S1,S5,C1,C3,C4 | 46006.4h | 36143.9h | IMSTSS |  |  | Rel-8 | SP-37 | Frederic |  |  |
| 223 | 1.70.1 | **General aspects of IMS Sup Services** | 395d? | 2007-09-03 A | 2009-03-06 | 98% | 7.98d? | 2007-09-03 | 2009-03-06 | 395d? | 265d |  | S1,C1,C3,C4 | 9752h | 7058.8h | IMSSS-Gal | Ericsson | Susana Sabater | Rel-8 | SP-37 | Alain |  |  |
| 224 | 1.70.1.1 | Service and Capability for Core IMS - inclusion of TISPAN requirements | 75d? | 2007-09-03 A | 2007-12-14 A | 100% |  | 2007-09-03 | 2007-12-14 | 75d? |  | finish no earlier than 2007-12-14 | S1 | 600h | 600h | TISCAPR8 | Ericsson | Susana Sabater | Rel-8 | SP-37 | Alain |  |  |
| 225 | 1.70.1.2 | Documentation of TISPAN R1 and R2 in CT1 | 208d? | 2007-11-28 A | 2008-09-12 A | 100% |  | 2007-11-28 | 2008-09-12 | 208d? |  | finish no earlier than 2008-09-12 | C1 | 1664h | 1664h | REDOC_TIS-C1 | Nokia Siemens Networks | peter.leis@nsn.com | Rel-8 | SP-38 | Frederic | PCG-21 |  |
| 226 | 1.70.1.3 | Documentation of TISPAN R1 and R2 in CT3 | 333d? | 2007-11-28 A | 2009-03-06 | 95% | 16.65d? | 2007-11-28 | 2009-03-06 | 333d? | 265d | finish no earlier than 2009-03-06 | C3 | 2664h | 2530.8h | REDOC_TIS-C3 | Nokia Siemens Networks | peter.leis@nsn.com | Rel-8 | SP-38 | Gwiho | PCG-21 |  |
| 227 | 1.70.1.4 | Documentation of TISPAN R1 and R2 in CT4 | 208d? | 2007-11-28 A | 2008-09-12 A | 100% |  | 2007-11-28 | 2008-09-12 | 208d? |  | finish no earlier than 2008-09-12 | C4 | 1664h | 1664h | REDOC_TIS-C4 | Nokia Siemens Networks | peter.leis@nsn.com | Rel-8 | SP-38 | Kimmo | PCG-21 |  |
| 228 | 1.70.2 | **IMS Multimedia Telephony Service** | 394d? | 2007-09-10 A | 2009-03-12 | 79% | 81.38d? | 2007-09-10 | 2009-03-12 | 394d? | 261d |  | S1,S5 | 5096h | 2894h | IMS-MMTel |  |  | Rel-8 | SP-37 | Alain |  |  |
| 229 | 1.70.2.1 | Merging TISPAN MMTel [requirements] for Common IMS | 65d? | 2007-09-10 A | 2007-12-07 A | 100% |  | 2007-09-10 | 2007-12-07 | 65d? |  | finish no earlier than 2007-12-07 | S1 | 520h | 520h | TMMTEL | Nokia Siemens Networks |  | Rel-8 | SP-37 | Alain |  |  |
| 230 | 1.70.2.2 | MMTel and Supplementary Services Charging | 309d? | 2008-01-07 A | 2009-03-12 | 75% | 77.25d? | 2008-01-07 | 2009-03-12 | 309d? | 261d | finish no earlier than 2009-03-12 | S5 | 2472h | 1854h | MMTel-CH | Alcatel-Lucent | GARDELLA, Maryse | Rel-8 | SP-38 | Dionisio | PCG-21 |  |
| 231 | 1.70.3 | **Call Completion on Busy Subscriber (CCBS)/Call Completion on Non-Reachable (CCNR) on IMS** | 483d? | 2007-05-02 A | 2009-03-06 | 95% | 25.89d? | 2007-05-02 | 2009-03-06 | 483d? | 265d |  | C1,C3 | 11072h | 10478.5h | CCBS_CCNR | Deutsche Telekom | martin.huelsemann@telekom.de | Rel-8 | SP-38 | Frederic | PCG-21 |  |
| 232 | 1.70.3.1 | Stage 3 CCBS_CCNR | 483d? | 2007-05-02 A | 2009-03-06 | 90% | 48.3d? | 2007-05-02 | 2009-03-06 | 483d? | 265d | finish no earlier than 2009-03-06 | C1 | 3864h | 3477.6h | CCBS_CCNR | Deutsche Telekom | martin.huelsemann@telekom.de | Rel-8 | SP-38 | Frederic | PCG-21 |  |
| 233 | 1.70.3.2 | Stage 3 CCBS_CCNR | 418d? | 2007-05-02 A | 2008-12-05 A | 100% |  | 2007-05-02 | 2008-12-05 | 418d? |  | finish no earlier than 2008-12-05 | C3 | 3344h | 3344h | CCBS_CCNR | Deutsche Telekom | martin.huelsemann@telekom.de | Rel-8 | SP-38 | Gwiho | PCG-21 |  |
| 234 | 1.70.4 | **Flexible Alerting** | 288d? | 2008-01-30 A | 2009-03-06 | 92% | 21.83d? | 2008-01-30 | 2009-03-06 | 288d? | 265d |  | S1,C1 | 5278.4h | 2809.6h | FA | Nortel | milanpa@nortel.com | Rel-8 | SP-39 | Alain | PCG-21 |  |
| 235 | 1.70.4.1 | Stage 1 FA | 92d? | 2008-01-30 A | 2008-06-05 A | 100% |  | 2008-01-30 | 2008-06-05 | 92d? |  |  | S1 | 670.4h | 670.4h | FA | Telecom Italia |  | Rel-8 | SP-39 | Alain | PCG-21 |  |
| 236 | 1.70.4.2 | Stage 3 FA | 288d? | 2008-01-30 A | 2009-03-06 | 90% | 28.8d? | 2008-01-30 | 2009-03-06 | 288d? | 265d | finish no earlier than 2009-03-06 | C1 | 2304h | 2073.6h | FA | Nortel | milanpa@nortel.com | Rel-8 | SP-39 | Frederic | PCG-21 |  |
| 237 | 1.70.5 | **Communication Wait on IMS** | 331d? | 2007-11-30 A | 2009-03-06 | 94% | 18.38d? | 2007-11-30 | 2009-03-06 | 331d? | 265d |  | C1,C3 | 7416h | 7004.14h | CW_IMS | Deutsche Telekom | martin.huelsemann@telekom.de | Rel-8 | SP-38 | Frederic | PCG-21 |  |
| 238 | 1.70.5.1 | Stage 3 CW-IMS | 331d? | 2007-11-30 A | 2009-03-06 | 90% | 33.1d? | 2007-11-30 | 2009-03-06 | 331d? | 265d | finish no earlier than 2009-03-06 | C1 | 2648h | 2383.2h | CW_IMS | Deutsche Telekom | martin.huelsemann@telekom.de | Rel-8 | SP-38 | Frederic | PCG-21 |  |
| 239 | 1.70.5.2 | Stage 3 CW-IMS | 265d? | 2007-11-30 A | 2008-12-05 A | 100% |  | 2007-11-30 | 2008-12-05 | 265d? |  | finish no earlier than 2008-12-05 | C3 | 2120h | 2120h | CW_IMS | Deutsche Telekom | martin.huelsemann@telekom.de | Rel-8 | SP-38 | Gwiho | PCG-21 |  |
| 240 | 1.70.6 | Advice of Charge (AoC) support in IMS Charging | 309d? | 2008-01-07 A | 2009-03-12 | 55% | 139.05d? | 2008-01-07 | 2009-03-12 | 309d? | 261d | finish no earlier than 2009-03-12 | S5 | 2472h | 1359.6h | IMSTSS | Nokia Siemens Networks | GÖRMER, Gerald | Rel-8 | SP-38 | Dionisio | PCG-21 |  |
| 241 | 1.70.7 | Add Interconnection Border Control Function (IBCF) to IMS Charging | 128d? | 2007-09-17 A | 2008-03-12 A | 100% |  | 2007-09-17 | 2008-03-12 | 128d? |  | finish no earlier than 2008-03-12 | S5 | 1024h | 1024h | IMSTSS | Alcatel-Lucent | GARDELLA, Maryse | Rel-8 | SP-37 | Dionisio |  |  |

Notes:
- 215: SA#40 SA1/2 completed. CT#40 WID approved.
- 216: SA#38 WID approved. SA#39 completed / Text3: 22.101
- 217: SA#38 WID approved. SA#40 completed / Text3: 23.292, 23.206
- 218: CT#42 Rel-8 extension to 03/09. CT#41 WID updated CP-080319=>CP-080492. / Text3: 24.292, 24.229
- 219: 23/07/08 Line created at CT1 Zagreb request. CT#41 WID updated CP-080319=>CP-080492. CT#41 work stopped / Text3: 24.293
- 220: CT#42 Rel-8 extension to 03/09. CT#41 WID updated CP-080319=>CP-080492. / Text3: 29.292
- 221: CT#42 completed. CT#41 WID updated CP-080319=>CP-080492. / Text3: 23.003, 29.232, 23.018, 29.002
- 224: SA#39 completed / Text3: 22.228, 22.115, 22.101
- 225: CT#41 completed / Text3: 24.141, 24.147, 24.173, 24.229, 24.247, 24.341, 24.604, 24.605, 24.606, 24.607, 24.608, 24.610, 24.611, 24.616, 24.623, 24.628, 24.629, 24.647, 24.654
- 226: CT#42 Rel-8 extension to 03/09 / Text3: 29.162, 29.163, 29.658
- 227: CT#41 completed / Text3: 29.228, 29.229
- 229: SA#38 completed / Text3: 22.173
- 230: SA#42 Rel-8 extension to 03/09 / Text3: 32.275, 32.298/299
- 232: CT#42 Rel-8 extension to 03/09 / Text3: 24.642, 24.229, 24.173
- 233: CT#42 completed / Text3: 29.163
- 235: SA#40 completed / Text3: 22.173
- 236: CT#42 Rel-8 extension to 03/09 / Text3: 24.239, 24.173
- 238: CT#42 Rel-8 extension to 03/09 / Text3: 24.615, 24.229, 24.173
- 239: CT#42 completed / Text3: 29.163
- 240: SA#42 Rel-8 extension to 03/09 / Text3: 32.280, 32.240/260/296/298/299
- 241: SA#39 completed / Text3: 32.260, 32.298

| ID | WBS | Task | Duration | Start | Finish | Complete | Remaining | Baseline start | Baseline finish | Baseline duration | Total slack | Constraint | Resources | Work | Actual work | Text1 | Text2 | Text4 | Text5 | Text6 | Text7 | Text8 |
| --- | --- | --- | --- | --- | --- | --- | --- | --- | --- | --- | --- | --- | --- | --- | --- | --- | --- | --- | --- | --- | --- | --- |
| 242 | 1.71 | **3GPP2 Input to Common IMS** | 200d? | 2008-03-07 A | 2008-12-11 A | 100% |  | 2008-03-07 | 2008-12-11 | 200d? |  |  | S1,S2,S3,C1,C3,C4 | 8653.2h | 8653.2h | CIMS_3GPP2 | PCG-21 | Nortel | Amar Deol | Rel-8 | SP-39 | Alain |
| 243 | 1.71.1 | Stage 1 CIMS_3GPP2 (SA1) | 30.65d? | 2008-03-12 A | 2008-06-05 A | 100% |  | 2008-03-12 | 2008-06-05 | 30.65d? |  | finish no earlier than 2008-06-12 | S1 | 245.2h | 245.2h | CIMS_3GPP2 | PCG-21 | Nortel | Amar Deol | Rel-8 | SP-39 | Alain |
| 244 | 1.71.2 | Stage 2 CIMS_3GPP2 (SA2) | 62d? | 2008-03-12 A | 2008-06-05 A | 100% |  | 2008-03-12 | 2008-06-05 | 62d? |  | finish no earlier than 2008-09-11 | S2 | 496h | 496h | IMS_Common | PCG-21 | Nortel | Amar Deol | Rel-8 | SP-39 | Maurice |
| 245 | 1.71.3 | Security CIMS_3GPP2 (SA3) | 197d? | 2008-03-12 A | 2008-12-11 A | 100% |  | 2008-03-12 | 2008-12-11 | 197d? |  | finish no earlier than 2008-12-11 | S3 | 1576h | 1576h | IMS_Common | PCG-21 | Nortel | Amar Deol | Rel-8 | SP-39 | Dionisio |
| 246 | 1.71.4 | Stage 3 CIMS_3GPP2 (CT1) | 196d? | 2008-03-07 A | 2008-12-05 A | 100% |  | 2008-03-07 | 2008-12-05 | 196d? |  | finish no earlier than 2008-12-11 | C1 | 1568h | 1568h | REDOC_3GPP2 | PCG-21 | Alcatel-Lucent | orsic@alcatel-lucent.com | Rel-8 | SP-39 | Frederic |
| 247 | 1.71.5 | Stage 3 CIMS_3GPP2 (CT3) | 196d? | 2008-03-07 A | 2008-12-05 A | 100% |  | 2008-03-07 | 2008-12-05 | 196d? |  | finish no earlier than 2008-12-05 | C3 | 1568h | 1568h | REDOC_3GPP2 | PCG-21 | Alcatel-Lucent | orsic@alcatel-lucent.com | Rel-8 | SP-39 | Gwiho |
| 248 | 1.71.6 | Stage 3 CIMS_3GPP2 (CT4) | 200d? | 2008-03-07 A | 2008-12-11 A | 100% |  | 2008-03-07 | 2008-12-11 | 200d? |  | finish no earlier than 2008-12-11 | C4 | 1600h | 1600h | REDOC_3GPP2 | PCG-21 | Alcatel-Lucent | orsic@alcatel-lucent.com | Rel-8 | SP-39 | Kimmo |
| 249 | 1.72 | **IMS Enhancements for support of Packet Cable access** | 388d? | 2006-12-06 A | 2008-05-30 A | 100% |  | 2006-12-06 | 2008-05-30 | 388d? |  |  | S2,S3,C1,C3,C4 | 27448h | 27448h | PktCbl |  | Cablelabs | Bernie McKibben | Rel-8 |  | Maurice |
| 250 | 1.72.1 | **IMS Enhancements for Cable Client Types and Deployment Models** | 345d? | 2007-02-05 A | 2008-05-30 A | 100% |  | 2007-02-05 | 2008-05-30 | 345d? |  |  | S2,C1 | 6992h | 6992h | PktCbl-Deploy |  | Cablelabs | Bernie McKibben | Rel-8 |  | Maurice |
| 251 | 1.72.1.1 | Architecture aspects of PktCbl-Deploy | 219d? | 2007-02-05 A | 2007-12-06 A | 100% |  | 2007-02-05 | 2007-12-06 | 219d? |  | finish no earlier than 2007-12-03 | S2 | 1752h | 1752h | PktCbl-Deploy |  | Cablelabs | Bernie McKibben | Rel-8 |  | Maurice |
| 252 | 1.72.1.2 | CT1 aspects of PktCbl-Deploy | 310d? | 2007-03-26 A | 2008-05-30 A | 100% |  | 2007-03-26 | 2008-05-30 | 310d? |  | finish no earlier than 2008-06-15 | C1 | 2480h | 2480h | PktCbl-Deploy |  | Cablelabs | D.Hancock@ CableLabs.com | Rel-8 |  | Frederic |
| 253 | 1.72.2 | **IMS Inter-working aspects in Support of Cable Regulatory requirements** | 290d? | 2007-02-05 A | 2008-03-15 A | 100% |  | 2007-02-05 | 2008-03-15 | 290d? |  |  | S2,C1,C3 | 5640h | 5640h | PktCbl-Intw |  | Cablelabs | B.McKibben@CableLabs.com | Rel-8 |  | Maurice |
| 254 | 1.72.2.1 | Architecture PktCbl-Interwork | 160d? | 2007-02-05 A | 2007-09-14 A | 100% |  | 2007-02-05 | 2007-09-14 | 160d? |  | start no earlier than 2007-02-05 | S2 | 1280h | 1280h | PktCbl-Intw |  | Cablelabs | B.McKibben@CableLabs.com | Rel-8 |  | Maurice |
| 255 | 1.72.2.2 | CT1,CT3 PktCbl-Interwork | 255d? | 2007-03-26 A | 2008-03-15 A | 100% |  | 2007-03-26 | 2008-03-15 | 255d? |  | finish no earlier than 2008-03-15 | C1,C3 | 2040h | 2040h | PktCbl-Intw |  | Cablelabs | D.Hancock@ CableLabs.com | Rel-8 |  | Frederic |
| 256 | 1.72.3 | **IMS Enhancements for Security Requirements in Support of Cable Deployments** | 388d? | 2006-12-06 A | 2008-05-30 A | 100% |  | 2006-12-06 | 2008-05-30 | 388d? |  |  | S3,C1,C3,C4 | 11712h | 11712h | PktCbl-Sec |  | Cablelabs | s.dotson@cablelabs.com | Rel-8 |  | Dionisio |
| 257 | 1.72.3.1 | SA3 Aspects of PktCbl-Sec | 331d? | 2006-12-06 A | 2008-03-12 A | 100% |  | 2006-12-06 | 2008-03-12 | 331d? |  | finish no earlier than 2007-12-20 | S3 | 2648h | 2648h | PktCbl-Sec |  | Cablelabs | s.dotson@cablelabs.com | Rel-8 |  | Dionisio |
| 258 | 1.72.3.2 | CT1 Aspects of PktCbl-Sec | 310d? | 2007-03-26 A | 2008-05-30 A | 100% |  | 2007-03-26 | 2008-05-30 | 310d? |  | finish no earlier than 2008-06-06 | C1 | 2480h | 2480h | PktCbl-Sec |  | Cablelabs | D.Hancock@ CableLabs.com | Rel-8 |  | Frederic |
| 259 | 1.72.3.3 | CT3 Aspects of PktCbl-Sec | 180d? | 2007-03-26 A | 2007-11-30 A | 100% |  | 2007-03-26 | 2007-11-30 | 180d? |  | finish no earlier than 2008-03-15 | C3 | 1440h | 1440h | PktCbl-Intw | PCG-21 | Cablelabs | D.Hancock@ CableLabs.com | Rel-8 | SP-38 | Gwiho |
| 260 | 1.72.3.4 | CT4 Aspects of PktCbl-Sec | 255d? | 2007-03-26 A | 2008-03-14 A | 100% |  | 2007-03-26 | 2008-03-14 | 255d? |  | finish no earlier than 2008-03-14 | C4 | 2040h | 2040h | PktCbl-Sec |  | Cablelabs | D.Hancock@ CableLabs.com | Rel-8 |  | Kimmo |
| 261 | 1.73 | **IMS System enhancements for corporate network access** | 446d? | 2007-06-22 A | 2009-03-06 | 94% | 28.9d? | 2007-06-22 | 2009-03-06 | 446d? | 265d |  | S2,S1,C1,C4 | 10012.8h | 6501.2h | IMS_Corp |  | Orange | Delphin Barankanira | Rel-8 |  | Maurice |
| 262 | 1.73.1 | SA1 aspects of IMS_Corp | 23.6d? | 2008-03-12 A | 2008-06-05 A | 100% |  | 2008-03-12 | 2008-06-05 | 23.6d? |  | finish no earlier than 2008-06-05 | S1 | 188.8h | 188.8h | IMS_Corp | PCG-21 | Telecom Italia |  | Rel-8 | SP-39 | Alain |
| 263 | 1.73.2 | SA2 aspects of IMS_Corp | 325d? | 2007-06-22 A | 2008-09-18 A | 100% |  | 2007-06-22 | 2008-09-18 | 325d? |  | finish no earlier than 2008-12-25 | S2 | 2600h | 2600h | IMS_Corp |  | Orange | Delphin Barankanira | Rel-8 |  | Maurice |
| 264 | 1.73.3 | CT1 aspects of IMS_Corp | 261d? | 2008-03-07 A | 2009-03-06 | 80% | 52.2d? | 2008-03-07 | 2009-03-06 | 261d? | 265d | finish no earlier than 2009-03-06 | C1 | 2088h | 1670.4h | IMS_Corp | PCG-21 | Alcatel-Lucent | drage@alcatel-lucent.com | Rel-8 | SP-39 | Frederic |
| 265 | 1.73.4 | CT4 aspects of IMS_Corp | 196d? | 2008-02-26 A | 2008-12-05 A | 100% |  | 2008-02-26 | 2008-12-05 | 196d? |  | finish no earlier than 2008-12-11 | C4 | 1568h | 1568h | IMS_Corp | PCG-21 | Alcatel-Lucent | drage@alcatel-lucent.com | Rel-8 | SP-39 | Kimmo |

Notes:
- 242: TSG#42 completed
- 243: SA#40 completed / Text3: 22.228, 22.173, 22.101, 22.153
- 244: SA#40 completed / Text3: 23.002, 23.141, 23.203, 23.167, 23.228
- 245: SA#42 completed [issues addressed under UID_370078 (IMS-Sec)] / Text3: 33.141, 33.203, 33.210
- 246: CT#42 completed. WID updated CP-080218=>CP-080494=>CP-080795 / Text3: 23.218, 24.141, 24.147, 24.173, 24.229, 24.238, 24.247, 24.604, 24.605, 24.606, 24.607, 24.608, 24.610, 24.611, 24.629, 24.930
- 247: CT#42 completed. WID updated CP-080218=>CP-080494=>CP-080795 / Text3: 29.163, 29.212, 29.213, 29.214
- 248: CT#42 completed. WID updated CP-080218=>CP-080494=>CP-080795 / Text3: 29.228, 29.229, 29.328, 29.329
- 249: CT#40 completed
- 250: CT#40 completed
- 251: SA#38 completed / Text3: 23.228
- 252: CT#40 completed
- 253: CT#39 completed
- 254: SA#37 completed / Text3: 23.228
- 255: CT#39 completed / Text3: 24.229
- 256: CT#40 completed
- 257: SA#39 completed / Text3: 33.203, 33.210, 33.220
- 258: CT#40 completed / Text3: 24.229
- 259: CT#38 completed / Text3: 29.163
- 260: CT#39 completed / Text3: 29.228, 29.229, 23.008
- 261: SA#40 SA2 proposed Rel-9 move. Rel-8 extension to Sep 2008 (await output of Workshop). SA#41 work completed (No Stage 2 impacts identified by Joint Workshop)
- 262: SA#40 completed
- 263: SA#41 completed / Text3: 23.228
- 264: CT#42 Rel-8 extension to 03/09 / Text3: 24.229, 24.503
- 265: CT#42 completed / Text3: 29.228, 29.229, 23.003, 23.008, 29.433

| ID | WBS | Task | Duration | Start | Finish | Complete | Remaining | Baseline start | Baseline finish | Baseline duration | Total slack | Constraint | Resources | Work | Actual work | Text1 | Text2 | Text7 | Text8 | Text4 | Text5 | Text6 |
| --- | --- | --- | --- | --- | --- | --- | --- | --- | --- | --- | --- | --- | --- | --- | --- | --- | --- | --- | --- | --- | --- | --- |
| 266 | 1.74 | **Maintenance of TISPAN documentation** | 244d? | 2007-07-02 A | 2008-06-05 A | 100% |  | 2007-07-02 | 2008-06-05 | 244d? |  |  | S2,C1,C3,C4 | 5984h | 5984h | MAINTISP | PCG-21 | SP-38 | Frederic |  |  |  |
| 267 | 1.74.1 | Maintenance of TISPAN R1 | 86d? | 2007-11-09 A | 2008-03-07 A | 100% |  | 2007-11-09 | 2008-03-07 | 86d? |  | start no earlier than 2007-11-09 | C1,C3,C4 | 688h | 688h | MAINT_R1 | PCG-21 | SP-38 | Kimmo | Alcatel-Lucent | drage@alcatel-lucent.com | Rel-7 |
| 268 | 1.74.2 | Maintenance of TISPAN R2 | 86d? | 2007-11-09 A | 2008-03-07 A | 100% |  | 2007-11-09 | 2008-03-07 | 86d? |  | start no earlier than 2007-11-09 | C1,C3,C4 | 688h | 688h | MAINT_R2 | PCG-21 | SP-38 | Kimmo | Alcatel-Lucent | drage@alcatel-lucent.com | Rel-8 |
| 269 | 1.74.3 | Documentation of TISPAN NGN R1 and R2 in 3GPP SA2 | 104d? | 2008-01-14 A | 2008-06-05 A | 100% |  | 2008-01-14 | 2008-06-05 | 104d? |  | finish no earlier than 2008-06-20 | S2 | 832h | 832h | IMS_Comm_Doc | PCG-21 | SP-38 | Maurice | Nokia Siemens Networks | jozsef.varga@nsn.com | Rel-8 |
| 270 | 1.74.4 | Maintenance of TISPAN release 1 common IMS | 114d? | 2007-07-02 A | 2007-12-06 A | 100% |  | 2007-07-02 | 2007-12-06 | 114d? |  | finish no earlier than 2007-12-06 | S2,S1 | 912h | 912h | IMS_Comm_Mtce7 | PCG-21 | SP-38 | Maurice | BT, Ericsson | Dick Knight, Raymond Forbes | Rel-7 |
| 271 | 1.74.5 | Maintenance of TISPAN release 2 common IMS | 114d? | 2007-07-02 A | 2007-12-06 A | 100% |  | 2007-07-02 | 2007-12-06 | 114d? |  | finish no earlier than 2007-12-06 | S2 | 912h | 912h | IMS_Comm_Mtce8 | PCG-21 | SP-38 | Maurice | Telecom Italia | antonio.ascolese@telecomitalia.it | Rel-8 |
| 272 | 1.75 | **IMS Service Continuity** | 258d? | 2008-03-12 A | 2009-03-06 | 97% | 7.98d? | 2008-03-12 | 2009-03-06 | 258d? | 265d |  | S2,S1,C1 | 4664h | 3015.6h | IMS-Cont | PCG-21 | SP-39 | Maurice | LG Electronics | JaeSeung SONG (anthonys@lge.com) | Rel-8 |
| 273 | 1.75.1 | Stage 1 IMS Service Continuity | 62d? | 2008-03-12 A | 2008-06-05 A | 100% |  | 2008-03-12 | 2008-06-05 | 62d? |  | start no earlier than 2008-03-12 | S1 | 496h | 496h | IMS-Cont | PCG-21 | SP-39 | Alain | LG Electronics | JaeSeung SONG (anthonys@lge.com) | Rel-8 |
| 274 | 1.75.2 | Stage 2 IMS Service Continuity | 62d? | 2008-03-12 A | 2008-06-05 A | 100% |  | 2008-03-12 | 2008-06-05 | 62d? |  | finish no earlier than 2008-06-05 | S2 | 496h | 496h | IMS-Cont | PCG-21 | SP-39 | Maurice | LG Electronics | JaeSeung SONG (anthonys@lge.com) | Rel-8 |
| 275 | 1.75.3 | Stage 3 IMS Service Continuity | 201d? | 2008-05-30 A | 2009-03-06 | 95% | 10.05d? | 2008-05-30 | 2009-03-06 | 201d? | 265d | finish no earlier than 2009-03-06 | C1 | 1608h | 1527.6h | IMS-Cont | PCG-21 | SP-40 | Maurice | Huawei | Lili Yang (kadyyang@huawei.com) | Rel-8 |
| 276 | 1.76 | **Security Enhancements for IMS** | 643.3d? | 2006-09-19 A | 2009-03-06 | 73% | 175.49d? | 2006-09-19 | 2009-03-06 | 643.3d? | 265d |  | S3,C1,C4 | 18624h | 11037.6h | IMS-Sec |  | SP-37 | Dionisio | Ericsson | Bengt Sahlin | Rel-8 |
| 277 | 1.76.1 | Stage 2 for IMS-Sec | 466d? | 2007-03-01 A | 2008-12-11 A | 100% |  | 2007-03-01 | 2008-12-11 | 466d? |  | finish no earlier than 2008-12-11 | S3 | 3728h | 3728h | IMS-Sec |  |  | Dionisio | Ericsson | Bengt Sahlin | Rel-8 |
| 278 | 1.76.2 | CT1 part of Stage 3 for IMS-Sec | 392d? | 2006-09-19 A | 2008-12-05 A | 100% |  | 2006-09-19 | 2008-12-05 | 392d? |  | finish no earlier than 2008-12-05 | C1 | 3136h | 3136h | IMS-Sec | PCG-21 | SP-39 | Frederic | Ericsson |  | Rel-8 |
| 279 | 1.76.3 | CT4 part of Stage 3 for IMS-Sec | 457d? | 2007-06-07 | 2009-03-06 |  |  | 2007-06-07 | 2009-03-06 | 457d? | 265d | finish no earlier than 2009-03-06 | C4 | 3656h |  | IMS-Sec | PCG-21 | SP-39 | Frederic | Ericsson |  | Rel-8 |
| 280 | 1.76.4 | CT1 part of NASS Bundled Authentication | 343d? | 2007-11-14 A | 2009-03-06 | 90% | 34.3d? | 2007-11-14 | 2009-03-06 | 343d? | 265d | finish no earlier than 2009-03-06 | C1 | 2744h | 2469.6h | NBA | PCG-21 | SP-38 | Frederic | Alcatel-Lucent | drage@alcatel-lucent.com | Rel-8 |
| 281 | 1.76.5 | CT4 part of NASS Bundled Authentication | 143d? | 2007-11-14 A | 2008-05-30 A | 100% |  | 2007-11-14 | 2008-05-30 | 143d? |  | start no earlier than 2007-11-14 | C4 | 1144h | 1144h | NBA-CT4 | PCG-21 | SP-38 | Kimmo | Alcatel-Lucent |  | Rel-8 |
| 282 | 1.77 | IMS initiated and controlled PSS and MBMS User Service | 262d? | 2008-03-12 A | 2009-03-12 | 80% | 52.4d? | 2008-03-12 | 2009-03-12 | 262d? | 261d | finish no earlier than 2009-03-12 | S4,S3 | 1003.2h | 584h | IMS_PSS_MBMS_US |  |  | Paolo | FT, Ericsson | olle.franceschi@ericsson.com | Rel-8 |
| 283 | 1.78 | **Multimedia interworking between IMS and CS networks** | 836d? | 2005-09-23 A | 2008-12-05 | 99% | 0d? | 2005-09-23 | 2008-12-05 | 836d? | 0d |  | C3,C4 | 16112h | 9816h | MIW-IMS |  |  | Gwiho | Vodafone | nico.gabriele@vodafone.com | Rel-8 |
| 284 | 1.78.1 | Note: Stages 1 and 2 defined in earlier Release | 49d? | 2005-09-23 A | 2005-11-30 A | 100% |  | 2005-09-23 | 2005-11-30 | 49d? |  | start no earlier than 2005-09-23 | S2 | 392h | 392h | MIW-IMS |  |  | Maurice | Vodafone | nico.gabriele@vodafone.com | Rel-8 |
| 285 | 1.78.2 | Stage 3 of MW-IMS | 571d? | 2005-09-23 A | 2007-11-30 A | 100% |  | 2005-09-23 | 2007-11-30 | 571d? |  | finish no earlier than 2007-09-14 | C3 | 4568h | 4568h | MIW-IMS-St3 |  |  | Gwiho | Vodafone | nico.gabriele@vodafone.com | Rel-8 |
| 286 | 1.78.3 | Stage 3 for MW-IMS, MONA extension | 285d? | 2007-11-05 A | 2008-12-05 A | 100% |  | 2007-11-05 | 2008-12-05 | 285d? |  | finish no earlier than 2008-12-05 | C3 | 2280h | 2280h | MIW-IMS | PCG-21 | SP-38 | Gwiho | Vodafone | Christer.Holmberg@ericsson.com | Rel-8 |
| 287 | 1.78.4 | Mn interface (MGCF – IM MGW) | 273d? | 2007-11-21 A | 2008-12-05 A | 100% |  | 2007-11-21 | 2008-12-05 | 273d? |  | finish no earlier than 2008-12-19 | C4 | 2184h | 2184h | MIW-IMS | PCG-21 | SP-38 | Kimmo | Vodafone | Christer.Holmberg@ericsson.com | Rel-8 |
| 288 | 1.79 | IMS Stage 3 IETF Protocol Alignment | 446d? | 2007-06-22 A | 2009-03-06 | 95% | 22.3d? | 2007-06-22 | 2009-03-06 | 446d? | 265d | finish no earlier than 2009-03-06 | C1 | 3568h | 3389.6h | IMSProtoc2 |  |  | Frederic | Alcatel-Lucent | drage@alcatel-lucent.com | Rel-8 |
| 289 | 1.80 | **Interworking between User-to-User Signalling (UUS) and SIP** | 271d? | 2007-11-30 A | 2008-12-12 | 80% | 54.7d? | 2007-11-30 | 2008-12-12 | 271d? | 325d |  | C1,C3 | 6464h | 5159.16h | UUSIW | PCG-21 | SP-38 | Kimmo | Huawei | Lili Yang (kadyyang@huawei.com) | Rel-8 |
| 290 | 1.80.1 | Stage 3 MGCF UUSIW | 266d? | 2007-11-30 A | 2008-12-05 A | 100% |  | 2007-11-30 | 2008-12-05 | 266d? |  | finish no earlier than 2008-12-05 | C1 | 2128h | 2128h | UUSIW | PCG-21 | SP-38 | Frederic | Huawei | Lili Yang (kadyyang@huawei.com) | Rel-8 |
| 291 | 1.80.2 | Stage 3 MGCF UUSIW | 271d? | 2007-11-30 A | 2008-12-12 | 60% | 108.4d? | 2007-11-30 | 2008-12-12 | 271d? | 325d | finish no earlier than 2008-12-12 | C3 | 2168h | 1300.8h | UUSIW | PCG-21 | SP-38 | Gwiho | Huawei | Lili Yang (kadyyang@huawei.com) | Rel-8 |

Notes:
- 266: SA#40 completed
- 267: CT#39 completed / Text3: 24.404, 24.405, 24.406, 24.407, 24.408, 24.410, 24.411, 24.416, 29.421, 24.423, 24.428, 24.429, 29.433, 24.441, 24.403, 29.427, 24.430, 29.412
- 268: CT#39 completed / Text3: 24.406, 24.407, 24.410, 24.411, 24.423, 24.430, 24.447, 24.451, 24.454, 24.503, 24.505, 24.508, 24.516, 24.528, 24.529, 29.412, 29.421, 29.433, 29.458, 29.527
- 269: WID approved SA#38. per OPs & ETSI GA 39. This is a joint effort of SA WG2 and TISPAN WG2. SA#40 completed / Text3: 23.228, 23.204, 23.167
- 270: SA#38 WID and TSs approved. SA#40 WID updated SP-070915=>SP-080315. SA#41 WID updated SP-080315=>SP-080501 / Text3: 22.273, 22.401, 23.406, 23.417, 23.508, 23.509, 23.511, 22.401, 22.173
- 271: SA#38 approved WID and TSs / Text3: 23.506, 23.507,23.517, 23.521
- 272: SA#40 Stage 1/2 completed. CT#40 WID approved
- 273: SA#40 completed
- 274: SA#40 completed / Text3: 23.237, 23.292
- 275: CT#42 Rel-8 extension to 03/09. CT#41 WID updated CP-080317=>CP-080491 / Text3: 24.237, 24.229, 24.216
- 276: SA#36 WID approved
- 277: SA#42 completed. SA#39 SA3 to remove Stage 3 from 33.178-100 for CTx work. SA#40 withdrawn 33.178-100. / Text3: 33.203, 33.141, 33.978, 33.828, 33.803
- 278: CT#42 completed. SA#39 SA3 to remove Stage 3 from 33.178-100 for CT1 work
- 279: CT#42 Rel-8 extension to 03/09. SA#39 SA3 to remove Stage 3 from 33.178-100 for CT1 work
- 280: CT#42 Rel-8 extension to 03/09 / Text3: 24.229
- 281: CT#40 completed / Text3: 29.229, 29.228, 23.008
- 282: SA#42 Rel-8 extension to 03/09. SA#39 WID approved. / Text3: 26.237, 26.234, 26.346, 33.246
- 284: SA#31 Moved from FS section Feb 2006
- 285: Moved from R7 WP because it is part of Feature UID_713024. This feature was extended to R8 by the inclusion (at Nov 2007 CT3 meeting) of Stage 3 extension covering MONA (WI 380021) / Text3: 29.863, 29.163
- 286: CT#42 completed / Text3: 29.863, 29.163
- 287: CT#42 completed / Text3: 29.332
- 288: CT#42 Rel-8 extension to 03/09. WID updated CP-070367=>CP-080794 (Add ability to register multiple access technologies from the same UE simultaneously) / Text3: 23.218, 24.229, 24.930
- 290: CT#42 completed / Text3: 24.279, 24.229
- 291: Depending on IETF draft / Text3: 29.163

| ID | WBS | Task | Type | Duration | Start | Finish | Complete | Remaining | Baseline start | Baseline finish | Baseline duration | Total slack | Constraint | Resources | Work | Actual work | Text1 | Text2 | Text4 | Text5 | Text6 | Text7 | Text8 | Text3 |
| --- | --- | --- | --- | --- | --- | --- | --- | --- | --- | --- | --- | --- | --- | --- | --- | --- | --- | --- | --- | --- | --- | --- | --- | --- |
| 292 | 1.81 | **Support of Overlap signalling** |  | 331d? | 2007-11-30 A | 2009-03-06 | 70% | 98.85d? | 2007-11-30 | 2009-03-06 | 331d? | 265d |  | C3,C1,C4 | 9488.16h | 6654.54h | Overlap | PCG-21 | Deutsche Telekom | r.jesske@telekom.de | Rel-8 | SP-38 | Gwiho |  |
| 293 | 1.81.1 | Stage 3 Overlap (CT1) |  | 266d? | 2007-11-30 A | 2008-12-05 | 60% | 106.4d? | 2007-11-30 | 2008-12-05 | 266d? | 330d | finish no earlier than 2008-12-05 | C1 | 2128h | 1276.8h | Overlap | PCG-21 | Deutsche Telekom | r.jesske@telekom.de | Rel-8 | SP-38 | Frederic | 24.229 |
| 294 | 1.81.2 | Stage 3 Overlap (CT3) |  | 331d? | 2007-11-30 A | 2009-03-06 | 55% | 148.95d? | 2007-11-30 | 2009-03-06 | 331d? | 265d | finish no earlier than 2009-03-06 | C3 | 2648h | 1456.4h | Overlap | PCG-21 | Deutsche Telekom | r.jesske@telekom.de | Rel-8 | SP-38 | Gwiho | 29.163 |
| 295 | 1.81.3 | Stage 3 Overlap (CT4) |  | 258.02d? | 2007-11-30 A | 2008-12-05 A | 100% |  | 2007-11-30 | 2008-12-05 | 258.02d? |  | start no earlier than 2007-11-30 | C4 | 2064.16h | 2064.16h | Overlap | PCG-21 | Deutsche Telekom | r.jesske@telekom.de | Rel-8 | SP-38 | Gwiho | 29.228, 29.229 |
| 296 | 1.82 | AS/MRFC Stage 2 and 3 |  | 278d? | 2007-11-14 A | 2008-12-05 A | 100% |  | 2007-11-14 | 2008-12-05 | 278d? |  | finish no earlier than 2008-12-05 | C1 | 2224h | 2224h | MRFC_TS | PCG-21 | HP | mark.syrett@hp.com | Rel-8 | SP-38 | Frederic | 23.218, 24.229, 24.147, 24.247 |
| 297 | 1.83 | **IMS Restoration Procedures** |  | 201d? | 2008-05-30 A | 2009-03-06 | 48% | 105.53d? | 2008-05-30 | 2009-03-06 | 201d? | 265d |  | C4,C1 | 4824h | 2291.4h | IMS_RP | PCG-21 | Ericsson | german.blanco@ericsson.com | Rel-8 | SP-40 | Kimmo |  |
| 298 | 1.83.1 | IMS Restoration Procedures |  | 201d? | 2008-05-30 A | 2009-03-06 | 95% | 10.05d? | 2008-05-30 | 2009-03-06 | 201d? | 265d | finish no earlier than 2009-03-06 | C4 | 1608h | 1527.6h | IMS_RP | PCG-21 | Ericsson | german.blanco@ericsson.com | Rel-8 | SP-40 | Kimmo | 23.380, 29.228, 29.229, 29.230, 23.008 |
| 299 | 1.83.2 | IMS Restoration Procedures |  | 201d? | 2008-05-30 | 2009-03-06 |  |  | 2008-05-30 | 2009-03-06 | 201d? | 265d | finish no earlier than 2009-03-06 | C1 | 1608h |  | IMS_RP | PCG-21 | Ericsson | german.blanco@ericsson.com | Rel-8 | SP-40 | Frederic | 24.229 |
| 300 | 1.84 | IMS Application Server Service Data Descriptions for AS interoperability |  | 125d? | 2008-09-12 A | 2009-03-06 | 90% | 12.5d? | 2008-09-12 | 2009-03-06 | 125d? | 265d | finish no earlier than 2009-03-06 | C4 | 1000h | 900h | IMS_ASIO | PCG-21 | Alcatel-Lucent | nhberry@alcatel-lucent.com | Rel-8 | CP-41 | Kimmo | 29.328, 29.329, 29.364 |
| 301 | 1.85 | **IMS – Interconnection Border Control Function (IBCF) – Transition Gateway (TrGW); Ix Interface; Stage 3** |  | 126d? | 2008-09-12 A | 2009-03-06 | 33% | 84d? | 2008-09-12 | 2009-03-06 | 126d? | 265d |  | C4,C3 | 2822.4h | 940.8h | IMS_IBCF | PCG-21 | Alcatel-Lucent | bruno.landais@alcatel-lucent.fr | Rel-8 | CP-41 | Kimmo |  |
| 302 | 1.85.1 | CT4 part of IMS_IBCF |  | 126d? | 2008-09-12 A | 2009-03-06 | 20% | 100.8d? | 2008-09-12 | 2009-03-06 | 126d? | 265d | finish no earlier than 2009-03-06 | C4 | 1008h | 201.6h | IMS_IBCF | PCG-21 | Alcatel-Lucent | bruno.landais@alcatel-lucent.fr | Rel-8 | CP-41 | Kimmo | 29.238 |
| 303 | 1.85.2 | CT3 part of IMS_IBCF |  | 100.8d? | 2008-09-12 A | 2009-03-06 | 50% | 50.4d? | 2008-09-12 | 2009-03-06 | 100.8d? | 265d | finish no earlier than 2009-03-06 | C3 | 806.4h | 403.2h | IMS_IBCF | PCG-21 | Alcatel-Lucent | bruno.landais@alcatel-lucent.fr | Rel-8 | CP-41 | Kimmo | 29.162, 29.235 |
| 304 | 1.86 | IMS Application Level Gateway Control Function (ALGCF) – IMS Access Media Gateway (IMA-MGW); Iq Interface; Stage 3 |  | 126d? | 2008-09-12 A | 2009-03-06 | 10% | 113.4d? | 2008-09-12 | 2009-03-06 | 126d? | 265d | finish no earlier than 2009-03-06 | C4 | 1008h | 100.8h | IMS_AGCF | PCG-21 | Alcatel-Lucent | bruno.landais@alcatel-lucent.fr | Rel-8 | CP-41 | Kimmo | 23.334. 29.334 |
| 305 | 1.87 | **I-WLAN Network Selection Principle (NSP)** |  | 390d? | 2007-06-14 A | 2008-12-11 | 98% | 9.72d? | 2007-06-14 | 2008-12-11 | 390d? | 326d |  | S1,C1,C6 | 5635.2h | 2452.48h | IWLANNSP |  | Telefonica O2 | chris.friel@o2.com | Rel-8 |  | Alain |  |
| 306 | 1.87.1 | Stage 1 for I-WLAN NSP | milestone | 0d? | 2007-06-14 A | 2007-06-14 A | 100% |  | 2007-06-14 | 2007-06-14 | 0d? |  |  | S1 |  |  | IWLANNSP | PCG-21 | Telefonica O2 | chris.friel@o2.com | Rel-8 | SP-39 | Alain | 22.234 |
| 307 | 1.87.2 | Stage 3 for I-WLAN NSP |  | 196d? | 2008-03-07 A | 2008-12-05 | 96% | 7.84d? | 2008-03-07 | 2008-12-05 | 196d? | 330d | finish no earlier than 2008-12-05 | C1 | 1568h | 1505.28h | IWLANNSP | PCG-21 | RIM | Adrian Buckley (abuckley@rim.com) | Rel-8 | CP-39 | Frederic | 24.234 |
| 308 | 1.87.3 | Stage 3 for I-WLAN NSP |  | 118.4d? | 2008-03-07 A | 2008-12-11 A | 100% |  | 2008-03-07 | 2008-12-11 | 118.4d? |  | finish no earlier than 2008-12-11 | C6 | 947.2h | 947.2h | IWLANNSP | PCG-21 | RIM | Adrian Buckley (abuckley@rim.com) | Rel-8 | CP-39 | Frederic | 31.102, 31.111 |
| 309 | 1.88 | **Mobility between 3GPP-WLAN Interworking and 3GPP Systems** |  | 321d? | 2007-09-14 A | 2008-12-05 | 99% | 2.68d? | 2007-09-14 | 2008-12-05 | 321d? | 330d |  | S2,C1 | 5176h | 5132.82h | IWLAN_Mob |  | Orange | xiaobao.chen@orange-ftgroup.com | Rel-8 | SP-37 | Maurice |  |
| 310 | 1.88.1 | Stage 2: I-WLAN Mobility |  | 190d? | 2007-09-14 A | 2008-06-05 A | 100% |  | 2007-09-14 | 2008-06-05 | 190d? |  | finish no earlier than 2008-09-08 | S2 | 1520h | 1520h | IWLAN_Mob | PCG-21 | Orange | xiaobao.chen@orange-ftgroup.com | Rel-8 | SP-38 | Maurice | 23.237 |
| 311 | 1.88.2 | CT1 aspects of I-WLAN Mobility |  | 136d? | 2008-05-30 A | 2008-12-05 | 98% | 2.72d? | 2008-05-30 | 2008-12-05 | 136d? | 330d | finish no earlier than 2008-12-05 | C1 | 1088h | 1066.24h | IWLAN_Mob | PCG-21 | Orange | reina.nader@orange-ftgroup.com | Rel-8 | CP-40 | Frederic | 24.327, 24.303 |
| 312 | 1.89 | **Enhancements for VGCS Applications (EVA)** |  | 713d? | 2006-03-15 A | 2008-12-05 | 98% | 12.89d? | 2006-03-15 | 2008-12-05 | 713d? | 330d |  | S1,C1,C4,G2 | 20216h | 15777.6h | EVA |  | Nortel | deola@nortel.com | Rel-8 |  | Alain |  |
| 313 | 1.89.1 | SA1 aspects of EVA |  | 191d? | 2006-03-15 A | 2006-12-06 A | 100% |  | 2006-03-15 | 2006-12-06 | 191d? |  | finish no earlier than 2006-12-06 | S1 | 1528h | 1528h | EVA-s1 |  | Nortel | deola@nortel.com | Rel-8 |  | Alain | 42.068 |
| 314 | 1.89.2 | VGCS/VBS and GPRS Interactions |  | 145d? | 2007-09-03 A | 2008-03-21 A | 100% |  | 2007-09-03 | 2008-03-21 | 145d? |  | finish no earlier than 2008-03-21 | S1 | 1160h | 1160h | EVA |  | Huawei | Ling Liu | Rel-8 | SP-37 | Alain | 42.068, 42.069 |
| 315 | 1.89.3 | CT1 aspects of EVA |  | 656d? | 2006-06-02 A | 2008-12-05 | 95% | 32.8d? | 2006-06-02 | 2008-12-05 | 656d? | 330d | finish no earlier than 2008-12-05 | C1 | 5248h | 4985.6h | EVA |  | Nortel | milanpa@nortel.com | Rel-8 |  | Frederic | 43.068, 44.068 |
| 316 | 1.89.4 | CT4 aspects of EVA |  | 391d? | 2006-06-02 A | 2007-11-30 A | 100% |  | 2006-06-02 | 2007-11-30 | 391d? |  | finish no earlier than 2007-06-01 | C4 | 3128h | 3128h | EVA |  | Nortel |  | Rel-8 |  | Kimmo | 29.002 |
| 317 | 1.89.5 | GERAN2 aspects of EVA |  | 431d? | 2006-06-30 A | 2008-02-22 A | 100% |  | 2006-06-30 | 2008-02-22 | 431d? |  | finish no earlier than 2008-02-22 | G2 | 3448h | 3448h | EVA-EVGCSA |  | Nortel | frank.billenkamp@nortel.com | Rel-8 |  | Girt | 44.018, 48.008 |

Notes:
- 292: CT#42 Rel-8 extension to 03/09
- 293: CT#42 Rel-8 extension to 03/09
- 294: CT#42 Rel-8 extension to 03/09 (only if overlap interworking is CT3 work; otherwise CT3 is 100% complete)
- 295: CT#42 completed
- 296: Triggered by Study UID_7048 (MRFC). CT#42 completed
- 297: CT#42 Rel-8 extension to 03/09. CT#41 WID updated CP-080281=>CP-080447. Triggered by Study TR 23.820 (FS_IMS_RP) UID_350018
- 298: CT#42 Rel-8 extension to 03/09
- 299: CT#42 Rel-8 extension to 03/09
- 300: CT#42 Rel-8 extension to 03/09. Triggered by UID_360030 (FS_IMS_ASIO)
- 301: CT#42 Rel-8 extension to 03/09. WID updated CP-080483=>CP-080746
- 302: CT#42 Rel-8 extension to 03/09. WID updated CP-080483=>CP-080746
- 303: CT#42 Rel-8 extension to 03/09. WID updated CP-080483=>CP-080746
- 304: CT#42 Rel-8 extension to 03/09. WID updated CP-080448=>CP-080723
- 305: SA#36 Stage 1 completed
- 306: SA#36 completed
- 307: 08/08 az split CT1 from CT6 part in WID
- 308: CT#42 completed
- 309: SA#40 Stage 2 completed. CT#40 WID approved
- 310: SA#40 completed
- 311: CT#40 WID approved
- 312: Stage 1/2 completed
- 313: SA#38 completed
- 314: SA#39 completed
- 316: CT#38 completed
- 317: GP#37 completed

| ID | WBS | Task | Type | Duration | Start | Finish | Complete | Remaining | Baseline start | Baseline finish | Baseline duration | Total slack | Constraint | Resources | Work | Actual work | Text1 | Text4 | Text5 | Text6 | Text8 | Text3 | Text12 | Text7 | Text2 |
| --- | --- | --- | --- | --- | --- | --- | --- | --- | --- | --- | --- | --- | --- | --- | --- | --- | --- | --- | --- | --- | --- | --- | --- | --- | --- |
| 318 | 1.90 | **Personal Network Management** |  | 890d? | 2005-07-11 A | 2008-12-05 | 99% | 4.29d? | 2005-07-11 | 2008-12-05 | 890d? | 330d |  | S1,C1,C4,S3 | 23240h | 14820.8h | PNM | Vodafone | armin.toepfer@vodafone.com | Rel-8 | Alain |  |  |  |  |
| 319 | 1.90.1 | Stage 1 for PNM |  | 276d? | 2005-07-11 A | 2006-07-31 A | 100% |  | 2005-07-11 | 2006-07-31 | 276d? |  | start no earlier than 2005-07-11 | S1 | 2208h | 2208h | PNM | Vodafone | armin.toepfer@vodafone.com | Rel-8 | Alain | 22.259 |  |  |  |
| 320 | 1.90.2 | Stage 2 for PNM |  | 445d? | 2007-03-26 A | 2008-12-05 A | 100% |  | 2007-03-26 | 2008-12-05 | 445d? |  | finish no earlier than 2008-12-05 | C1 | 3560h | 3560h | PNM | Vodafone | yang.lu@vodafone.com | Rel-8 | Frederic | 23.259 |  |  |  |
| 321 | 1.90.3 | **Stage 3 for PNM** |  | 445d? | 2007-03-26 A | 2008-12-05 | 99% | 4.45d? | 2007-03-26 | 2008-12-05 | 445d? | 330d |  | C1,C4 | 10680h | 7172.8h | PNM | Vodafone | yang.lu@vodafone.com | Rel-8 | Frederic |  |  |  |  |
| 322 | 1.90.3.1 | CT1 aspects of Stage 3 PNM |  | 445d? | 2007-03-26 A | 2008-12-05 | 98% | 8.9d? | 2007-03-26 | 2008-12-05 | 445d? | 330d | finish no earlier than 2008-12-05 | C1 | 3560h | 3488.8h | PNM | Vodafone | yang.lu@vodafone.com | Rel-8 | Frederic | 24.259, 24.229 |  |  |  |
| 323 | 1.90.3.2 | CT4 aspects of Stage 3 PNM |  | 445d? | 2007-03-26 A | 2008-12-05 A | 100% |  | 2007-03-26 | 2008-12-05 | 445d? |  | finish no earlier than 2008-12-11 | C4 | 3560h | 3560h | PNM | Vodafone | yang.lu@vodafone.com | Rel-8 | Kimmo | 23.008, 23.018, 29.002, 29.328, 29.329 |  |  |  |
| 324 | 1.90.4 | Key establishment between a UICC hosting device and a remote device |  | 235d? | 2006-12-06 A | 2007-10-30 A | 100% |  | 2006-12-06 | 2007-10-30 | 235d? |  | finish no earlier than 2007-10-30 | S3 | 1880h | 1880h | PNM | Ericsson | Vesa.Lehtovirta@ericsson.com | Rel-7 | Michael | 33.259 |  |  |  |
| 325 | 1.90.5 | Deleted - Actual Requirements of PNM | milestone | 0d? | 2007-03-26 A | 2007-03-26 A | 100% |  | 2007-03-26 | 2007-03-26 | 0d? |  | finish no earlier than 2007-03-26 | C1 |  |  | PNM | Ericsson |  | Rel-8 | Frederic |  | SP-37 |  |  |
| 326 | 1.91 | **eCall Data Transfer** |  | 637d? | 2006-09-28 A | 2009-03-06 | 93% | 44.07d? | 2006-09-28 | 2009-03-06 | 637d? | 265d |  | S1,C1 | 9744h | 7366.4h | Edata | Airbiquity | rrobinson@airbiquity.com | Rel-8 | Alain |  |  |  |  |
| 327 | 1.91.1 | eData Requirements |  | 380d? | 2006-09-28 A | 2008-03-12 A | 100% |  | 2006-09-28 | 2008-03-12 | 380d? |  | finish no earlier than 2006-12-07 | S1 | 3040h | 3040h | EData | Airbiquity | rrobinson@airbiquity.com | Rel-8 | Alain | 22.101, 22.105 |  | SP-37 |  |
| 328 | 1.91.2 | Transfer of data during an emergency call |  | 201d? | 2008-05-30 A | 2009-03-06 | 80% | 40.2d? | 2008-05-30 | 2009-03-06 | 201d? | 265d | finish no earlier than 2009-03-06 | C1 | 1608h | 1286.4h | EData | T-Mobile | Dieter Jacobsohn | Rel-8 | Kimmo | 24.008 |  | SP-40 | PCG-21 |
| 329 | 1.92 | eCall data transfer Phase 2: Comparison of alternative in-band modem solutions and standardization of one in-band modem solution |  | 471d? | 2007-12-06 A | 2009-09-24 | 85% | 70.65d? | 2007-12-06 | 2009-09-24 | 471d? | 121d | finish no earlier than 2009-09-24 | S4 | 3768h | 3202.8h | eCall_Phase2 | Airbiquity | lhong@airbiquity.com & rrobinson@airbiquity.com | Rel-8 | Paolo | 26.967, 26.267, 26.268 |  |  |  |
| 330 | 1.93 | **IP Interconnection of Services** |  | 668d? | 2006-08-16 A | 2009-03-06 | 79% | 140.54d? | 2006-08-16 | 2009-03-06 | 668d? | 265d |  | S1,S2,S5,C3,C4 | 21688h | 9233.2h | IPinterc | Telefonica O2 | chris.friel@O2.com | Rel-8 | Alain |  |  | SP-38 | PCG-21 |
| 331 | 1.93.1 | Stage 1 for IPinterc |  | 70d? | 2007-12-06 A | 2008-03-12 A | 100% |  | 2007-12-06 | 2008-03-12 | 70d? |  | start no earlier than 2007-12-06 | S1 | 560h | 560h | IPinterc | Telefonica O2 | chris.friel@O2.com | Rel-8 | Alain | 22.101, 22.228 |  | SP-38 | PCG-21 |
| 332 | 1.93.2 | **System enhancements for interconnection interfaces between two IMSs** |  | 668d? | 2006-08-16 A | 2009-03-06 | 97% | 19.64d? | 2006-08-16 | 2009-03-06 | 668d? | 265d |  | S2,S5,C3 | 11616h | 6743.6h | IMS_NNI | Telecom Italia | Mario Madella (mario.madella@telecomitalia.it) | Rel-8 | Maurice |  |  |  |  |
| 333 | 1.93.2.1 | Stage 2 for IMS_NNI |  | 120d? | 2007-06-22 A | 2007-12-06 A | 100% |  | 2007-06-22 | 2007-12-06 | 120d? |  | finish no earlier than 2007-12-21 | S2 | 960h | 960h | IMS_NNI | Telecom Italia | Mario Madella (mario.madella@telecomitalia.it) | Rel-8 | Maurice | 23.002, 23.228 |  |  |  |
| 334 | 1.93.2.2 | IMS inter-operator service interconnection interface |  | 461d? | 2007-06-01 A | 2009-03-06 | 95% | 23.05d? | 2007-06-01 | 2009-03-06 | 461d? | 265d | finish no earlier than 2009-03-06 | C3 | 3688h | 3503.6h | FBI2-IOPSI | Telecom Italia | antonio.ascolese@telecomitalia.it | Rel-8 | Gwiho | 29.865, 29.165 |  |  |  |
| 335 | 1.93.2.3 | Charging harmonization for NGN between 3GPP and ATIS-TMOC |  | 51d? | 2006-09-28 A | 2006-12-07 A | 100% |  | 2006-09-28 | 2006-12-07 | 51d? |  | finish no earlier than 2006-12-07 | S5 | 408h | 408h | FBI2-TISP2-CH | Amdocs | Brown, Yishai | Rel-8 | Dionisio | 32.297 |  |  |  |
| 336 | 1.93.2.4 | Deleted - Protocol impact of FBI for TISPAN R2 |  | 152d? | 2006-08-16 A | 2007-03-15 A | 100% |  | 2006-08-16 | 2007-03-15 | 152d? |  | finish no earlier than 2007-03-15 | C1 | 1216h | 1216h | FBI2-TISP2-c1 | Ericsson |  | Rel-8 | Frederic |  | SP-38 |  |  |
| 337 | 1.93.2.5 | Deleted (never approved) - Stage 2 of FBI for TISPAN R2 - Rel 8 | milestone | 0d? | 2007-11-30 A | 2007-11-30 A | 100% |  | 2007-11-30 | 2007-11-30 | 0d? |  | finish no earlier than 2007-11-30 | S2 |  |  | FBI2-TISP2-s2 | Nokia Siemens Networks |  | Rel-8 | Maurice |  | SP-36 |  |  |
| 338 | 1.93.3 | **CS-IBCF and CS-TrGW definition in 3GPP specifications** |  | 201d? | 2008-05-30 A | 2009-03-06 | 40% | 120.6d? | 2008-05-30 | 2009-03-06 | 201d? | 265d |  | C3,C4 | 4824h | 1929.6h | CS-IBCF | Telecom Italia | mauro.ficaccio@telecomitalia.it | Rel-8 | Kimmo |  |  | CP-40 | PCG-21 |
| 339 | 1.93.3.1 | CT3 aspects CS-IBCF |  | 201d? | 2008-05-30 A | 2009-03-06 | 70% | 60.3d? | 2008-05-30 | 2009-03-06 | 201d? | 265d | finish no earlier than 2009-03-06 | C3 | 1608h | 1125.6h | CS-IBCF | Telecom Italia | mauro.ficaccio@telecomitalia.it | Rel-8 | Kimmo | 29.235 |  | CP-40 | PCG-21 |
| 340 | 1.93.3.2 | CT4 aspects CS-IBCF |  | 201d? | 2008-05-30 A | 2009-03-06 | 10% | 180.9d? | 2008-05-30 | 2009-03-06 | 201d? | 265d | finish no earlier than 2009-03-06 | C4 | 1608h | 160.8h | CS-IBCF | Telecom Italia | mauro.ficaccio@telecomitalia.it | Rel-8 | Kimmo | 29.238, 23.231, 29.232 |  | CP-40 | PCG-21 |
| 341 | 1.94 | **Support of (G)MSC-S – (G)MSC-S Nc Interface based on the SIP-I protocol** |  | 386d? | 2007-09-14 A | 2009-03-06 | 98% | 6.78d? | 2007-09-14 | 2009-03-06 | 386d? | 265d |  | C4,C3 | 11872h | 8842.4h | SIP_Nc | Vodafone | David.Hutton@vodafone.com | Rel-8 | Kimmo |  |  |  |  |
| 342 | 1.94.1 | Stage 1 for SIP_Nc (covered by Feature IPinterc) |  | 70d? | 2007-12-06 A | 2008-03-12 A | 100% |  | 2007-12-06 | 2008-03-12 | 70d? |  | start no earlier than 2007-12-06 | S1 | 560h | 560h | IPinterc | Telefonica O2 | chris.friel@O2.com | Rel-8 | Alain | 22.101, 22.228 |  |  | PCG-21 |
| 343 | 1.94.2 | SIP-I based circuit-switched core network; Stage 2 |  | 321d? | 2007-09-14 A | 2008-12-05 A | 100% |  | 2007-09-14 | 2008-12-05 | 321d? |  | finish no earlier than 2008-12-11 | C4 | 2568h | 2568h | SIP_Nc-St2 | Vodafone | David.Hutton@vodafone.com | Rel-8 | Kimmo | 23.231, 23.153, 23.205 |  |  |  |
| 344 | 1.94.3 | Application of SIP-I Protocols to Circuit Switched (CS) core network architecture; Stage 3 |  | 321d? | 2007-09-14 A | 2008-12-05 A | 100% |  | 2007-09-14 | 2008-12-05 | 321d? |  | finish no earlier than 2008-12-11 | C4 | 2568h | 2568h | SIP_Nc-St3 | Vodafone | David.Hutton@vodafone.com | Rel-8 | Kimmo | 29.231, 29.232, 29.332 |  |  |  |
| 345 | 1.94.4 | Interworking between the 3GPP CS domain with SIP-I as signalling protocol and other networks |  | 386d? | 2007-09-14 A | 2009-03-06 | 95% | 19.3d? | 2007-09-14 | 2009-03-06 | 386d? | 265d | finish no earlier than 2009-03-06 | C3 | 3088h | 2933.6h | SIP_Nc | Nokia Siemens Networks | Thomas.Belling@nsn.com | Rel-8 | Gwiho | 29.235, 23.172, 23.202, 29.007, 29.163, 29.414 |  |  |  |

Notes:
- 318: Feb 06 moved FS=>Feature. SA#31 Stage 1 completed. SA#40 WID updated with reduced scope SP-060574=>SP-080327
- 319: SA#31 completed. SA#40 WID updated SP-060574=>SP-080327
- 320: CT#42 completed
- 321: Moved from FS section Feb 06: SP-33: Create new section to capture the PNM stage 2 aspects and identify any impacts to existing stage 2 specifications.
- 323: CT#42 No impact to CT4 specifications
- 324: 07/08: Moved from Rel-7 to Rel-8 WP; Feature=>BB as per SA3/SA WID in SP-060839, keeping the same UID
- 325: SA#37 stopped
- 326: SA#39 completed. Linked to SA4 Feature UID_34042 (eCall_Phase2). CT#40 approved Stage 3 WID.
- 327: SA4 to select a suitable in-band modem. SA#39 completed
- 328: CT#42 Rel-8 extension to 03/09
- 329: SA#42 Rel-8 extension to 09/09. Triggered by Study UID_360015 (eCALLIBMS). Linked to SA1 Feature UID_330005 (EData).
- 330: CT#42 Rel-8 extension to 03/09. SA#39 Stage 1 completed. Covers Stage 1 for IMS_NNI (UID_360024), SIP_Nc (UID_360026) , CS-IBCF (UID_400008). SA#41 WID updated SP-070871=>SP-080565 [Moved under it as BBs 3 existing Features: CS-IBCF, IMS_NNI, SIP_Nc]
- 331: SA#39 completed.
- 332: CT#42 Rel-8 extension to 03/09. SA#36 Name changed from "System enhancements for TISPAN Rel2". Stage 1 in Feature UID_380060 (IPinterc). CT#41 updated WID CP-080054=>CP-080578 (Feature IMS_NNI=>BB under Ipinterc)
- 333: SA#38 completed. SA#41 WID updated SP-070490=>SP-080554
- 334: CT#42 Rel-8 extension to 03/09. CT#41 updated WID CP-080054=>CP-080578.
- 335: SA#34 completed
- 336: SA#38 stopped
- 337: SA#36 stopped
- 338: CT#42 Rel-8 extension to 03/09. CT#41 WID updated CP-080392=>CP-080577 (Feature CS-IBCF=>BB under Ipinterc).
- 339: CT#42 Rel-8 extension to 03/09
- 340: CT#42 Rel-8 extension to 03/09
- 341: Stage 1 in Feature UID_380060 (IPinterc). CT#40 updated WID CP-070517=>CP-080282
- 342: 22/07/08 Created. Stage 1 for SIP_Nc (covered by SA1 Feature UID_380060 Ipinterc)
- 343: CT#42 completed
- 344: CT#42 completed
- 345: CT#42 target 12/08=>03/09

| ID | WBS | Task | Type | Duration | Start | Finish | Complete | Remaining | Baseline start | Baseline finish | Baseline duration | Total slack | Constraint | Resources | Work | Actual work | Text1 | Text4 | Text5 | Text6 | Text7 | Text8 | Text3 | Text2 |
| --- | --- | --- | --- | --- | --- | --- | --- | --- | --- | --- | --- | --- | --- | --- | --- | --- | --- | --- | --- | --- | --- | --- | --- | --- |
| 346 | 1.95 | **Earthquake and Tsunami Warning System** |  | 325d? | 2007-09-10 A | 2008-12-05 A | 100% |  | 2007-09-10 | 2008-12-05 | 325d? |  |  | S1,S2,C1 | 5904h | 5904h | ETWS | NTT DoCoMo | kitaharar@nttdocomo.co.jp | Rel-8 | SP-37 | Alain |  |  |
| 347 | 1.95.1 | Stage 1 for ETWS |  | 133d? | 2007-09-10 A | 2008-03-12 A | 100% |  | 2007-09-10 | 2008-03-12 | 133d? |  | finish no earlier than 2008-03-12 | S1 | 1064h | 1064h | ETWS | NTT DoCoMo | kitaharar@nttdocomo.co.jp | Rel-8 | SP-37 | Alain | 22.168 |  |
| 348 | 1.95.2 | SA2 aspects of ETWS |  | 179d? | 2008-01-14 A | 2008-09-18 A | 100% |  | 2008-01-14 | 2008-09-18 | 179d? |  | finish no earlier than 2008-09-08 | S2 | 1432h | 1432h | ETWS | NTT DoCoMo | tanakai@nttdocomo.co.jp | Rel-8 | SP-38 | Maurice | 23.828, 23.401 | PCG-21 |
| 349 | 1.95.3 | CT1 aspects of ETWS |  | 50.5d? | 2008-05-30 A | 2008-12-05 A | 100% |  | 2008-05-30 | 2008-12-05 | 50.5d? |  | finish no earlier than 2008-12-05 | C1 | 404h | 404h | ETWS | NTT DoCoMo | yamashitahi@s1.nttdocomo.co.jp | Rel-8 | CP-40 | Kimmo | 23.041 | PCG-21 |
| 350 | 1.95.4 | CT4 aspects of ETWS |  | 50.5d? | 2008-09-26 A | 2008-12-05 A | 100% |  | 2008-09-26 | 2008-12-05 | 50.5d? |  | finish no earlier than 2008-12-05 | C4 | 404h | 404h | ETWS | NTT DoCoMo | yamashitahi@s1.nttdocomo.co.jp | Rel-8 | CP-40 | Kimmo | 29.168 | PCG-21 |
| 351 | 1.96 | **Storage and easy access of In Case of Emergency numbers on UICC** |  | 519d? | 2007-03-13 A | 2009-03-06 | 97% | 17.24d? | 2007-03-13 | 2009-03-06 | 519d? | 265d |  | S1,C6 | 8864h | 8569.48h | ICE | Vodafone | armin.toepfer@vodafone.com | Rel-8 | SP-38 | Alain |  | PCG-21 |
| 352 | 1.96.1 | Stage 1 for ICE |  | 262d? | 2007-03-13 A | 2008-03-12 A | 100% |  | 2007-03-13 | 2008-03-12 | 262d? |  | finish no earlier than 2008-03-12 | S1 | 2096h | 2096h | ICE | Vodafone | armin.toepfer@vodafone.com | Rel-8 | SP-38 | Alain | 22.030, 22.101 | PCG-21 |
| 353 | 1.96.2 | CT6 aspects of ICE |  | 519d? | 2007-03-13 A | 2009-03-06 | 95% | 25.95d? | 2007-03-13 | 2009-03-06 | 519d? | 265d | finish no earlier than 2009-03-06 | C6 | 4152h | 3944.4h | ICE | Vodafone | armin.toepfer@vodafone.com | Rel-8 | SP-38 | Alain | 31.102 | PCG-21 |
| 354 | 1.97 | Local Charging Zone Requirements |  | 380d? | 2006-09-28 A | 2008-03-12 A | 100% |  | 2006-09-28 | 2008-03-12 | 380d? |  | finish no earlier than 2006-12-07 | S1 | 3040h | 3040h | LCZR | China Mobile | liuhongyfw@chinamobile.com | Rel-8 |  | Alain | 22.115 |  |
| 355 | 1.98 | **Customized Alerting Tone (CAT) Service** |  | 588d? | 2006-12-06 A | 2009-03-06 | 79% | 125.19d? | 2006-12-06 | 2009-03-06 | 588d? | 265d |  | S1,C1,C3,C4 | 9534h | 5105.04h | CAT | China Mobile | fenglingjuan@chinamobile.com | Rel-8 |  | Alain |  |  |
| 356 | 1.98.1 | Stage 1 for CAT |  | 207d? | 2006-12-06 A | 2007-09-20 A | 100% |  | 2006-12-06 | 2007-09-20 | 207d? |  | start no earlier than 2006-12-06 | S1 | 1656h | 1656h | CAT | China Mobile | fenglingjuan@chinamobile.com | Rel-8 | SP-37 | Alain | 22.182 |  |
| 357 | 1.98.2 | TISPAN requirements for customized multimedia information services |  | 71d? | 2007-09-03 A | 2007-12-10 A | 100% |  | 2007-09-03 | 2007-12-10 | 71d? |  | finish no earlier than 2007-12-10 | S1 | 568h | 568h | TISCMI | China Mobile | Feng Lingjuan | Rel-8 | SP-37 | Alain | 22.182 |  |
| 358 | 1.98.3 | IMS CAT Supplementary Service |  | 164d? | 2008-04-21 A | 2008-12-05 A | 100% |  | 2008-04-21 | 2008-12-05 | 164d? |  | finish no earlier than 2008-12-05 | C1 | 1312h | 1312h | CAT-SS | Nortel | milanpa@nortel.com | Rel-8 | CP-39 | Frederic | 24.182 | PCG-21 |
| 359 | 1.98.4 | CAT solution for voice and video call in CS domain |  | 184.8d? | 2008-03-12 A | 2008-12-05 | 10% | 166.32d? | 2008-03-12 | 2008-12-05 | 184.8d? | 330d | finish no earlier than 2008-12-05 | C3 | 1478.4h | 147.84h | CAT-SS | Nortel | milanpa@nortel.com | Rel-8 | CP-39 | Gwiho | 29.163 | PCG-21 |
| 360 | 1.98.5 | CAT Service in 3GPP CS domain |  | 126d? | 2008-09-12 A | 2009-03-06 | 95% | 6.3d? | 2008-09-12 | 2009-03-06 | 126d? | 265d | finish no earlier than 2009-03-06 | C4 | 1008h | 957.6h | CAT-3G_CS | China Mobile | zhaoyuyi@chinamobile.com | Rel-8 | CP-41 |  | 23.205, 23.231, 29.002 | PCG-21 |
| 361 | 1.98.6 | CAT Service in 3GPP CS domain |  | 57.95d? | 2008-09-12 A | 2008-12-05 A | 100% |  | 2008-09-12 | 2008-12-05 | 57.95d? |  | start no earlier than 2008-09-12 | C1 | 463.6h | 463.6h | CAT-3G_CS | China Mobile | zhaoyuyi@chinamobile.com | Rel-8 | CP-41 |  | 24.008, 23.014 | PCG-21 |
| 362 | 1.99 | **Service-Level Interworking for Messaging Services** |  | 444d? | 2007-03-26 A | 2008-12-05 | 99% | 2.42d? | 2007-03-26 | 2008-12-05 | 444d? | 330d |  | S1,S2,C3,C1 | 7544h | 3970.24h | MESSIW | Huawei | ling.liu@huawei.com; duanxiaoqin@huawei.com | Rel-8 |  | Alain |  |  |
| 363 | 1.99.1 | Stage 1 for MESSIW | milestone | 0d? | 2007-03-26 A | 2007-03-26 A | 100% |  | 2007-03-26 | 2007-03-26 | 0d? |  | finish no earlier than 2007-12-01 | S1 |  |  | MESSIW | Huawei | ling.liu@huawei.com | Rel-8 |  | Alain | 22.105, 22.340 |  |
| 364 | 1.99.2 | Stage 2 for MESSIW |  | 227d? | 2007-04-26 A | 2008-03-07 A | 100% |  | 2007-04-26 | 2008-03-07 | 227d? |  | finish no earlier than 2008-03-07 | S2 | 1816h | 1816h | MESSIW | Huawei | patrice.hede@huawei.com | Rel-8 |  | Maurice | 23.811, 23.204 |  |
| 365 | 1.99.3 | Stage 3 for MESSIW |  | 136d? | 2008-05-30 A | 2008-12-05 | 98% | 2.72d? | 2008-05-30 | 2008-12-05 | 136d? | 330d | finish no earlier than 2008-12-05 | C3 | 1088h | 1066.24h | MESSIW | Huawei | xupeili@huawei.com | Rel-8 | CP-40 | Gwiho | 29.311 | PCG-21 |
| 366 | 1.99.4 | Stage 3 for MESSIW |  | 136d? | 2008-05-30 A | 2008-12-05 A | 100% |  | 2008-05-30 | 2008-12-05 | 136d? |  | finish no earlier than 2008-12-12 | C1 | 1088h | 1088h | MESSIW | Huawei | xupeili@huawei.com | Rel-8 | CP-40 | Frederic | 24.229 | PCG-21 |
| 367 | 1.100 | **Multimedia Priority Service** |  | 717d? | 2006-06-08 A | 2009-03-06 | 44% | 404.92d? | 2006-06-08 | 2009-03-06 | 717d? | 265d |  | S1,C1,C3,C4 | 18648h | 8116.62h | PRIOR | Telcordia | jgarraha@telcordia.com | Rel-8 |  | Alain |  |  |
| 368 | 1.100.1 | Service Requirements for PRIOR |  | 391d? | 2006-06-08 A | 2007-12-06 A | 100% |  | 2006-06-08 | 2007-12-06 | 391d? |  | finish no earlier than 2007-11-30 | S1 | 3128h | 3128h | PRIOR-EMR | Telcordia | jgarraha@telcordia.com | Rel-8 |  | Alain | 22.153 |  |
| 369 | 1.100.2 | Stage 3 for PRIOR |  | 591d? | 2006-12-01 A | 2009-03-06 | 50% | 295.5d? | 2006-12-01 | 2009-03-06 | 591d? | 265d | finish no earlier than 2009-03-06 | C1 | 4728h | 2364h | PRIOR | Alcatel-Lucent | drage@alcatel-lucent.com | Rel-8 |  | Frederic | 24.229 |  |
| 370 | 1.100.3 | Stage 3 for PRIOR |  | 316d? | 2007-09-21 | 2008-12-05 |  |  | 2007-09-21 | 2008-12-05 | 316d? | 330d | finish no earlier than 2008-12-05 | C3 | 2528h |  | PRIOR | Alcatel-Lucent | drage@alcatel-lucent.com | Rel-8 | SP-37 | Gwiho | 29.212, 29.213, 29.214, 29.163 |  |
| 371 | 1.100.4 | Stage 3 for PRIOR |  | 316d? | 2007-09-21 A | 2008-12-05 | 5% | 300d? | 2007-09-21 | 2008-12-05 | 316d? | 330d | finish no earlier than 2008-12-05 | C4 | 2528h | 128h | PRIOR | Alcatel-Lucent | drage@alcatel-lucent.com | Rel-8 | SP-37 | Kimmo | 23.008, 29.228, 29.229 |  |

Notes:
- 346: CT#42 completed. SA#38 WID approved. Larger scope Feature UID_380057 (PWS) moved to Rel-9. No SA2 impact.
- 347: SA#39 completed
- 348: SA#41 completed . SA#40 extension to Sep 2008 on impacts of adding the CBC to MME interface.
- 349: CT#42 completed. WID updated CP-080318=>CP-080659=>CP-080951
- 350: CT#42 completed. WID updated CP-080318=>CP-080659=>CP-080951
- 351: SA#39 Stage 1 completed. CT#41 completed
- 352: SA#39 Stage 1 completed
- 353: CT#42 Rel-8 extension to 03/09 (add ICE Graphics as per SA1 request)
- 354: SA#39 Stage 1 completed
- 355: Conflict 3GPP vs. 3GPP2 IMS CAT. SA#40 extension to Sep 2008 for SA2 (Forking, Early session model)
- 357: SA#38 completed
- 358: CT#42 completed. CT#41 WID updated CP-080074=>CP-080496.
- 359: CT#41 WID updated CP-080074=>CP-080496. Triggered by Study UID_360031 (FS_CAT_VVC_CS) TR 29.882.
- 360: CT#42 Rel-8 extension to 03/09. Triggered by Study UID_360031 (FS_CAT_VVC_CS) TR 29.882.
- 361: Triggered by Study UID_360031 (FS_CAT_VVC_CS) TR 29.882. CT#42 completed
- 362: SA#39 Stage 2 completed. CT#40 added New Stage 3 WID.
- 363: SA#35 completed
- 364: SA#39 completed
- 365: CT#42 WID updated CP-080391=>CP-080575=>CP-080773
- 366: CT#42 completed. WID updated CP-080391=>CP-080575=>CP-080773
- 367: SA#38 Stage 1 completed. No Stage 2 identified
- 368: SA#38 completed
- 369: CT#42 Rel-8 extension to 03/09

| ID | WBS | Task | Duration | Start | Finish | Complete | Remaining | Baseline start | Baseline finish | Baseline duration | Total slack | Constraint | Resources | Work | Actual work | Text1 | Text4 | Text5 | Text6 | Text8 | Text3 | Text7 | Text12 | Text2 |
| --- | --- | --- | --- | --- | --- | --- | --- | --- | --- | --- | --- | --- | --- | --- | --- | --- | --- | --- | --- | --- | --- | --- | --- | --- |
| 372 | 1.101 | **OSA Rel-8** | 202d? | 2007-08-23 A | 2008-05-30 A | 100% |  | 2007-08-23 | 2008-05-30 | 202d? |  |  | S1,C5 | 23552h | 23552h | OSA8 | Orange | Song Dong | Rel-8 | Alain |  |  |  |  |
| 373 | 1.101.1 | OSA Stage 1 - Service Requirements | 145d? | 2007-08-23 A | 2008-03-12 A | 100% |  | 2007-08-23 | 2008-03-12 | 145d? |  | finish no earlier than 2007-12-04 | S1 | 1160h | 1160h | OSA8 | Orange, AePONA | Song Dong | Rel-8 | Alain | 22.127 |  |  |  |
| 374 | 1.101.2 | OSA Stage 1 - NGN Service Requirement | 140d? | 2007-09-03 A | 2008-03-14 A | 100% |  | 2007-09-03 | 2008-03-14 | 140d? |  | finish no earlier than 2008-03-14 | S1 | 1120h | 1120h | OSA8-IMS | Orange | Song Dong | Rel-8 | Alain | 22.127 | SP-37 |  |  |
| 375 | 1.101.3 | **OSA Stage 2/3 enhancements** | 157d? | 2007-10-25 A | 2008-05-30 A | 100% |  | 2007-10-25 | 2008-05-30 | 157d? |  |  | C5 | 20016h | 20016h | OSA8 | Orange | salim.mouniralaoui@orange-ftgroup.com | Rel-8 | Gwiho | 23.198, 29.198, 29.199 |  |  |  |
| 376 | 1.101.3.1 | Delete - Ensure Parlay-X composable with identity management frameworks, in particular Liberty Alliance | 157d? | 2007-10-25 A | 2008-05-30 A | 100% |  | 2007-10-25 | 2008-05-30 | 157d? |  | finish no earlier than 2008-12-25 | C5 | 1256h | 1256h | OSA8 | Ericsson, FT/Orange, Sprint, Telecom Italia | catherine.mulligan@ericsson.com | Rel-8 | Gwiho | existing 29.199-xy | CP-37 | CP-40 |  |
| 377 | 1.101.3.2 | Parlay-X Content Management web service (store/manage meta-data) | 157d? | 2007-10-25 A | 2008-05-30 A | 100% |  | 2007-10-25 | 2008-05-30 | 157d? |  | finish no earlier than 2008-12-04 | C5 | 1256h | 1256h | OSA8 | ETRI | Yoo, Hyunkyung (hkyoo@etri.re.kr) | Rel-8 | Gwiho | 29.199-21 | CP-37 |  |  |
| 378 | 1.101.3.3 | Parlay-X Policy web service | 157d? | 2007-10-25 A | 2008-05-30 A | 100% |  | 2007-10-25 | 2008-05-30 | 157d? |  | finish no earlier than 2008-12-04 | C5 | 1256h | 1256h | OSA8 | ETRI | Park, Yoo-mi ( parkym@etri.re.kr) | Rel-8 | Gwiho | 29.199-22 | CP-37 |  |  |
| 379 | 1.101.3.4 | Parlay-X Terminal status web service | 157d? | 2007-10-25 A | 2008-05-30 A | 100% |  | 2007-10-25 | 2008-05-30 | 157d? |  | finish no earlier than 2008-05-30 | C5 | 1256h | 1256h | OSA8 | Orange | salim.mouniralaoui@orange-ftgroup.com | Rel-8 | Gwiho | 29.199-08 | CP-37 |  |  |
| 380 | 1.101.3.5 | Delete - Identify communication format used by a particular application | 157d? | 2007-10-25 A | 2008-05-30 A | 100% |  | 2007-10-25 | 2008-05-30 | 157d? |  | finish no earlier than 2008-05-30 | C5 | 1256h | 1256h | OSA8 | Ericsson | catherine.mulligan@ericsson.com | Rel-8 | Gwiho | existing 29.199-xy | CP-37 | CP-40 |  |
| 381 | 1.101.3.6 | Delete - Security on User Profile Management - reuse GUP API (22.127 CR 0084 S1-071794) | 128d? | 2007-12-05 A | 2008-05-30 A | 100% |  | 2007-12-05 | 2008-05-30 | 128d? |  | finish no earlier than 2008-12-25 | C5 | 1024h | 1024h | OSA8 | Telecom Italia | vincenzo.amorino@telecomitalia.it | Rel-8 | Gwiho | PXWS Framework | CP-38 | CP-40 | PCG-21 |
| 382 | 1.101.3.7 | Delete - Privacy on Subscriber Identity (Liberty Alliance, OASIS) (22.127 CR 0085 S1-071835) | 128d? | 2007-12-05 A | 2008-05-30 A | 100% |  | 2007-12-05 | 2008-05-30 | 128d? |  | finish no earlier than 2008-12-25 | C5 | 1024h | 1024h | OSA8 | Telecom Italia | vincenzo.amorino@telecomitalia.it | Rel-8 | Gwiho | PXWS Framework | CP-38 | CP-40 | PCG-21 |
| 383 | 1.101.3.8 | Delete - Topology Hiding (22.127 CR 0086 S1-071838) | 128d? | 2007-12-05 A | 2008-05-30 A | 100% |  | 2007-12-05 | 2008-05-30 | 128d? |  | finish no earlier than 2008-12-25 | C5 | 1024h | 1024h | OSA8 | Telecom Italia | vincenzo.amorino@telecomitalia.it | Rel-8 | Gwiho | PXWS Framework | CP-38 | CP-40 | PCG-21 |
| 384 | 1.101.3.9 | Delete - Subscriber event notification (22.127 CR 0087 S1-071836) | 128d? | 2007-12-05 A | 2008-05-30 A | 100% |  | 2007-12-05 | 2008-05-30 | 128d? |  | finish no earlier than 2008-12-25 | C5 | 1024h | 1024h | OSA8 | Telecom Italia | vincenzo.amorino@telecomitalia.it | Rel-8 | Gwiho | PXWS Framework | CP-38 | CP-40 | PCG-21 |
| 385 | 1.101.3.10 | Delete - Event notification (22.127 CR 0088 S1-071762) | 128d? | 2007-12-05 A | 2008-05-30 A | 100% |  | 2007-12-05 | 2008-05-30 | 128d? |  | finish no earlier than 2008-12-25 | C5 | 1024h | 1024h | OSA8 | Telecom Italia | vincenzo.amorino@telecomitalia.it | Rel-8 | Gwiho | PXWS Framework | CP-38 | CP-40 | PCG-21 |
| 386 | 1.101.3.11 | Delete - Access policy (22.127 CR 0089 S1-071763) | 128d? | 2007-12-05 A | 2008-05-30 A | 100% |  | 2007-12-05 | 2008-05-30 | 128d? |  | finish no earlier than 2008-12-25 | C5 | 1024h | 1024h | OSA8 | Telecom Italia | vincenzo.amorino@telecomitalia.it | Rel-8 | Gwiho | PXWS Framework | CP-38 | CP-40 | PCG-21 |
| 387 | 1.101.3.12 | Delete - API usage accounting (22.127 CR 0090 S1-071792) | 128d? | 2007-12-05 A | 2008-05-30 A | 100% |  | 2007-12-05 | 2008-05-30 | 128d? |  | finish no earlier than 2008-12-25 | C5 | 1024h | 1024h | OSA8 | Telecom Italia | vincenzo.amorino@telecomitalia.it | Rel-8 | Gwiho | PXWS Framework | CP-38 | CP-40 | PCG-21 |
| 388 | 1.101.3.13 | Presence alignment with OMA and IETF (22.127 CR 0092 S1-071764) | 128d? | 2007-12-05 A | 2008-05-30 A | 100% |  | 2007-12-05 | 2008-05-30 | 128d? |  | finish no earlier than 2008-05-30 | C5 | 1024h | 1024h | OSA8 | Ericsson | catherine.mulligan@ericsson.com | Rel-8 | Gwiho | 29.199-14/13 | CP-38 |  | PCG-21 |
| 389 | 1.101.3.14 | Delete - Service identification (22.127 CR 0095 S1-071837) | 128d? | 2007-12-05 A | 2008-05-30 A | 100% |  | 2007-12-05 | 2008-05-30 | 128d? |  | finish no earlier than 2008-05-30 | C5 | 1024h | 1024h | OSA8 | Ericsson | catherine.mulligan@ericsson.com | Rel-8 | Gwiho | existing 29.199-xy | CP-38 | CP-40 | PCG-21 |
| 390 | 1.101.3.15 | Framework Enterprise Operator (Service Subscription function) | 102d? | 2008-01-10 A | 2008-05-30 A | 100% |  | 2008-01-10 | 2008-05-30 | 102d? |  | finish no earlier than 2008-05-30 | C5 | 816h | 816h | OSA8 | AePONA | Alan.Taylor@aepona.com | Rel-8 | Gwiho | 29.198-03 | CP-39 |  | PCG-21 |
| 391 | 1.101.3.16 | Mobility Emergency Location | 102d? | 2008-01-10 A | 2008-05-30 A | 100% |  | 2008-01-10 | 2008-05-30 | 102d? |  | finish no earlier than 2008-05-30 | C5 | 816h | 816h | OSA8 | AePONA | Alan.Taylor@aepona.com | Rel-8 | Gwiho | 29.198-06 | CP-39 |  | PCG-21 |
| 392 | 1.101.3.17 | Connectivity Manager SCF | 102d? | 2008-01-10 A | 2008-05-30 A | 100% |  | 2008-01-10 | 2008-05-30 | 102d? |  |  | C5 | 816h | 816h | OSA8 | AePONA | Alan.Taylor@aepona.com | Rel-8 | Gwiho | 29.198-10 | CP-39 |  | PCG-21 |
| 393 | 1.101.3.18 | PAM Presence Agent | 102d? | 2008-01-10 A | 2008-05-30 A | 100% |  | 2008-01-10 | 2008-05-30 | 102d? |  | finish no earlier than 2008-05-30 | C5 | 816h | 816h | OSA8 | AePONA | Alan.Taylor@aepona.com | Rel-8 | Gwiho | 29.198-14 | CP-39 |  | PCG-21 |
| 394 | 1.102 | **Paging Permission with Access Control (PPACR)** | 389d? | 2007-06-12 A | 2008-12-05 | 99% | 0d? | 2007-06-12 | 2008-12-05 | 389d? | 0d |  | S1,C1 | 5888h | 3328h | PPACR | NTT DoCoMo | Morita Takashi | Rel-8 | Alain |  |  |  |  |
| 395 | 1.102.1 | Stage 1 for PPACR | 69d? | 2007-06-12 A | 2007-09-14 A | 100% |  | 2007-06-12 | 2007-09-14 | 69d? |  | finish no earlier than 2007-09-14 | S1 | 552h | 552h | PPACR-S1 | NTT DoCoMo | Morita Takashi | Rel-8 | Alain | 22.011 | SP-37 |  |  |
| 396 | 1.102.2 | Stage 3 for PPACR (CT1) | 278d? | 2007-11-14 A | 2008-12-05 A | 100% |  | 2007-11-14 | 2008-12-05 | 278d? |  | finish no earlier than 2008-12-05 | C1 | 2224h | 2224h | PPACR-CT1 | NTT DoCoMo |  | Rel-8 | Frederic | 24.008, 23.122, 24.301 | CP-38 |  | PCG-21 |

Notes:
- 372: TSG#40 completed. New OSA work in OMA. SA1 need to remove unfulfilled Requirements to align with CT5 Stage 2/3 reality.
- 373: TSG#40 New OSA work in OMA. SA1 to remove non-fulfilled Requirements.
- 374: TSG#40 New OSA work in OMA. SA1 to remove non-fulfilled Requirements.
- 375: CT#40 WID updated CP-070349=>CP-080252. Started work completed. Unfulfilled Rel-8 Stage 1 and New OSA work to be done in OMA. SA1 needs to remove non-fulfilled requirements in 22.127
- 376: CT#40: Work moved to OMA
- 377: CT#40 completed
- 378: CT#40 completed
- 379: CT#40 completed
- 380: CT#40: Work moved to OMA
- 381: SA#38 SP-070853 R8 CRs 22.127 OSA Stage 1. CT#40: Work moved to OMA
- 382: SA#38 SP-070853 R8 CRs 22.127 OSA Stage 1. CT#40: Work moved to OMA
- 383: SA#38 SP-070853 R8 CRs 22.127 OSA Stage 1. CT#40: Work moved to OMA
- 384: SA#38 SP-070853 R8 CRs 22.127 OSA Stage 1. CT#40: Work moved to OMA
- 385: SA#38 SP-070853 R8 CRs 22.127 OSA Stage 1. CT#40: Work moved to OMA
- 386: SA#38 SP-070853 R8 CRs 22.127 OSA Stage 1. CT#40: Work moved to OMA
- 387: SA#38 SP-070853 R8 CRs 22.127 OSA Stage 1. CT#40: Work moved to OMA
- 388: CT#40 completed
- 389: SA#38 SP-070853 R8 CRs 22.127 OSA Stage 1. CT#40: Work moved to OMA
- 390: CT#40 completed
- 391: CT#40 completed
- 392: CT#40 completed
- 393: CT#40 completed
- 394: Triggered by Study UID_330016 (PPAC). SA#37 Stage 1 completed
- 395: SA#37 completed
- 396: CT#42 completed

| ID | WBS | Task | Duration | Start | Finish | Complete | Remaining | Baseline start | Baseline finish | Baseline duration | Total slack | Constraint | Resources | Work | Actual work | Text1 | Text4 | Text6 | Text7 | Text8 | Text2 |
| --- | --- | --- | --- | --- | --- | --- | --- | --- | --- | --- | --- | --- | --- | --- | --- | --- | --- | --- | --- | --- | --- |
| 397 | 1.103 | **Value-Added Services for Short Message Service** | 390d? | 2007-09-10 A | 2009-03-06 | 38% | 242.51d? | 2007-09-10 | 2009-03-06 | 390d? | 265d |  | S1,C4,C1 | 6200h | 2228.8h | VAS4SMS | China Mobile | Rel-8 | SP-37 | Alain |  |
| 398 | 1.103.1 | Stage 1 for VAS4SMS | 133d? | 2007-09-10 A | 2008-03-12 A | 100% |  | 2007-09-10 | 2008-03-12 | 133d? |  | finish no earlier than 2008-03-21 | S1 | 1064h | 1064h | VAS4SMS | China Mobile | Rel-8 | SP-37 | Alain |  |
| 399 | 1.103.2 | VAS4SMS Interface and Signalling Flow | 126d? | 2008-09-12 A | 2009-03-06 | 10% | 113.4d? | 2008-09-12 | 2009-03-06 | 126d? | 265d | finish no earlier than 2009-03-06 | C4 | 1008h | 100.8h | VAS4SMS | China Mobile | Rel-8 | CP-41 |  | PCG-21 |
| 400 | 1.103.3 | VAS4SMS Interface and Signalling Flow | 126d? | 2008-09-08 | 2009-03-06 |  |  | 2008-09-08 | 2009-03-06 | 126d? | 265d | finish no earlier than 2009-03-06 | C1 | 1008h |  | VAS4SMS | China Mobile | Rel-8 | CP-41 |  | PCG-21 |
| 401 | 1.104 | **Charging for multi-phases services** | 70d? | 2007-12-06 A | 2008-03-12 A | 100% |  | 2007-12-06 | 2008-03-12 | 70d? |  |  | S1 | 560h | 560h | CHRGMPH | Telecom Italia | Rel-8 | SP-38 | Alain | PCG-21 |
| 402 | 1.104.1 | Stage 1 for CHRGMPH | 70d? | 2007-12-06 A | 2008-03-12 A | 100% |  | 2007-12-06 | 2008-03-12 | 70d? |  | start no earlier than 2007-12-06 | S1 | 560h | 560h | CHRGMPH-s1 | Telecom Italia | Rel-8 | SP-38 | Alain | PCG-21 |
| 403 | 1.105 | **Home NodeB / eNodeB** | 331d? | 2007-12-06 A | 2009-03-12 | 67% | 110.45d? | 2007-12-06 | 2009-03-12 | 331d? | 261d |  | S1,C1 | 6280h | 2980h | HomeNB | Vodafone | Rel-8 | SP-38 | Alain | PCG-21 |
| 404 | 1.105.1 | Stage 1 for HNB_eHNB | 70d? | 2007-12-06 A | 2008-03-12 A | 100% |  | 2007-12-06 | 2008-03-12 | 70d? |  | start no earlier than 2007-12-06 | S1 | 560h | 560h | HomeNB-S1 | Vodafone | Rel-8 | SP-38 | Alain | PCG-21 |
| 405 | 1.105.2 | CSG and Idle Mode Mobility for LTE Home eNodeB | 126d? | 2008-09-12 A | 2009-03-06 | 70% | 37.8d? | 2008-09-12 | 2009-03-06 | 126d? | 265d | finish no earlier than 2009-03-06 | C1 | 1008h | 705.6h | HomeNB-LTE | Huawei | Rel-8 | CP-41 |  | PCG-21 |
| 406 | 1.105.3 | CSG and Idle Mode Mobility for 3G Home NodeB | 126d? | 2008-09-12 A | 2009-03-06 | 70% | 37.8d? | 2008-09-12 | 2009-03-06 | 126d? | 265d | finish no earlier than 2009-03-06 | C1 | 1008h | 705.6h | HomeNB-3G | Qualcomm | Rel-8 | CP-41 |  | PCG-21 |
| 407 | 1.105.4 | Support of Closed Subscriber Group (CSG) | 66d? | 2008-12-05 A | 2009-03-06 | 85% | 9.9d? | 2008-12-05 | 2009-03-06 | 66d? | 265d | finish no earlier than 2009-03-06 | C4 | 528h | 448.8h | HomeNB | CT#42 | Rel-8 |  |  |  |
| 408 | 1.105.5 | 3G Home NodeB OAM&P Type 1 Interface | 66d? | 2008-12-11 | 2009-03-12 |  |  | 2008-12-11 | 2009-03-12 | 66d? | 261d | finish no earlier than 2009-03-12 | S5 | 528h |  | HomeNB-3G_OAM |  | Rel-8 |  |  |  |
| 409 | 1.106 | **UTRA HNB** | 261d? | 2008-03-07 A | 2009-03-06 | 89% | 28.94d? | 2008-03-07 | 2009-03-06 | 261d? | 265d |  | R2,R4,R3 | 6872h | 6110.1h | HNB |  | Rel-8 | SP-39 | Juergen | PCG-21 |
| 410 | 1.106.1 | Support of UTRA HNB | 201d? | 2008-05-30 A | 2009-03-06 | 80% | 40.2d? | 2008-05-30 | 2009-03-06 | 201d? | 265d | finish no earlier than 2009-03-06 | R2 | 1608h | 1286.4h | HNB-supp | Huawei | Rel-8 | SP-40 | Joern | PCG-21 |
| 411 | 1.106.2 | FDD Home NodeB RF requirements | 261d? | 2008-03-07 A | 2009-03-06 | 90% | 26.1d? | 2008-03-07 | 2009-03-06 | 261d? | 265d | finish no earlier than 2009-03-06 | R4 | 2088h | 1879.2h | HNB-RF | Motorola | Rel-8 | SP-39 | Stefania | PCG-21 |
| 412 | 1.106.3 | UTRAN Architecture for 3G HNB | 136d? | 2008-05-30 A | 2008-12-05 A | 100% |  | 2008-05-30 | 2008-12-05 | 136d? |  | finish no earlier than 2008-12-05 | R3 | 1088h | 1088h | HNB-arch | Alcatel-Lucent | Rel-8 | SP-40 | Juergen | PCG-21 |
| 413 | 1.107 | Lawful Interception in the 3GPP Rel-8 | 524d? | 2007-03-12 A | 2009-03-12 | 60% | 209.6d? | 2007-03-12 | 2009-03-12 | 524d? | 261d | finish no earlier than 2009-03-12 | S3 | 4192h | 2515.2h | LI8 | BMWi, Verizon | Rel-8 |  | Dionisio |  |
| 414 | 1.108 | **Generic Bootstrapping Architecture Push Function** | 318d? | 2008-03-12 A | 2009-05-29 | 40% | 191.29d? | 2008-03-12 | 2009-05-29 | 318d? | 205d |  | S3,C1,C4 | 8972.8h | 2561.6h | GBAPush | Ericsson | Rel-8 | SP-39 | Dionisio | PCG-21 |
| 415 | 1.108.1 | SA3 part of GBAPush | 193d? | 2008-03-12 A | 2008-12-05 A | 100% |  | 2008-03-12 | 2008-12-05 | 193d? |  | finish no earlier than 2008-12-05 | S3 | 1544h | 1544h | GBAPush | Ericsson | Rel-8 | SP-39 | Dionisio | PCG-21 |
| 416 | 1.108.2 | SA3 GBAPush enhancement | 318d? | 2008-03-12 A | 2009-05-29 | 40% | 190.8d? | 2008-03-12 | 2009-05-29 | 318d? | 205d | finish no earlier than 2009-05-29 | S3 | 2544h | 1017.6h | GBAPush | Ericsson | Rel-9 | SP-39 | Dionisio | PCG-21 |
| 417 | 1.108.3 | CT1 part of GBAPush | 113.8d? | 2008-03-12 | 2008-12-05 |  |  | 2008-03-12 | 2008-12-05 | 113.8d? | 330d | finish no earlier than 2008-12-05 | C1 | 910.4h |  | GBAPush | Ericsson | Rel-8 | SP-39 | Dionisio | PCG-21 |
| 418 | 1.108.4 | CT4 part of GBAPush | 178.8d? | 2008-03-12 | 2009-03-06 |  |  | 2008-03-12 | 2009-03-06 | 178.8d? | 265d | finish no earlier than 2009-03-06 | C4 | 1430.4h |  | GBAPush | Ericsson | Rel-8 | SP-39 | Dionisio | PCG-21 |
| 419 | 1.109 | Requirements and Test methods for Wideband Terminals | 197d? | 2008-03-12 A | 2008-12-11 A | 100% |  | 2008-03-12 | 2008-12-11 | 197d? |  | start no earlier than 2008-03-12 | S4 | 1576h | 1576h | RETEM_WB_T | FT, Ericsson | Rel-8 |  | Paolo |  |
| 420 | 1.110 | Extending PSS and MBMS User Services for optimized Mobile TV | 266d? | 2007-12-06 A | 2008-12-11 A | 100% |  | 2007-12-06 | 2008-12-11 | 266d? |  | finish no earlier than 2008-12-11 | S4 | 2128h | 2128h | PSS_MBMS_OMTV | Ericsson | Rel-8 |  | Paolo |  |

Notes:
- 397: CT#42 Rel-8 extension to 03/09. SA#39 Stage 1 completed / Text5: Wu Bin (wubin@chinamobile.com)
- 398: SA#39 completed / Text3: 22.142 / Text5: Wu Bin (wubin@chinamobile.com)
- 399: CT#42 Rel-8 extension to 03/09. WID updated CP-080444=>CP-080721 / Text3: 29.002, 23.142 / Text5: Wu Bin (wubin@chinamobile.com)
- 400: CT#42 Rel-8 extension to 03/09. WID updated CP-080444=>CP-080721 / Text3: 23.040 / Text5: Wu Bin (wubin@chinamobile.com)
- 401: SA#39 completed / Text3: 22.115 / Text5: Marco.DeLuca1@telecomitalia.it
- 402: SA#39 completed / Text3: 22.115 / Text5: Marco.DeLuca1@telecomitalia.it
- 403: SA#39 Stage 1 completed / Text5: John Watson
- 404: SA#39 completed / Text3: 22.011, 22.115 / Text5: John Watson
- 405: CT#42 Rel-8 extension to 03/09 / Text3: 23.122 24.301, 24.801, 24.285 / Text5: Zhang Peng
- 406: CT#42 Rel-8 extension to 03/09. WID updated CP-080499=>CP-080792 / Text3: 23.122, 24.008, 24.285 [Allowed Closed Subscriber Group (CSG) List] / Text5: Osok Song
- 407: CT#42 Rel-8 extension to 03/09 in CP-080967. Align with SA1 22.011 CR0139 (Home network independent support of roamers in CSG) / Text3: 29.002, 29.272, 23.008, 23.003 / Text5: CT#42
- 408: SA#42 Rel-8 extension to 03/09
- 409: RP#40 WID approved RP-080483
- 410: SR in RP-081041. RP#42 Rel-8 extension to 03/09. RP#41 WID updated RP-080483=>RP-080752. / Text3: 25.304, 25.331, 25.306 / Text5: yangxudong@huawei.com
- 411: SR in RP-080816. RP#42 Rel-8 extension to 03/09. WID updated RP-080234=>RP-080971 / Text3: 25.104, 25.141, 25.9xx (FDD Home NodeB RF Requirements) / Text5: howard.thomas@motorola.com
- 412: SR in RP-081073. RP#42 completed / Text3: 25.401, 25.410, 25.412, 25.413, 25.414, 25.415, 25.4xy / Text5: Martin Warner (mw15@alcatel-lucent.com)
- 413: SA#42 extension 12/08=>03/09. SA#40/41 3-months extensions granted / Text3: 33.106, 33.107, 33.108 / Text5: berthold.wilhelm@bnetza.de, ron_ryan@verizon.net
- 414: CT#42 Rel-8 extension to 03/09. SA#41 Target completion 09/08=>12/08 / Text5: Rolf Blom
- 415: SA#42 completed 33.223 as Rel-8. 33.224 moved to Rel-9 / Text3: 33.223 / Text5: Rolf Blom
- 416: SA#42 33.224 moved to Rel-9 (33.223 completed as Rel-8) / Text3: 33.224 / Text5: Rolf Blom
- 417: CT#42 Rel-8 extension to 03/09 / Text3: 24.109 / Text5: Rolf Blom
- 418: CT#42 Rel-8 extension to 03/09 / Text3: 29.109 / Text5: Rolf Blom
- 419: SA#42 completed. SA#39 WID approved. / Text3: 26.131, 26.132 / Text5: stephane.ragot@orange-ftgroup.com, wanqing.shi@sonyericsson.com
- 420: SA#42 completed. SA#38 WID approved. / Text3: 26.234, 26.346, 26.946 / Text5: thorsten.lohmar@ericsson.com

| ID | WBS | Task | Duration | Start | Finish | Complete | Remaining | Baseline start | Baseline finish | Baseline duration | Total slack | Constraint | Resources | Work | Actual work | Text1 | Text2 | Text4 | Text5 | Text6 | Text7 | Text8 | Text12 |
| --- | --- | --- | --- | --- | --- | --- | --- | --- | --- | --- | --- | --- | --- | --- | --- | --- | --- | --- | --- | --- | --- | --- | --- |
| 421 | 1.111 | **Encoding formats, transport formats and media description signalling for interworking, QoE, and other enhancements to MTSI-MHI** | 331d? | 2007-12-06 A | 2009-03-12 | 56% | 146.41d? | 2007-12-06 | 2009-03-12 | 331d? | 261d |  | S4,C3,C1,C4 | 9640h | 5375.9h | MTSI_eMHI | PCG-21 | Ericsson, Qualcomm | olle.franceschi@ericsson.com, nleung@qualcomm.com | Rel-8 | SP-40 | Paolo |  |
| 422 | 1.111.1 | MTSI Video - Dynamic Rate Adaptation/Signalling of Image Size | 331d? | 2007-12-06 A | 2009-03-12 | 50% | 165.5d? | 2007-12-06 | 2009-03-12 | 331d? | 261d | finish no earlier than 2009-03-12 | S4 | 2648h | 1324h | MTSI_eMHI-DRASIS |  | Qualcomm, Samsung | nleung@qualcomm.com & kyunghun.jung@samsung.com | Rel-8 |  | Paolo |  |
| 423 | 1.111.2 | CT3 part of Enhancement of interworking between MTSI and CS networks | 201d? | 2008-05-30 A | 2009-03-06 | 90% | 20.1d? | 2008-05-30 | 2009-03-06 | 201d? | 265d | finish no earlier than 2009-03-06 | C3 | 1608h | 1447.2h | MTSI_eMHI | PCG-21 | Huawei | Tingfang Tang (tagna_online@huawei.com) | Rel-8 | CP-40 | Gwiho |  |
| 424 | 1.111.3 | CT1 part of Enhancement of interworking between MTSI and CS networks | 141d? | 2008-05-30 A | 2008-12-12 A | 100% |  | 2008-05-30 | 2008-12-12 | 141d? |  | start no earlier than 2008-05-30 | C1 | 1128h | 1128h | MTSI_eMHI | PCG-21 | Huawei | Tingfang Tang (tagna_online@huawei.com) | Rel-8 | CP-40 | Frederic |  |
| 425 | 1.111.4 | CT4 part of Enhancement of interworking between MTSI and CS networks | 201d? | 2008-05-30 | 2009-03-06 |  |  | 2008-05-30 | 2009-03-06 | 201d? | 265d | finish no earlier than 2009-03-06 | C4 | 1608h |  | MTSI_eMHI | PCG-21 | Huawei | Tingfang Tang (tagna_online@huawei.com) | Rel-8 | CP-40 | Kimmo |  |
| 426 | 1.112 | **OAM&P 8** | 461d? | 2007-06-07 A | 2009-03-12 | 95% | 24.83d? | 2007-06-07 | 2009-03-12 | 461d? | 261d |  | S5,C1 | 38699.2h | 30601.1h | OAM8 |  |  |  | Rel-8 |  | Dionisio |  |
| 427 | 1.112.1 | **Network Infrastructure Management** | 461d? | 2007-06-07 A | 2009-03-12 | 90% | 44.47d? | 2007-06-07 | 2009-03-12 | 461d? | 261d |  | S5 | 17512h | 13765.9h | OAM8-NIM |  |  |  | Rel-8 |  | Dionisio |  |
| 428 | 1.112.1.1 | Telecom Management Methodology | 461d? | 2007-06-07 A | 2009-03-12 | 90% | 46.1d? | 2007-06-07 | 2009-03-12 | 461d? | 261d | finish no earlier than 2009-03-12 | S5 | 3688h | 3319.2h | OAM8 |  | Ericsson | TOVINGER, Thomas | Rel-8 |  | Dionisio |  |
| 429 | 1.112.1.2 | Advanced Alarming on Itf-N | 266d? | 2007-06-07 A | 2008-06-12 A | 100% |  | 2007-06-07 | 2008-06-12 | 266d? |  | finish no earlier than 2008-12-11 | S5 | 2128h | 2128h | OAM8 |  | Nokia Siemens Networks | SUERBAUM, Clemens | Rel-8 |  | Dionisio |  |
| 430 | 1.112.1.3 | CN CS Bearer Transport Network (BTN) relative NRM | 266d? | 2007-06-07 A | 2008-06-12 A | 100% |  | 2007-06-07 | 2008-06-12 | 266d? |  | finish no earlier than 2008-12-11 | S5 | 2128h | 2128h | OAM8 |  | China Mobile | LI, Jian | Rel-8 |  | Dionisio |  |
| 431 | 1.112.1.4 | Deleted - End point modelling for reference point | 324d? | 2007-09-17 A | 2008-12-11 A | 100% |  | 2007-09-17 | 2008-12-11 | 324d? |  | finish no earlier than 2008-12-11 | S5 | 2592h | 2592h | OAM8 |  | Motorola | YAO, Yizhi | Rel-8 | SP-37 | Dionisio | SP-41 |
| 432 | 1.112.1.5 | Alignment with eTOM and M.3060 architectural concepts | 210d? | 2008-02-22 A | 2008-12-11 A | 100% |  | 2008-02-22 | 2008-12-11 | 210d? |  | start no earlier than 2008-02-22 | S5 | 1680h | 1680h | OAM8 | PCG-21 | TeliaSonera | Berggren, Tommy | Rel-8 | SP-39 | Dionisio |  |
| 433 | 1.112.1.6 | IRP SOAP Solution Sets | 201d? | 2008-06-05 A | 2009-03-12 | 40% | 120.6d? | 2008-06-05 | 2009-03-12 | 201d? | 261d | finish no earlier than 2009-03-12 | S5 | 1608h | 643.2h | OAM8 | PCG-21 | Ericsson | edwin.tse@ericsson.com | Rel-8 | SP-40 | Dionisio |  |
| 434 | 1.112.2 | **Performance Management** | 396d? | 2007-06-07 A | 2008-12-11 | 98% | 6.6d? | 2007-06-07 | 2008-12-11 | 396d? | 326d |  | S5 | 12672h | 12460.8h | OAM8-PM |  |  |  | Rel-8 |  | Dionisio |  |
| 435 | 1.112.2.1 | IP bearer network Performance measurement definitions | 396d? | 2007-06-07 A | 2008-12-11 A | 100% |  | 2007-06-07 | 2008-12-11 | 396d? |  | finish no earlier than 2008-12-11 | S5 | 3168h | 3168h | OAM8 |  | China Mobile | lilianyuan@chinamobile.com | Rel-8 |  | Dionisio |  |
| 436 | 1.112.2.2 | HSUPA performance measurements | 396d? | 2007-06-07 A | 2008-12-11 A | 100% |  | 2007-06-07 | 2008-12-11 | 396d? |  | finish no earlier than 2008-12-11 | S5 | 3168h | 3168h | OAM8 |  | China Mobile | LI, Jian | Rel-8 |  | Dionisio |  |
| 437 | 1.112.2.3 | Key Performance Indicators (KPIs) for UMTS and GSM | 396d? | 2007-06-07 A | 2008-12-11 | 95% | 19.8d? | 2007-06-07 | 2008-12-11 | 396d? | 326d | finish no earlier than 2008-12-11 | S5 | 3168h | 3009.6h | OAM8 |  | China Mobile | Liang Shuangchun | Rel-8 |  | Dionisio |  |
| 438 | 1.112.3 | **Trace Management** | 196d? | 2008-03-07 A | 2008-12-05 | 99% | 0d? | 2008-03-07 | 2008-12-05 | 196d? | 0d |  | S5,C1,C3,C4 | 5777.6h | 4374.4h | OAM8-Trace |  |  |  | Rel-8 |  | Dionisio |  |
| 439 | 1.112.3.1 | Service Level Tracing in IMS | 196d? | 2008-03-07 A | 2008-12-05 A | 100% |  | 2008-03-07 | 2008-12-05 | 196d? |  | finish no earlier than 2008-12-05 | C1 | 1568h | 1568h | OAM8-Trace |  | Vodafone | peter.dawes@vodafone.com | Rel-8 |  | Frederic |  |
| 440 | 1.112.3.2 | Service Level Tracing in IMS | 175.4d? | 2008-03-07 A | 2008-12-05 A | 100% |  | 2008-03-07 | 2008-12-05 | 175.4d? |  | finish no earlier than 2008-12-05 | C3 | 1403.2h | 1403.2h | OAM8-Trace | PCG-21 | Vodafone | peter.dawes@vodafone.com | Rel-8 | CP-40 | Frederic |  |
| 441 | 1.112.3.3 | Service Level Tracing in IMS | 175.4d? | 2008-03-07 A | 2008-12-05 A | 100% |  | 2008-03-07 | 2008-12-05 | 175.4d? |  | finish no earlier than 2008-12-05 | C4 | 1403.2h | 1403.2h | OAM8-Trace | PCG-21 | Vodafone | peter.dawes@vodafone.com | Rel-8 | CP-40 | Frederic |  |
| 442 | 1.113 | **Charging Management small Enhancements** | 716d? | 2006-03-16 A | 2008-12-11 A | 100% |  | 2006-03-16 | 2008-12-11 | 716d? |  |  | S5 | 12544h | 12544h | CH8 |  |  |  | Rel-8 |  | Dionisio |  |
| 443 | 1.113.1 | Online charging correlation | 457d? | 2006-03-16 A | 2007-12-14 A | 100% |  | 2006-03-16 | 2007-12-14 | 457d? |  | start no earlier than 2006-03-16 | S5 | 3656h | 3656h | CH8 |  | Orange | Chahine, Rony | Rel-8 |  | Dionisio |  |
| 444 | 1.113.2 | SMS online charging | 137d? | 2007-06-07 A | 2007-12-14 A | 100% |  | 2007-06-07 | 2007-12-14 | 137d? |  | finish no earlier than 2007-12-14 | S5 | 1096h | 1096h | CH8 |  | Vodafone | WONG, Gavin | Rel-8 |  | Dionisio |  |
| 445 | 1.113.3 | Deleted - WLAN Offline Charging | 244d? | 2008-01-07 A | 2008-12-11 A | 100% |  | 2008-01-07 | 2008-12-11 | 244d? |  | finish no earlier than 2008-12-11 | S5 | 1952h | 1952h | CH8 | PCG-21 | Alcatel-Lucent | GARDELLA, Maryse | Rel-8 | SP-38 | Dionisio | SP-42 |
| 446 | 1.113.4 | Introduce Online Charging from SMS-SC into the SMS Charging Specifications | 61d? | 2008-09-18 A | 2008-12-11 A | 100% |  | 2008-09-18 | 2008-12-11 | 61d? |  | finish no earlier than 2008-12-11 | S5 | 488h | 488h | CH8 | PCG-21 | Acision | Gebler, Erik - Acision [erik.gebler (at) acision.com] | Rel-8 | SP-41 |  |  |

Notes:
- 421: TSG#42 Rel-8 extension to 03/09
- 422: SA#42 Rel-8 extension to 03/09. SA#40 WID updated SP-070755=>SP-080246. [Feature=>BB under new Feature UID_400028 (MTSI)] / Text3: 26.114
- 423: CT#42 Rel-8 extension to 03/09. WID updated CP-080422=>CP-080774 / Text3: 29.163
- 424: CT#42 completed (No CT1-impact). WID updated CP-080422=>CP-080774
- 425: CT#42 Rel-8 extension to 03/09. WID updated CP-080422=>CP-080774 / Text3: 29.332
- 428: SA#42 Rel-8 extension to 03/09 / Text3: 32.155, 32.153
- 429: SA#40 completed / Text3: 32.121, 32.122, 32.123
- 430: SA#40 completed / Text3: 32.632/3/5
- 431: SA#41 Work stopped. Contributions related to E-UTRAN/EPC to be submitted to UID_380036 E-UTRAN NRM IRP/ UID_380037 EPC NRM IRP / Text3: 32.152, 32.62/3/4x, 32.73x
- 432: SA#42 completed / Text3: 32.101/2, 32-series
- 433: SA#42 Rel-8 extension to 03/09 / Text3: 32.111-7, 32.617, 32.417, 32.367, 32.627, 32.327, 32.337, 32.347, 32.357, 32.387, 32.397, 32.447, 32.637, 32.647, 32.657, 32.677, 32.697, 32.717, 32.727, 32.737, 32.747
- 435: SA#42 completed. SA#36 WID updated SP-050319=>SP-070301 / Text3: 32.321/2/3/5
- 436: SA#42 completed / Text3: 32.405
- 437: SA#42 Rel-8 extension to 03/09 / Text3: 32.410
- 439: CT#42 completed. CT#40 WID updated CP-060521=>CP-080315. / Text3: 24.323, 24.229
- 440: CT#42 completed (No CT3-impact). CT#40 WID updated CP-060521=>CP-080315
- 441: CT#42 completed. CT#40 WID updated CP-060521=>CP-080315. / Text3: 29.228, 29.229
- 443: SA#38 completed / Text3: 32.296
- 444: SA#38 completed / Text3: 32.274, 32.240/299
- 445: SA#42 stopped / Text3: 32.252, 32.298, 32.299
- 446: SA#42 completed. Linked to SA2 UID 32081 (Support of SMS over IP networks) and CT4 UID 340016 (Routeing of MT-SMS via the HPLMN). / Text3: 32.274, 32.299

| ID | WBS | Task | Type | Duration | Start | Finish | Complete | Remaining | Baseline start | Baseline finish | Baseline duration | Total slack | Constraint | Resources | Work | Actual work | Text1 | Text2 | Text4 | Text5 | Text6 | Text8 | Text7 | Text12 |
| --- | --- | --- | --- | --- | --- | --- | --- | --- | --- | --- | --- | --- | --- | --- | --- | --- | --- | --- | --- | --- | --- | --- | --- | --- |
| 447 | 1.114 | **Conferencing enhancements for Mp interface** |  | 266d? | 2007-11-30 A | 2008-12-05 A | 100% |  | 2007-11-30 | 2008-12-05 | 266d? |  |  | C4 | 6384h | 6384h | eMp | PCG-21 | Huawei | Chencheng@huawei.com | Rel-8 | Kimmo |  |  |
| 448 | 1.114.1 | Stage 2 for eMp |  | 266d? | 2007-11-30 A | 2008-12-05 A | 100% |  | 2007-11-30 | 2008-12-05 | 266d? |  | finish no earlier than 2008-12-11 | C4 | 2128h | 2128h | eMp | PCG-21 | Huawei | Chencheng@huawei.com | Rel-8 | Kimmo | CP-38 |  |
| 449 | 1.114.2 | Stage 3 for eMp |  | 266d? | 2007-11-30 A | 2008-12-05 A | 100% |  | 2007-11-30 | 2008-12-05 | 266d? |  | finish no earlier than 2008-12-05 | C4 | 2128h | 2128h | eMp | PCG-21 | Huawei | Chencheng@huawei.com | Rel-8 | Kimmo | CP-38 |  |
| 450 | 1.115 | **Contact Manager for 3GPP UICC applications** |  | 642d? | 2006-06-22 A | 2008-12-05 A | 100% |  | 2006-06-22 | 2008-12-05 | 642d? |  |  | C6 | 13352h | 13352h | eUPHBOOK |  | Gemalto | Jacques.seif@gemalto.com | Rel-8 | Xavier |  |  |
| 451 | 1.115.1 | Requirements for Contact Manager |  | 392d? | 2006-06-22 A | 2007-12-21 A | 100% |  | 2006-06-22 | 2007-12-21 | 392d? |  | finish no earlier than 2007-12-21 | C6 | 3136h | 3136h | eUPHBOOK-St1 |  | Gemalto | Jacques.seif@gemalto.com | Rel-8 | Xavier |  |  |
| 452 | 1.115.2 | External interface for eUPHBOOK |  | 220d? | 2007-05-07 A | 2008-03-07 A | 100% |  | 2007-05-07 | 2008-03-07 | 220d? |  | finish no earlier than 2008-03-07 | C6 | 1760h | 1760h | eUPHBOOK-Ext_Spec |  | Gemalto | Jacques.seif@gemalto.com | Rel-8 | Xavier |  |  |
| 453 | 1.115.3 | Internal interface for eUPHBOOK |  | 415d? | 2007-05-07 A | 2008-12-05 A | 100% |  | 2007-05-07 | 2008-12-05 | 415d? |  | finish no earlier than 2008-12-05 | C6 | 3320h | 3320h | eUPHBOOK-Int_Spec |  | Gemalto | Jacques.seif@gemalto.com | Rel-8 | Xavier | CP-37 |  |
| 454 | 1.115.4 | Deleted - Implementation of eUPHBOOK | milestone | 0d? | 2007-06-21 A | 2007-06-21 A | 100% |  | 2007-06-21 | 2007-06-21 | 0d? |  | start no earlier than 2007-06-21 | C6 |  |  | eUPHBOOK-St23 |  | Giesecke & Devrient | Claus Dietze | Rel-8 | Xavier |  | SP-33 |
| 455 | 1.116 | **Contact Manager Conformance Test specifications** |  | 205d? | 2008-05-30 | 2009-03-12 |  |  | 2008-05-30 | 2009-03-12 | 205d? | 261d |  | C6 | 4920h |  | eUPHBOOK-Test | PCG-21 | Comprion, Gemalto | Udo Willenbrink, Jacques Seif | Rel-8 | Xavier | CP-40 |  |
| 456 | 1.116.1 | Contact Manager for 3GPP UICC applications test specifications |  | 205d? | 2008-05-30 | 2009-03-12 |  |  | 2008-05-30 | 2009-03-12 | 205d? | 261d | finish no earlier than 2009-03-12 | C6 | 1640h |  | eUPHBOOK-Test |  | Comprion, Gemalto | Udo Willenbrink | Rel-8 |  |  |  |
| 457 | 1.116.2 | Contact Manager API for Java™ Card test specification |  | 205d? | 2008-05-30 | 2009-03-12 |  |  | 2008-05-30 | 2009-03-12 | 205d? | 261d | finish no earlier than 2009-03-12 | C6 | 1640h |  | eUPHBOOK-Test |  | Gemalto | jacques.seif@gemalto.com | Rel-8 |  |  |  |
| 458 | 1.117 | **Rel-8 LTE – 3G Long Term Evolution - Evolved Packet System RAN part** |  | 644d? | 2006-09-25 A | 2009-03-12 | 92% | 50.34d? | 2006-09-25 | 2009-03-12 | 644d? | 261d |  | RP,S5 | 44896h | 39083.1h | LTE |  | NTT DoCoMo | Takehiro Nakamura | Rel-8 | Juergen |  |  |
| 459 | 1.117.1 | LTE – Physical Layer |  | 380d? | 2006-09-25 A | 2008-03-07 A | 100% |  | 2006-09-25 | 2008-03-07 | 380d? |  | finish no earlier than 2007-09-14 | R1 | 3040h | 3040h | LTE-Phys |  | NTT DoCoMo | Sadayuki Abeta | Rel-8 | Patrick |  |  |
| 460 | 1.117.2 | LTE – Radio Interface Layer 2 and 3 Protocol Aspect |  | 575d? | 2006-09-25 A | 2008-12-05 A | 100% |  | 2006-09-25 | 2008-12-05 | 575d? |  | finish no earlier than 2008-12-11 | R2 | 4600h | 4600h | LTE-L23 |  | Nokia Siemens Networks | Benoist Sébire | Rel-8 | Joern |  |  |
| 461 | 1.117.3 | LTE – eUTRAN Interfaces |  | 575d? | 2006-09-25 A | 2008-12-05 A | 100% |  | 2006-09-25 | 2008-12-05 | 575d? |  | finish no earlier than 2008-12-11 | R3 | 4600h | 4600h | LTE-interfaces |  | Ericsson | Martin Israelsson | Rel-8 | Juergen |  |  |
| 462 | 1.117.4 | LTE – Evolved UTRA and UTRAN RF Radio Transmission/Reception, System Performance Requirements and Conformance Testing |  | 575d? | 2006-09-25 A | 2008-12-05 A | 100% |  | 2006-09-25 | 2008-12-05 | 575d? |  | finish no earlier than 2008-12-11 | R4 | 4600h | 4600h | LTE-RF |  | Nokia Siemens Networks | Tuomo Saynajakangas | Rel-8 | Stefania |  |  |
| 463 | 1.117.5 | LTE – FDD repeaters |  | 386d? | 2007-09-14 A | 2009-03-06 | 75% | 96.5d? | 2007-09-14 | 2009-03-06 | 386d? | 265d | finish no earlier than 2009-03-06 | R4 | 3088h | 2316h | LTE-Repeaters |  | Powerwave Technologies, Andrew Wireless | ralf.michanikl@andrew.com, Alf.Ahlstrom@pwav.com | Rel-8 | Stefania | RP-37 |  |
| 464 | 1.117.6 | **E-UTRAN Data Definitions** |  | 389d? | 2007-09-17 A | 2009-03-12 | 80% | 76.37d? | 2007-09-17 | 2009-03-12 | 389d? | 261d |  | S5 | 13096h | 10525.1h | E-UTRAN-OAM | PCG-21 |  |  | Rel-8 | Dionisio | SP-39 |  |
| 465 | 1.117.6.1 | Subscriber and Equipment Trace for E-UTRAN and EPC |  | 389d? | 2007-09-17 A | 2009-03-12 | 90% | 38.9d? | 2007-09-17 | 2009-03-12 | 389d? | 261d | finish no earlier than 2009-03-12 | S5 | 3112h | 2800.8h | E-UTRAN-OAM |  | Ericsson | PETERSEN, Robert | Rel-8 | Dionisio | SP-37 |  |
| 466 | 1.117.6.2 | E-UTRAN Network Resource Model (NRM) Integration Reference Point (IRP) |  | 309d? | 2008-01-07 A | 2009-03-12 | 60% | 123.6d? | 2008-01-07 | 2009-03-12 | 309d? | 261d | finish no earlier than 2009-03-12 | S5 | 2472h | 1483.2h | E-UTRAN-OAM | PCG-21 | Ericsson | ELMDAHL, Per | Rel-8 | Dionisio | SP-38 |  |
| 467 | 1.117.6.3 | Performance measurements for E-UTRAN |  | 275d? | 2008-02-22 A | 2009-03-12 | 80% | 55d? | 2008-02-22 | 2009-03-12 | 275d? | 261d | finish no earlier than 2009-03-12 | S5 | 2200h | 1760h | E-UTRAN-OAM | PCG-21 | Motorola, Huawei | YAO, Yizhi | Rel-8 | Dionisio | SP-39 |  |
| 468 | 1.117.6.4 | Key Performance Indicators (KPIs) for E-UTRAN |  | 275d? | 2008-02-22 A | 2009-03-12 | 90% | 27.5d? | 2008-02-22 | 2009-03-12 | 275d? | 261d | finish no earlier than 2009-03-12 | S5 | 2200h | 1980h | E-UTRAN-OAM | PCG-21 | Ericsson | HÜBINETTE, Ulf | Rel-8 | Dionisio | SP-39 |  |
| 469 | 1.117.7 | **Self-Organizing Networks (SON)** |  | 210d? | 2008-02-22 A | 2008-12-11 A | 100% |  | 2008-02-22 | 2008-12-11 | 210d? |  |  | S5 | 6720h | 6720h | LTE_SON-OAM | PCG-21 | Vodafone | GOMPAKIS, Panagiotis | Rel-8 | Dionisio | SP-39 |  |
| 470 | 1.117.7.1 | SON Concepts and requirements |  | 210d? | 2008-02-22 A | 2008-12-11 A | 100% |  | 2008-02-22 | 2008-12-11 | 210d? |  |  | S5 | 1680h | 1680h | LTE_SON-OAM | PCG-21 | Vodafone | GOMPAKIS, Panagiotis | Rel-8 | Dionisio | SP-39 |  |
| 471 | 1.117.7.2 | Self-Establishment of eNBs |  | 210d? | 2008-02-22 A | 2008-12-11 A | 100% |  | 2008-02-22 | 2008-12-11 | 210d? |  | start no earlier than 2008-02-22 | S5 | 1680h | 1680h | LTE_SON-OAM | PCG-21 | Nokia Siemens Networks | SUERBAUM, Clemens | Rel-8 | Dionisio | SP-39 |  |
| 472 | 1.117.7.3 | SON Automatic Neighbour Relations (ANR) List Management |  | 210d? | 2008-02-22 A | 2008-12-11 A | 100% |  | 2008-02-22 | 2008-12-11 | 210d? |  | finish no earlier than 2008-12-11 | S5 | 1680h | 1680h | LTE_SON-OAM | PCG-21 | Ericsson | TSE, Edwin | Rel-8 | Dionisio | SP-39 |  |

Notes:
- 447: CT#42 completed. WID updated CP-070868=>CP-080725
- 448: CT#42 completed. WID updated CP-070868=>CP-080725 / Text3: 23.333
- 449: CT#42 completed. WID updated CP-070868=>CP-080725 / Text3: 29.333
- 450: aka Enhanced USIM phonebook. CT#40: WID updated CP-070622=>CP-080382
- 451: CT#38 completed / Text3: 21.111
- 452: CT#39 completed / Text3: 31.220
- 453: CT#42 completed / Text3: 31.221
- 454: SA#33 stopped / Text3: 31.102
- 455: CT#42 work not started
- 456: CT#42 work not started / Text3: 31.320 (external interface for communication with the ME)
- 457: CT#42 work not started / Text3: 31.321 (internal interface (API))
- 458: RP#41 WID Updated RP-060635=>RP-080747. Last SR in RP-080741 (extension sheet shall be provided for RP#42) / Text3: 36.300, 36.938
- 459: Text3: 36.201, 36.211, 36.212, 36.213, 36.214, 25.215, 25.225
- 460: RP#42 completed. ASN.1 freezing target 03/09 / Text3: 36.302, 36.304, 36.306, 36.314, 36.321, 36.322, 36.323, 36.331, 25.302, 25.304, 25.331
- 461: RP#42 completed / Text3: 36.401, 36.410, 36.411, 36.412, 36.413, 36.414, 36.420, 36.421, 36.422, 36.423, 36.424, 36.902, 25.413
- 462: RP#42 completed (closed at 95%) / Text3: 36.101, 36.104, 36.113, 36.124, 36.133, 36.141, 36.942, 25.123, 25.133
- 463: SR in RP-080797. RP#42 Rel-8 extension to 03/09 / Text3: 36.106, 36.143, 25.113
- 465: SA#42 Rel-8 extension to 03/09 / Text3: 32.42x, 32.44x
- 466: SA#42 Rel-8 extension to 03/09 / Text3: 32.761/2/3/5
- 467: SA#42 Rel-8 extension to 03/09 / Text3: 32.425
- 468: SA#42 Rel-8 extension to 03/09 / Text3: 32.450, 32.451
- 469: SA#42 completed (WT UID_390007 moved to Rel-9). SA#40 updated WID SP-080064=>SP-080275.
- 470: SA#42 completed. SA#40 updated WID SP-080064=>SP-080275. SA#41 UID_390004 split to monitor 32.500 progress. / Text3: 32.500
- 471: SA#42 completed / Text3: 32.501, 32.502, 32.531/2/3/7
- 472: SA#42 completed / Text3: 32.511, 32.761/2/3/5

| ID | WBS | Task | Duration | Start | Finish | Complete | Remaining | Baseline start | Baseline finish | Baseline duration | Total slack | Constraint | Resources | Work | Actual work | Text1 | Text6 | Text8 | Text4 | Text5 | Text2 | Text7 | Text12 |
| --- | --- | --- | --- | --- | --- | --- | --- | --- | --- | --- | --- | --- | --- | --- | --- | --- | --- | --- | --- | --- | --- | --- | --- |
| 473 | 1.118 | **Rel-8 LTE – Terminal Conformance Test Specification** | 596d? | 2007-06-01 A | 2009-09-11 | 34% | 395.01d? | 2007-06-01 | 2009-09-11 | 596d? | 130d |  | R5 | 15560h | 5247.43h | LTE-UEConTest | Rel-8 | Ingbert |  |  |  |  |  |
| 474 | 1.118.1 | 3G LTE – Terminal Protocol Conformance Test Specifications | 466d? | 2007-06-01 A | 2009-03-13 | 35% | 302.9d? | 2007-06-01 | 2009-03-13 | 466d? | 260d | finish no earlier than 2009-03-13 | R5 | 3728h | 1304.8h | LTE-UEConTest_SIG | Rel-8 | Ingbert | NEC, Motorola | david.lecompte@nectech.fr, Jacob.John@motorola.com |  |  |  |
| 475 | 1.118.2 | LTE – Terminal Radio Transmission and Reception Conformance Test Specifications (FDD) | 466d? | 2007-06-01 A | 2009-03-13 | 50% | 233d? | 2007-06-01 | 2009-03-13 | 466d? | 260d | finish no earlier than 2009-03-13 | R5 | 3728h | 1864h | LTE-UEConTest_RF_FDD | Rel-8 | Ingbert | Agilent | andrea_leonardi@agilent.com |  |  |  |
| 476 | 1.118.3 | LTE – Terminal Radio Transmission and Reception Conformance Test Specifications (TDD) | 596d? | 2007-06-01 A | 2009-09-11 | 20% | 476.8d? | 2007-06-01 | 2009-09-11 | 596d? | 130d | finish no earlier than 2009-09-11 | R5 | 4768h | 953.6h | LTE-UEConTest_RF_TDD | Rel-8 | Ingbert | Agilent | andrea_leonardi@agilent.com | PCG-21 | RP-41 |  |
| 477 | 1.119 | **Rel-8 Improvements of the Radio Interface** | 585d? | 2007-03-05 A | 2009-05-29 | 87% | 77.88d? | 2007-03-05 | 2009-05-29 | 585d? | 205d |  | RP | 20664h | 14496h | RInImp8 | Rel-8 | Juergen |  |  |  |  |  |
| 478 | 1.119.1 | UMTS 1500 MHz | 140d? | 2007-03-05 A | 2007-09-14 A | 100% |  | 2007-03-05 | 2007-09-14 | 140d? |  | finish no earlier than 2007-09-14 | R4 | 1120h | 1120h | RInImp8-UMTS1500 | Rel-8 | Stefania | NTT DoCoMo | Takehiro Nakamura |  |  |  |
| 479 | 1.119.2 | UMTS 700 MHz FDD | 325d? | 2007-03-05 A | 2008-05-30 A | 100% |  | 2007-03-05 | 2008-05-30 | 325d? |  | finish no earlier than 2008-06-12 | R4 | 2600h | 2600h | RInImp8-UMTS700 | Rel-8 | Stefania | Nokia | Tuomo Saynajakangas |  |  |  |
| 480 | 1.119.3 | UMTS 2300 MHz TDD LCR | 195d? | 2007-12-17 A | 2008-09-12 A | 100% |  | 2007-12-17 | 2008-09-12 | 195d? |  | finish no earlier than 2008-09-12 | R4 | 1560h | 1560h | RInImp8-UMTS2300TDD | Rel-8 | Stefania | CATT | songyuexia@datangmobile.cn | PCG-21 | RP-38 |  |
| 481 | 1.119.4 | UMTS/LTE 3500 MHz | 380d? | 2007-12-17 A | 2009-05-29 | 30% | 266d? | 2007-12-17 | 2009-05-29 | 380d? | 205d | finish no earlier than 2009-05-29 | R4 | 3040h | 912h | RInImp8-UMTSLTE3500 | Rel-8 | Stefania | Ericsson | johan.skold@ericsson.com | PCG-21 | RP-38 |  |
| 482 | 1.119.5 | Further Improved Minimum Performance Requirements for HSDPA UE (FDD) - Two-Branch Interference Cancellation | 265d? | 2007-03-05 A | 2008-03-07 A | 100% |  | 2007-03-05 | 2008-03-07 | 265d? |  | finish no earlier than 2008-03-12 | R4 | 2120h | 2120h | RInImp8-2BIC | Rel-8 | Stefania | AT&T | marc.grant@cingular.com |  |  |  |
| 483 | 1.119.6 | CS Voice Service over HSPA | 167d? | 2007-07-19 A | 2008-03-07 A | 100% |  | 2007-07-19 | 2008-03-07 | 167d? |  |  | R2 | 1336h | 1336h | RInImp8-CsHspa | Rel-8 | Joern | Nokia Siemens Networks | woonhee.hwang@nsn.com |  | RP-37 |  |
| 484 | 1.119.7 | Performance requirements for 15 code reception with 16QAM/QPSK | 126d? | 2007-06-11 A | 2008-03-07 A | 100% |  | 2007-06-11 | 2008-03-07 | 126d? |  | finish no earlier than 2008-06-12 | R4 | 1008h | 1008h | RInImp8-Hsdpa15codes | Rel-8 | Stefania | Vodafone | tim.frost@vodafone.com |  | RP-37 |  |
| 485 | 1.119.8 | Deleted - UMTS 2300 MHz FDD/TDD | 400d? | 2007-03-05 A | 2008-09-12 A | 100% |  | 2007-03-05 | 2008-09-12 | 400d? |  | finish no earlier than 2008-12-11 | R4 | 3200h | 3200h | RInImp8-UMTS2300 | Rel-8 | Stefania | AT&T | marc.grant@cingular.com |  |  | RP-41 |
| 486 | 1.120 | **Rel-8 Improvements of the Radio Interface - UE Conformance Testing** | 396d? | 2007-06-01 A | 2008-12-05 A | 100% |  | 2007-06-01 | 2008-12-05 | 396d? |  |  | R5 | 6256h | 6256h | RInImp-UEConTest | Rel-8 | Ingbert |  |  |  |  |  |
| 487 | 1.120.1 | Conformance Test Aspects – CS Voice Service over HSPA | 336d? | 2007-06-01 A | 2008-09-12 A | 100% |  | 2007-06-01 | 2008-09-12 | 336d? |  | finish no earlier than 2008-09-12 | R5 | 2688h | 2688h | RInImp8-CsHspa_UEConTest | Rel-8 | Ingbert | Huawei | baoyi@huawei.com |  |  |  |
| 488 | 1.120.2 | Conformance Test Aspects – Performance requirements for 15 code reception with 16QAM/QPSK (FDD) | 195d? | 2008-03-07 A | 2008-12-05 A | 100% |  | 2008-03-07 | 2008-12-05 | 195d? |  | finish no earlier than 2008-12-05 | R5 | 1560h | 1560h | RInImp8-UEConTest_ Hsdpa15codes | Rel-8 | Ingbert | Ericsson | Mikael.Ziren@Ericsson.com | PCG-21 | RP-40 |  |
| 489 | 1.121 | **Rel-8 RAN improvements** | 595d? | 2007-06-04 A | 2009-09-11 | 86% | 83.54d? | 2007-06-04 | 2009-09-11 | 595d? | 130d |  | RP | 36584h | 31447.7h | RANimp | Rel-8 | Juergen |  |  |  |  |  |
| 490 | 1.121.1 | Combination of 64QAM and MIMO for HSDPA (FDD) | 205d? | 2007-06-04 A | 2008-09-12 A | 100% |  | 2007-06-04 | 2008-09-12 | 205d? |  | finish no earlier than 2008-09-12 | R1 | 1640h | 1640h | RANimp-64QamMimoHsdpa | Rel-8 | Patrick | Ericsson | Johan.Bergman@ericsson.com |  |  |  |
| 491 | 1.121.2 | Improved L2 for uplink | 186d? | 2007-09-14 A | 2008-05-30 A | 100% |  | 2007-09-14 | 2008-05-30 | 186d? |  | finish no earlier than 2008-05-30 | R2 | 1488h | 1488h | RANimp-UplinkL2dataRates | Rel-8 | Joern | Ericsson | Janne.Peisa@ericsson.com |  | RP-37 |  |
| 492 | 1.121.3 | Enhanced Uplink for CELL_FACH State in FDD | 321d? | 2007-09-14 A | 2008-12-05 A | 100% |  | 2007-09-14 | 2008-12-05 | 321d? |  | finish no earlier than 2008-12-12 | R2 | 2568h | 2568h | RANimp-UplinkEnhState | Rel-8 | Joern | Nokia Siemens Networks | markus.wimmer@nsn.com |  | RP-37 |  |
| 493 | 1.121.4 | Enhanced UE DRX for FDD | 261d? | 2007-09-14 A | 2008-09-12 A | 100% |  | 2007-09-14 | 2008-09-12 | 261d? |  | finish no earlier than 2008-09-12 | R2 | 2088h | 2088h | RANimp-DRX | Rel-8 | Joern | Nokia | luis.barreto@nokia.com |  | RP-37 |  |
| 494 | 1.121.5 | Enhancements for SRNS Relocation Procedure | 261d? | 2007-09-14 A | 2008-09-12 A | 100% |  | 2007-09-14 | 2008-09-12 | 261d? |  | finish no earlier than 2008-09-12 | R3 | 2088h | 2088h | RANimp-SrnsReloc | Rel-8 | Juergen | Nokia Siemens Networks | masatoshi.nakamata@nsn.com |  | RP-37 |  |
| 495 | 1.121.6 | Enhancements for FDD HSPA Evolution | 321d? | 2007-09-14 A | 2008-12-05 A | 100% |  | 2007-09-14 | 2008-12-05 | 321d? |  | finish no earlier than 2008-12-05 | R3,R2 | 2568h | 2568h | RANimp-HSPAEvo | Rel-8 | Juergen | Nokia Siemens Networks | masatoshi.nakamata@nsn.com |  | RP-37 |  |
| 496 | 1.121.7 | 64QAM for 1.28 Mcps TDD HSDPA | 264d? | 2007-12-04 A | 2008-12-05 A | 100% |  | 2007-12-04 | 2008-12-05 | 264d? |  | finish no earlier than 2008-12-05 | R1 | 2112h | 2112h | RANimp-64Qam1.28TDD | Rel-8 | Patrick | ZTE | zfmail@zte.com.cn | PCG-21 | RP-38 |  |
| 497 | 1.121.8 | Enhanced CELL_FACH state in 1.28 Mcps TDD | 264d? | 2007-12-04 A | 2008-12-05 A | 100% |  | 2007-12-04 | 2008-12-05 | 264d? |  | finish no earlier than 2008-12-12 | R2 | 2112h | 2112h | RANimp-EnhState1.28TDD | Rel-8 | Joern | ZTE | zhang.yincheng@zte.com.cn | PCG-21 | RP-38 |  |
| 498 | 1.121.9 | 1.28 Mcps LCR TDD Repeater | 464d? | 2007-12-04 A | 2009-09-11 | 40% | 278.4d? | 2007-12-04 | 2009-09-11 | 464d? | 130d | finish no earlier than 2009-09-11 | R4 | 3712h | 1484.8h | RANimp-Repeaters1.28TDD | Rel-8 | Stefania | RITT | qinyan@chinattl.com | PCG-21 | RP-38 |  |
| 499 | 1.121.10 | Continuous Connectivity for packet data users for 1.28Mcps TDD | 261d? | 2008-03-07 A | 2009-03-06 | 70% | 78.3d? | 2008-03-07 | 2009-03-06 | 261d? | 265d | finish no earlier than 2009-03-06 | R1 | 2088h | 1461.6h | RANimp-LCRCPC | Rel-8 | Patrick | TD Tech | chenying@td-tech.com | PCG-21 | RP-39 |  |
| 500 | 1.121.11 | HSPA VoIP to WCDMA/GSM CS continuity | 261d? | 2008-03-07 A | 2009-03-06 | 65% | 91.35d? | 2008-03-07 | 2009-03-06 | 261d? | 265d | finish no earlier than 2009-03-06 | R2 | 2088h | 1357.2h | RANimp-HSPAVoIP | Rel-8 | Joern | Nokia | Simone.Provvedi@nokia.com | PCG-21 | RP-39 |  |
| 501 | 1.121.12 | HS-DSCH Serving Cell Change Enhancements | 196d? | 2008-03-07 A | 2008-12-05 A | 100% |  | 2008-03-07 | 2008-12-05 | 196d? |  | finish no earlier than 2008-12-12 | R2 | 1568h | 1568h | RANimp-HSDSCH | Rel-8 | Joern | Ericsson | henrik.enbuske@ericsson.com | PCG-21 | RP-39 |  |
| 502 | 1.121.13 | MIMO for 1.28 Mcps TDD | 251d? | 2007-11-01 A | 2009-05-15 | 60% | 100.4d? | 2007-11-01 | 2009-05-15 | 251d? | 215d | finish no earlier than 2009-05-15 | R1,R4 | 2008h | 1204.8h | RANimp-MIMOLCR | Rel-8 | Patrick | CATT | wangke@datangmobile.cn | PCG-21 | RP-40 |  |
| 503 | 1.121.14 | Support for Additional Navigation Satellite Systems (ANSS) for LCS | 201d? | 2008-05-30 A | 2009-03-06 | 95% | 10.05d? | 2008-05-30 | 2009-03-06 | 201d? | 265d | finish no earlier than 2009-03-06 | R2 | 1608h | 1527.6h | RANimp-ANSS | Rel-8 | Joern | Qualcomm | Etienne Chaponniere (echaponn@qualcomm.com) | PCG-21 | RP-40 |  |
| 504 | 1.121.15 | Dual-Cell HSDPA operation on adjacent carriers | 261d? | 2008-05-30 A | 2009-05-29 A | 100% |  | 2008-05-30 | 2009-05-29 | 261d? |  | finish no earlier than 2009-05-29 | R1 | 2088h | 2088h | RANimp-DCHSDPA | Rel-8 | Patrick | Ericsson | johan.bergman@ericsson.com | PCG-21 | RP-40 |  |

Notes:
- 473: Testing for Feature UID_20068 (LTE)
- 474: SR in RP-080798. RP#41 WID updated RP-070428=>RP-080647. Completion target 12/08=>03/09 / Text3: 36.521-1, 36.521-2, 36.508, 36.523-1, 36.523-2, 36.509
- 475: SR in RP-080799. WID updated RP-080382=>RP-080601. Completion target 12/08=>03/09 / Text3: 36.521-1, 36.521-2, 36.521-3, 36.508, 36.509, 36.903
- 476: SR in RP-080799. RP#41 WID updated RP-080382=>RP-080601. Completion target 12/08=>03/09 / Text3: 36.521-1, 36.521-2, 36.521-3, 36.508, 36.509, 36.903
- 478: SR in RP-070526 / Text3: 25.101, 25.104, 25.133, 25.141, 25.331, 25.942, 25.306, 25.307, 34.121
- 479: SR in RP-080260 / Text3: 25.101, 25.104, 25.133, 25.141, 25.331, 25.942, 25.306, 25.307, 34.121
- 480: SR in RP-080517. RP#41 completed / Text3: 25.102, 25.105, 25.113, 25.123, 25.142, 34.124, 25.306, 25.331, 34.122
- 481: SR in RP-080800. RP#42 WID updated RP-071012=>RP-081096. Testing in UID_4200xy & UID_4200xz / Text3: 25.101, 25.104, 25.113, 25.133, 25.141, 34.124, 25.307, 25.331, 25.461, 25.463, 36.101, 36.104, 36.141, 25.307, 36.331
- 482: SR in RP-080041.
- 483: SR in RP-080042. / Text3: 25.323, 25.331, 25.322
- 484: SR in RP-080043. / Text3: 25.101
- 485: SR in RP-080515. RP#41 stopped / Text3: 25.101, 25.104, 25.133, 25.141, 25.331, 25.942, 25.306, 25.307, 34.121
- 486: 05/08: Linked to Feature UID_20028 (RInImp)
- 487: SR in RP-080542. RP#41 completed. / Text3: 34.108, 34.123-1, 34.123-2, 34.123-3
- 488: SR in RP-080818. RP#42 completed. Linked to UID_370033.
- 490: SR in RP-080518. RP#41 completed / Text3: 25.308, 25.211, 25.212, 25.213, 25.306, 25.331, 25.433, 25.435, 25.423, 25.425, 25.101, 25.104, 25.141
- 491: SR in RP-080265. RP#40 completed / Text3: 25.319, 25.301, 25.306, 25.321, 25.331, 25.433, 25.435, 25.423, 25.425, 25.427
- 492: SR in RP-080804. RP#42 completed / Text3: 25.309, 25.211, 25.214, 25.321, 25.331, 25.423, 25.433
- 493: SR in RP-080520. RP#41 completed / Text3: 25.306, 25.308, 25.321, 25.331, 25.423
- 494: SR in RP-080521. RP#41 completed / Text3: 25.306, 25.308, 25.321, 25.331, 25.423, 25.433, 25.214, 25.133
- 495: SR in RP-080805. RP#42 completed. WID updated RP-070760=>RP-080830 / Text3: 25.423, 25.427, 25.433
- 496: SR in RP-080806. RP#42 completed / Text3: 25.201, 25.221, 25.222, 25.223, 25.224, 25.306, 25.308, 25.321, 25.331, 25.423, 25.433, 25.102, 25.105, 25.142
- 497: SR in RP-080807. RP#42 completed / Text3: 25.308, 25.304, 25.306, 25.224, 25.321, 25.331, 25.433, 25.435, 25.423, 25.425, 25.123
- 498: SR in RP-081087. Completion target 09/09. / Text3: 25.113
- 499: SR in RP-080809. RP#42 Rel-8 extension to 03/09 / Text3: 25.929
- 500: SR in RP-080810. RP#42 Rel-8 extension to 03/09. RP#41 WID updated RP-080229=>RP-080749. / Text3: 25.331, 25.413
- 501: SR in RP-080811. RP#42 completed / Text3: 25.21x, 25.321, 25.331, 25.423, 25.433, 25.101, 25.104, 25.133
- 502: SR in RP-080812. RP#42 Rel-8 extension to 05/09 (R4 part) / Text3: 25.201, 25.221, 25.222, 25.223, 25.224, 25.306, 25.308, 25.321, 25.331, 25.423, 25.433, 25.102, 25.105, 25.142
- 503: SR in RP-080813. RP#42 Rel-8 extension to 03/09 (performance requirements will be considered separately / WI closed at 95%). GERAN leading the work. / Text3: 25.305, 25.331, 25.453, 25.413, 25.423, 25.433
- 504: SR in RP-080814. RP#42 completed except RAN4 part 05/09 / Text3: 25.211, 25.212, 25.213, 25.214, 25.215, 25.308, 25.321, 25.331, 25.423, 25.433, 25.101, 25.104, 25.133

| ID | WBS | Task | Type | Duration | Start | Finish | Complete | Remaining | Baseline start | Baseline finish | Baseline duration | Total slack | Constraint | Resources | Work | Actual work | Text1 | Text6 | Text8 | Text2 | Text4 | Text7 |
| --- | --- | --- | --- | --- | --- | --- | --- | --- | --- | --- | --- | --- | --- | --- | --- | --- | --- | --- | --- | --- | --- | --- |
| 505 | 1.122 | **Rel-8 RAN improvements - UE Conformance Testing** |  | 261d? | 2008-05-30 A | 2009-05-29 | 14% | 223.39d? | 2008-05-30 | 2009-05-29 | 261d? | 205d |  | R5 | 5615.2h | 538.4h | RANimp-UEConTest | Rel-8 | Ingbert |  |  |  |
| 506 | 1.122.1 | Conformance Test Aspects – Improved L2 for uplink |  | 206d? | 2008-05-30 A | 2009-03-13 | 20% | 164.8d? | 2008-05-30 | 2009-03-13 | 206d? | 260d | finish no earlier than 2009-03-13 | R5 | 1648h | 329.6h | RANimp-UEConTest_UplinkL2dataRates | Rel-8 | Ingbert | PCG-21 | Ericsson | RP-40 |
| 507 | 1.122.2 | Conformance Test Aspects – 64QAM for 1.28 Mcps TDD HSDPA |  | 261d? | 2008-05-30 A | 2009-05-29 | 10% | 234.9d? | 2008-05-30 | 2009-05-29 | 261d? | 205d | finish no earlier than 2009-05-29 | R5 | 2088h | 208.8h | RANimp-UEConTest_64Qam1.28TDD | Rel-8 | Ingbert | PCG-21 | ZTE | RP-40 |
| 508 | 1.123 | 3.84 Mcps TDD MBSFN Integrated Mobile Broadcast |  | 395d? | 2007-06-04 A | 2008-12-05 A | 100% |  | 2007-06-04 | 2008-12-05 | 395d? |  | finish no earlier than 2008-12-05 | R1 | 3160h | 3160h | MBSFN-DOB | Rel-8 | Patrick |  | Ericsson |  |
| 509 | 1.124 | **MBMS - UE Conformance Testing** |  | 596d? | 2007-06-01 A | 2009-09-11 | 55% | 269.86d? | 2007-06-01 | 2009-09-11 | 596d? | 130d |  | R5 | 11792h | 6452.7h | MBMSE_UEConTest | Rel-8 | Ingbert | PCG-21 |  | SP-40 |
| 510 | 1.124.1 | Conformance Test Aspects – MBMS TDD Physical layer Enhancements – MBSFN for HCR and VHCR TDD |  | 336d? | 2007-06-01 A | 2008-09-12 A | 100% |  | 2007-06-01 | 2008-09-12 | 336d? |  | start no earlier than 2007-06-01 | R5 | 2688h | 2688h | MBMSE-RANPhysTDD_UEConTest | Rel-7 | Ingbert |  | IPWireless |  |
| 511 | 1.124.2 | Conformance Test Aspects – MBMS LCR TDD Physical Layer Enhancement |  | 336d? | 2008-05-30 A | 2009-09-11 | 40% | 201.6d? | 2008-05-30 | 2009-09-11 | 336d? | 130d | finish no earlier than 2009-09-11 | R5 | 2688h | 1075.2h | MBMSE-RANPhysLCRTDD_UEConTest | Rel-8 | Ingbert | PCG-21 | CATT | RP-40 |
| 512 | 1.124.3 | Conformance Test Aspects – MBSFN for FDD |  | 206d? | 2008-05-30 A | 2009-03-13 | 5% | 195.95d? | 2008-05-30 | 2009-03-13 | 206d? | 260d | finish no earlier than 2009-03-13 | R5 | 1648h | 80.4h | MBMSE-UEConTest_RANPhysFDD | Rel-8 | Ingbert | PCG-21 | Huawei | RP-40 |
| 513 | 1.125 | GERAN support for GERAN - 3G Long Term Evolution interworking |  | 641d? | 2006-09-08 A | 2009-02-20 | 85% | 96.15d? | 2006-09-08 | 2009-02-20 | 641d? | 275d | finish no earlier than 2009-02-20 | GP | 5128h | 4358.8h | GELTE | Rel-8 | Paolo |  | Nokia, Nokia Siemens Networks |  |
| 514 | 1.126 | U-TDOA Enhancement | milestone | 0d? | 2007-05-18 A | 2007-05-18 A | 100% |  | 2007-05-18 | 2007-05-18 | 0d? |  | finish no earlier than 2007-05-18 | GP |  |  | GUTEN | Rel-8 | Paolo |  | TruePosition |  |
| 515 | 1.127 | **GAN Enhancements** |  | 386d? | 2007-08-31 A | 2009-02-20 | 40% | 232.81d? | 2007-08-31 | 2009-02-20 | 386d? | 275d |  | GP | 7184h | 2851.15h | GANENH | Rel-8 | Paolo |  | T-Mobile |  |
| 516 | 1.127.1 | Update to GAN specifications |  | 126d? | 2007-08-31 A | 2008-02-22 A | 100% |  | 2007-08-31 | 2008-02-22 | 126d? |  | finish no earlier than 2008-02-22 | GP | 1008h | 1008h | GANENH-SPEC | Rel-8 | Paolo |  | T-Mobile |  |
| 517 | 1.127.2 | Update TS 51.010 Mobile Station (MS) Conformance Specification for GAN Enhancements |  | 386d? | 2007-08-31 A | 2009-02-20 | 20% | 308.8d? | 2007-08-31 | 2009-02-20 | 386d? | 275d | finish no earlier than 2009-02-20 | GP | 3088h | 617.6h | GANENH-MStest | Rel-8 | Ingbert |  | T-Mobile |  |
| 518 | 1.128 | **AoIP (A-interface over IP)** |  | 2334d? | 2000-01-03 A | 2008-12-11 A | 100% |  | 2000-01-03 | 2008-12-11 | 2334d? |  |  | GP,S4,C4,C1,C3 | 41404.1h | 41404.1h | AoIP | Rel-8 | Paolo | PCG-21 | China Mobile, Ericsson |  |
| 519 | 1.128.1 | GERAN aspects of AoIP |  | 2320d? | 2000-01-03 A | 2008-11-21 A | 100% |  | 2000-01-03 | 2008-11-21 | 2320d? |  | finish no earlier than 2008-11-21 | GP | 18560h | 18560h | AoIP | Rel-8 | Paolo | PCG-21 | China Mobile, Ericsson | SP-40 |
| 520 | 1.128.2 | Media Requirements for CS over IP based User Plane |  | 267d? | 2007-12-05 A | 2008-12-11 A | 100% |  | 2007-12-05 | 2008-12-11 | 267d? |  | finish no earlier than 2008-12-11 | S4 | 1996.09h | 1996.09h | AoIP-CSoIP | Rel-8 | Paolo | PCG-21 | China Mobile, Ericsson | SP-40 |
| 521 | 1.128.3 | Core Network Impacts for A-Interface User Plane over IP |  | 136d? | 2008-05-30 A | 2008-12-05 A | 100% |  | 2008-05-30 | 2008-12-05 | 136d? |  | start no earlier than 2008-05-30 | C4 | 1088h | 1088h | AoIP-CN | Rel-8 | Kimmo | PCG-21 | Ericsson | CP-40 |
| 522 | 1.128.4 | Core Network Impacts for A-Interface User Plane over IP |  | 68d? | 2008-05-30 A | 2008-12-05 A | 100% |  | 2008-05-30 | 2008-12-05 | 68d? |  | finish no earlier than 2008-12-05 | C1 | 544h | 544h | AoIP-CN | Rel-8 | Kimmo | PCG-21 | Ericsson | CP-40 |
| 523 | 1.128.5 | Core Network Impacts for A-Interface User Plane over IP |  | 68d? | 2008-05-30 A | 2008-12-05 A | 100% |  | 2008-05-30 | 2008-12-05 | 68d? |  | finish no earlier than 2008-12-05 | C3 | 544h | 544h | AoIP-CN | Rel-8 | Kimmo | PCG-21 | Ericsson | CP-40 |
| 524 | 1.129 | New multicarrier BTS class |  | 261d? | 2007-08-31 A | 2008-08-29 A | 100% |  | 2007-08-31 | 2008-08-29 | 261d? |  | finish no earlier than 2008-08-29 | G1 | 2088h | 2088h | MCBTS | Rel-8 | Paolo |  | Alcatel-Lucent |  |
| 525 | 1.130 | Support for Additional Navigation Satellite Systems (ANSS) for LCS |  | 136d? | 2008-05-16 A | 2008-11-21 A | 100% |  | 2008-05-16 | 2008-11-21 | 136d? |  | start no earlier than 2008-05-16 | G2 | 1088h | 1088h | ANSS | Rel-8 | Paolo |  | Qualcomm |  |
| 526 | 1.131 | **A-GNSS Performances and Testing Procedures** |  | 341d? | 2008-05-16 A | 2009-09-04 | 9% | 311.43d? | 2008-05-16 | 2009-09-04 | 341d? | 135d |  | GP | 7544h | 654.15h | AGNSSPTP | Rel-8 | Paolo |  | Thales |  |
| 527 | 1.131.1 | A-GNSS Minimum Performances |  | 261d? | 2008-05-16 A | 2009-05-15 | 20% | 208.8d? | 2008-05-16 | 2009-05-15 | 261d? | 215d | start no earlier than 2008-05-16 | G1 | 2088h | 417.6h | AGNSSPTP- Perfreq | Rel-8 | Paolo |  | Thales |  |
| 528 | 1.131.2 | A-GNSS Testing Procedures |  | 341d? | 2008-05-16 | 2009-09-04 |  |  | 2008-05-16 | 2009-09-04 | 341d? | 135d | start no earlier than 2008-05-16 | G3new | 2728h |  | AGNSSPTP-MStest | Rel-8 | Paolo |  | Thales |  |

Notes:
- 505: 05/08: Linked to Feature UID_20029 (RANimp)
- 506: SR in RP-080822. Linked UID_370036. RP#41 WID updated RP-080310=>RP-080606. Completion target 12/08=>03/09. / Text3: 34.108, 34.123-1, 34.123-2, 34.123-3 / Text5: leif.mattisson@ericsson.com
- 507: SR in RP-080825. RP#42 target 03/09=>05/09. Linked UID_380075 / Text3: 34.108, 34.122, 34.123-1, 34.123-2, 34.123-3 / Text5: ma.zijiang@zte.com.cn
- 508: RP#42 completed. WID updated RP-070493=>RP-081124 (changed WI title "MBSFN Downlink Optimized Broadcast (DOB) 3.84 Mcps TDD" => "3.84Mcps TDD MBSFN Integrated Mobile Broadcast"). RP#39 SR in RP-080218. / Text3: 25.102, 25.105, 25.123, 25.201, 25.221, 25.222, 25.223, 25.306, 25.331, 25.346, 25.402, 25.433 / Text5: Lars Lindbom
- 510: SR in RP-080541. RP#41 completed. Linked to Feature UID_31084 (MBMSE), BB UID_340043 (MBMSE-RANPhysTDD) / Text3: 34.108, 34.122, 34.123-1/2/3 / Text5: tspeight@ipwireless.com
- 511: SR in RP-080826. Linked UID_31084 (MBMSE). / Text5: chenxiaozhong@datangmobile.cn
- 512: SR in RP-080823 / Text5: Xiang Li (trica_li@huawei.com)
- 513: GP#40 Rel-8 extension to 02/09 / Text3: 24.008, 43.055, 43.129, 43.246, 44.018, 44.060, 45.002, 45.008, 45.010, 48.008, 48.018, 51.010 / Text5: sergio.parolari@nsn.com, vlora.rexhepi@nokia.com
- 514: GP#36 completed / Text3: 43.059, 45.008, 48.071 / Text5: terri.brooks@trueposition.com
- 515: GP#37 completed. Testing open / Text5: mohammed.versi@t-mobile.com
- 516: GP#37 completed / Text3: 43.318, 44.318 / Text5: mohammed.versi@t-mobile.com
- 517: GP#39 completion target 08/08=>11/08=>02/09 / Text3: 51.010 / Text5: mohammed.versi@t-mobile.com
- 518: GP#40/TSG#42 completed . Triggered by TR 43.903 Study on A-interface over IP (AINTIP) UID_50589. / Text5: wangshuaiyu@chinamobile.com and paul.schliwa-bertling@ericsson.com
- 519: GP#40 completed. GP#39 updated WID GP-080901=>GP-081362. / Text3: 48.001, 48.002, 48.008, 48.020, 49.008, 48.103 / Text5: wangshuaiyu@chinamobile.com and paul.schliwa-bertling@ericsson.com
- 520: SA#42 completed / Text3: 26.102, 26.103, 26.202 / Text5: Karl.Hellwig@Ericsson.com
- 521: CT#42 completed. Updated WID CP-080278=>CP-080722 / Text3: 23.205, 23.153, 23.231, 29.232 / Text5: Phil Hodges
- 522: CT#42 completed. Updated WID CP-080278=>CP-080722 / Text3: 23.009 / Text5: Phil Hodges
- 523: CT#42 completed. Updated WID CP-080278=>CP-080722 / Text3: 29.007 / Text5: Phil Hodges
- 524: GP#39 completed / Text3: 45.005, 45.050, 51.021 / Text5: thomas.bitzer@alcatel-lucent.de
- 525: GP#40 completed. Align with RANimp-ANSS ongoing work item. GP#40 WID updated GP-080776=>GP-081784 (Conformance testing moved to A-GNSS WID) / Text3: 43.059, 44.031, 49.031, 44.071, 48.031, 51.010 / Text5: Mungal Dhanda
- 526: GP#40 Completion target 08/09=>09/09. WID updated GP-080790=>GP-081785. / Text5: Michel.monnerat@thalesaleniaspace.com
- 527: GP#40 WID updated GP-080791=>GP-081786 / Text3: 45.005 / Text5: Michel.monnerat@thalesaleniaspace.com
- 528: GP#40 WID updated GP-080792=>GP-081787. / Text3: 51.010-1 / Text5: Michel.monnerat@thalesaleniaspace.com

| ID | WBS | Task | Type | Duration | Start | Finish | Complete | Remaining | Baseline start | Baseline finish | Baseline duration | Total slack | Constraint | Resources | Work | Actual work | Text1 | Text2 | Text4 | Text6 | Text8 | Text3 | Text7 | Text12 |
| --- | --- | --- | --- | --- | --- | --- | --- | --- | --- | --- | --- | --- | --- | --- | --- | --- | --- | --- | --- | --- | --- | --- | --- | --- |
| 529 | 1.132 | **Conformance testing for the Latency Reductions feature** |  | 411d? | 2008-02-22 A | 2009-09-18 | 64% | 146.24d? | 2008-02-22 | 2009-09-18 | 411d? | 125d |  | G1, G3new | 8664h | 5581.32h | CTLATRED | PCG-21 | Ericsson | Rel-8 | Paolo |  |  |  |
| 530 | 1.132.1 | MS conformance testing for the Latency Reductions feature |  | 411d? | 2008-02-22 A | 2009-09-18 | 45% | 226.05d? | 2008-02-22 | 2009-09-18 | 411d? | 125d | finish no earlier than 2009-09-18 | G3new | 3288h | 1479.6h | CTLATRED-MStest | PCG-21 | Ericsson | Rel-8 | Ingbert | 51.010 |  |  |
| 531 | 1.132.2 | BTS conformance testing for the Latency Reductions feature |  | 261d? | 2008-02-22 A | 2009-02-20 | 95% | 13.05d? | 2008-02-22 | 2009-02-20 | 261d? | 275d | finish no earlier than 2009-02-20 | G1 | 2088h | 1983.6h | CTLATRED-BTStest | PCG-21 | Ericsson | Rel-8 | Paolo | 51.021 |  |  |
| 532 | 1.133 | MS Conformance Tests of changes introduced by WI “Support of Packet-switched Handover for GERAN A/Gb mode” |  | 196d? | 2008-02-22 A | 2008-11-21 A | 100% |  | 2008-02-22 | 2008-11-21 | 196d? |  | finish no earlier than 2008-11-21 | G3new | 1568h | 1568h | PSHCT-MStest | PCG-21 | Rohde & Schwarz | Rel-8 | Ingbert | 51.010 |  |  |
| 533 | 1.134 | Mobile Station conformance testing of Support of Conversational Services in A/Gb mode via the PS domain |  | 321d? | 2008-02-22 | 2009-05-15 |  |  | 2008-02-22 | 2009-05-15 | 321d? | 215d | finish no earlier than 2009-05-15 | G3new | 2568h |  | SCSAGBCT-MStest | PCG-21 | Nokia | Rel-8 | Ingbert | 51.010 |  |  |
| 534 | 1.135 | (Small) Technical Enhancements and Improvements for Rel-8 |  | 509d? | 2007-01-01 A | 2008-12-11 | 75% | 127.25d? | 2007-01-01 | 2008-12-11 | 509d? | 326d | finish no earlier than 2008-12-11 | All | 4072h | 3054h | TEI8 |  | ALL | Rel-8 |  |  |  |  |
| 535 | 1.136 | Test - (Small) Technical Enhancements and Improvements for Rel-8 |  | 140d? | 2008-05-30 A | 2008-12-11 | 70% | 42d? | 2008-05-30 | 2008-12-11 | 140d? | 326d | start no earlier than 2008-05-30 | R5 | 1120h | 784h | TEI8_Test | PCG-21 | ALL | Rel-8 | Ingbert |  | RP-40 |  |
| 536 | 1.137 | **Deleted - All-IP Network** |  | 448d? | 2004-06-28 A | 2006-03-15 A | 100% |  | 2004-06-28 | 2006-03-15 | 448d? |  |  | S1 | 7168h | 7168h | AIPN |  | NTT DoCoMo | Rel-8 | Alain |  |  | SP-38 |
| 537 | 1.137.1 | Deleted - Stage 1 |  | 448d? | 2004-06-28 A | 2006-03-15 A | 100% |  | 2004-06-28 | 2006-03-15 | 448d? |  | finish no earlier than 2006-03-15 | S1 | 3584h | 3584h | AIPN |  | NTT DoCoMo | Rel-8 | Alain | 22.258 |  | SP-38 |
| 538 | 1.138 | Deleted - was Rel7 - LCS for 3GPP Interworking WLAN | milestone | 0d? | 2007-09-28 A | 2007-09-28 A | 100% |  | 2007-09-28 | 2007-09-28 | 0d? |  | start no earlier than 2007-09-28 | S2 |  |  | LCS4_IWLAN |  | LG Electronics | Rel-8 | Maurice | 23.234, 23.271, 23.167 |  | SP-35 |
| 539 | 1.139 | Deleted - never approved- FBI Phase 2 | milestone | 0d | 2007-09-28 A | 2007-09-28 A | 100% |  | 2007-09-28 | 2007-09-28 | 0d |  | start no earlier than 2007-09-28 | S2 |  |  | FBI2 |  | Nokia Siemens Networks | Rel-8 | Maurice |  |  | SP-38 |
| 540 | 1.140 | Deleted -Enhancements to BS30 Bearer service for Videotelephony | milestone | 0d? | 2007-03-15 A | 2007-03-15 A | 100% |  | 2007-03-15 | 2007-03-15 | 0d? |  | finish no earlier than 2007-03-15 | S1 |  |  | BS30 |  |  | Rel-8 | Alain | 22.002, 22.004, 22.101, 22.105, 24.008 |  | SP-38 |
| 541 | 1.141 | Deleted - IMS Enhancements Rel-8 |  | 75d? | 2007-09-03 A | 2007-12-14 A | 100% |  | 2007-09-03 | 2007-12-14 | 75d? |  |  | S1 | 600h | 600h | IMS8 |  | Telecom Italia | Rel-8 | Alain |  | SP-37 | SP-38 |
| 542 | 1.142 | Release 8 Feasibility Studies | milestone | 0d? | 2008-03-20 | 2008-03-20 |  |  | 2008-03-20 | 2008-03-20 | 0d? | 516d | finish no earlier than 2008-03-20 | CP,GP,RP,SP |  |  |  |  |  | Rel-8 |  |  |  |  |
| 543 | 1.143 | Study on Customised Alerting Tone (CAT) Requirements |  | 245d? | 2005-10-07 A | 2006-09-14 A | 100% |  | 2005-10-07 | 2006-09-14 | 245d? |  | start no earlier than 2005-10-07 | S1 | 1960h | 1960h | FS_CAT |  | China Mobile | Rel-8 | Michael | 22.982 |  |  |
| 544 | 1.144 | Study on Facilitating Machine to Machine Communication in GSM and UMTS (M2M) |  | 350d? | 2005-11-04 A | 2007-03-08 A | 100% |  | 2005-11-04 | 2007-03-08 | 350d? |  | finish no earlier than 2006-06-16 | S1 | 2800h | 2800h | FS_M2M |  | Siemens | Rel-8 | Alain | 22.868 |  |  |
| 545 | 1.145 | Study on Network Composition |  | 526d? | 2005-12-07 A | 2007-12-12 A | 100% |  | 2005-12-07 | 2007-12-12 | 526d? |  | finish no earlier than 2006-09-27 | S1 | 4208h | 4208h | FS_NetComp |  | Siemens | Rel-8 | Alain | 22.980 |  |  |
| 546 | 1.146 | Study on Requirements of IMS Multimedia Conferencing |  | 330d? | 2006-06-08 A | 2007-09-12 A | 100% |  | 2006-06-08 | 2007-09-12 | 330d? |  | finish no earlier than 2007-03-21 | S1 | 2640h | 2640h | FS_IMSconf |  | China Mobile | Rel-8 | Alain | 22.948 |  |  |
| 547 | 1.147 | Study on support of a Public Warning System |  | 140d? | 2007-09-03 A | 2008-03-14 A | 100% |  | 2007-09-03 | 2008-03-14 | 140d? |  |  | S1 | 1120h | 1120h | FS_PWS |  | T-Mobile | Rel-8 | Alain | 22.968 |  |  |
| 548 | 1.148 | Study on Paging Permission with Access Control |  | 256d? | 2006-09-28 A | 2007-09-20 A | 100% |  | 2006-09-28 | 2007-09-20 | 256d? |  | finish no earlier than 2007-09-20 | S1 | 2048h | 2048h | FS_PPAC |  | NTT DoCoMo | Rel-8 | Alain | 22.908 |  |  |
| 549 | 1.149 | Study on Non 3GPP access NSP |  | 392d? | 2006-12-06 A | 2008-06-05 A | 100% |  | 2006-12-06 | 2008-06-05 | 392d? |  | finish no earlier than 2007-11-19 | S1 | 3136h | 3136h | FS_N3GtoNSP |  | Telefonica O2 | Rel-8 | Alain | 22.912 |  |  |
| 550 | 1.150 | Study on Value Added Services for Short Message Service |  | 263d? | 2006-12-06 A | 2007-12-07 A | 100% |  | 2006-12-06 | 2007-12-07 | 263d? |  | finish no earlier than 2007-12-07 | S1 | 2104h | 2104h | FS_VAS4SMS |  | China Mobile | Rel-8 | Alain | 22.942 |  |  |
| 551 | 1.151 | Study on Service continuity between mobile and WLAN networks |  | 262d? | 2006-12-06 A | 2007-12-06 A | 100% |  | 2006-12-06 | 2007-12-06 | 262d? |  | finish no earlier than 2008-12-25 | S1 | 2096h | 2096h | FS_SMLSWLAN |  | BT | Rel-8 | Alain | 22.937 |  |  |
| 552 | 1.152 | Study on Services Alignment and Migration |  | 331d? | 2006-12-06 A | 2008-03-12 A | 100% |  | 2006-12-06 | 2008-03-12 | 331d? |  | finish no earlier than 2007-09-20 | S1 | 2648h | 2648h | FS_ServAl |  | China Mobile | Rel-8 | Alain | 22.983 | SP-37 |  |

Notes:
- 529: GP#40 target completion 11/08=>09/09 / Text5: mats.y.samuelsson@ericsson.com and hakan.e.grunditz@ericsson.com
- 530: GP#40 target completion 11/08=>09/09 / Text5: hakan.e.grunditz@ericsson.com
- 531: GP#40 completion target 08/08=>11/08=>02/09 / Text5: mats.y.samuelsson@ericsson.com
- 532: GP#40 completed / Text5: Franz.Segerer@ROHDE-SCHWARZ.COM
- 533: Text5: arsi.heino@nokia.com
- 536: SA#38 stopped. 25/07/08 Moved UID_31059 Study on All-IP Network (FS_AIPN/was AIPFS ) to Rel-7 out of the stopped Rel-8 Feature UID_31067 Deleted - All-IP Network (AIPN) / Text5: c.masyu@nttdocomo.co.jp
- 537: 22.258 withdrawn, superseded by 22.278 (UID 320022). SA#38 stopped / Text5: c.masyu@nttdocomo.co.jp
- 538: SP-35 stopped / Text5: dhshim@lge.com
- 539: SA#38 stopped
- 540: SA#38 stopped (no support) / Text5: andre.jarvis@three.co.uk
- 541: SA#38 stopped
- 543: Spin-off WID UID_370028 under Feature CAT UID_340029 / Text5: fenglingjuan@chinamobile.com
- 544: SA#35 completed. Spin-off SA3 SID UID_370053. SA#40 Spin-off new Feature UID_400033 (NIMTC) / Text5: Juergen Merkel
- 545: SA#38 completed / Text5: joerg.swetina@siemens.com
- 546: SA#37 completed. Spin-off New Feature UID_370026 (VAS4SM) / Text5: zhengjianping@chinamobile.com
- 547: SA#39 completed. Spin-off Rel-9 Feature UID_380057 (PWS) / Text5: mark.younge@t-mobile.com
- 548: SA#37 completed. Spin-off new Feature UID_370084 (PPACR) / Text5: noguchi@nttdocomo.co.jp
- 549: SA#38 completed. Spin-off New Feature UID_380062 (N3GTONSP). SA#40 WID updated SP-060930=>SP-080318. TR re-approved with new # 22.812=>22.912 / Text5: chris.friel@o2.com
- 550: SA#38 completed. Spin-off New Feature UID_370026 (VAS4SM) / Text5: wubin@chinamobile.com
- 551: SA#38 completed / Text5: mike.meyerstein@bt.com
- 552: SA#39 completed. Spin-off Feature UID_330017 (ServAl) / Text5: fenglingjuan@chinamobile.com

| ID | WBS | Task | Duration | Start | Finish | Complete | Remaining | Baseline start | Baseline finish | Baseline duration | Total slack | Constraint | Resources | Work | Actual work | Text1 | Text4 | Text5 | Text6 | Text8 | Text3 | Text2 | Text7 | Text12 |
| --- | --- | --- | --- | --- | --- | --- | --- | --- | --- | --- | --- | --- | --- | --- | --- | --- | --- | --- | --- | --- | --- | --- | --- | --- |
| 553 | 1.153 | **Study on 3GPP System Architecture Evolution** | 1115d? | 2004-12-03 A | 2009-03-12 | 99% | 10.63d? | 2004-12-03 | 2009-03-12 | 1115d? | 261d |  | S2,S3 | 23976h | 23747.5h | FS_SAE | Vodafone | Chris Pudney | Rel-8 | Maurice |  |  |  |  |
| 554 | 1.153.1 | Stage 2 Interim conclusion for RAN Work to start | 990d? | 2004-12-03 A | 2008-09-18 A | 100% |  | 2004-12-03 | 2008-09-18 | 990d? |  | finish no earlier than 2005-09-23 | S2 | 7920h | 7920h | FS_SAE | Vodafone | Chris Pudney | Rel-8 | Maurice | 23.882 |  |  |  |
| 555 | 1.153.2 | Stage 2 study on 3GPP architectural development | 704d? | 2006-01-09 A | 2008-09-18 A | 100% |  | 2006-01-09 | 2008-09-18 | 704d? |  | finish no earlier than 2007-09-28 | S2 | 5632h | 5632h | FS_SAE | Vodafone | Chris Pudney | Rel-8 | Maurice | 23.882 |  |  |  |
| 556 | 1.153.3 | Security study for Inter-access mobility between non 3GPP and 3GPP system | 399d? | 2007-09-03 A | 2009-03-12 | 95% | 19.95d? | 2007-09-03 | 2009-03-12 | 399d? | 261d | finish no earlier than 2009-03-12 | S3 | 3192h | 3032.4h | FS_SAE | Nokia | dajiang.zhang@nokia.com | Rel-8 | Dionisio | 33.821, 33.922 |  |  |  |
| 557 | 1.154 | Study on Stage 2 aspects of IMS Service Brokering | 589d? | 2006-06-19 A | 2008-09-18 A | 100% |  | 2006-06-19 | 2008-09-18 | 589d? |  | finish no earlier than 2008-09-18 | S2 | 4712h | 4712h | FS_ISB_ST2 | Telcordia | raquel@research.telcordia.com | Rel-8 | Maurice | 23.810 |  |  |  |
| 558 | 1.155 | Study on IMS utilizing multicast bearer services | 447d? | 2006-03-22 A | 2007-12-06 A | 100% |  | 2006-03-22 | 2007-12-06 | 447d? |  | finish no earlier than 2007-12-03 | S2 | 3576h | 3576h | FS_MLTICAST-IMS | Nokia Siemens Networks |  | Rel-8 | Maurice | 23.847 |  |  |  |
| 559 | 1.156 | Study on Mobility between 3GPP-WLAN Interworking and 3GPP Systems | 393d? | 2007-03-20 A | 2008-09-18 A | 100% |  | 2007-03-20 | 2008-09-18 | 393d? |  | finish no earlier than 2008-09-18 | S2 | 3144h | 3144h | FS_SM3GWLAN | Orange | Orange | Rel-8 | Maurice | 23.827 WITHDRAWN |  |  |  |
| 560 | 1.157 | Study on Multimedia Session Continuity | 291d? | 2007-04-26 A | 2008-06-05 A | 100% |  | 2007-04-26 | 2008-06-05 | 291d? |  | finish no earlier than 2008-06-05 | S2 | 2328h | 2328h | FS_MMSC | LG Electronics |  | Rel-8 | Maurice | 23.893 |  |  |  |
| 561 | 1.158 | **Study on centralized IMS service control** | 363d? | 2006-10-23 A | 2008-03-12 A | 100% |  | 2006-10-23 | 2008-03-12 | 363d? |  |  | S2,S1 | 7952h | 7952h | FS_ICS | Ericsson | peter.bleckert@ericsson.com | Rel-8 | Alain |  | PCG-21 | SP-38 |  |
| 562 | 1.158.1 | Study on centralized IMS services requirements | 268d? | 2007-03-05 A | 2008-03-12 A | 100% |  | 2007-03-05 | 2008-03-12 | 268d? |  | start no earlier than 2007-03-05 | S1 | 2144h | 2144h | FS_ICS-S1 | Ericsson | peter.bleckert@ericsson.com | Rel-8 | Alain | 22.892 |  | SP-37 |  |
| 563 | 1.158.2 | Study on centralized IMS services control | 363d? | 2006-10-23 A | 2008-03-12 A | 100% |  | 2006-10-23 | 2008-03-12 | 363d? |  | finish no earlier than 2008-02-21 | S2 | 2904h | 2904h | FS_IMS_CSC | Alcatel-Lucent | andybennett@Alcatel-Lucent.com | Rel-8 | Maurice | 23.892 |  |  |  |
| 564 | 1.159 | Study on Architecture of IMS based Customized Alerting Tone (CAT) | 208d? | 2007-12-04 A | 2008-09-18 A | 100% |  | 2007-12-04 | 2008-09-18 | 208d? |  | finish no earlier than 2008-09-08 | S2 | 1664h | 1664h | FS_CAT-St2 | China Mobile | WANG, Jing (wangjing@chinamobilecom) | Rel-8 | Maurice | 23.872 | PCG-21 | SP-38 |  |
| 565 | 1.160 | Study on Transferring of emergency call data – in-band modem solution | 265d? | 2006-12-07 A | 2007-12-12 A | 100% |  | 2006-12-07 | 2007-12-12 | 265d? |  | finish no earlier than 2008-09-18 | S4 | 2120h | 2120h | eCALLIBMS | Airbiquity | lhong@airbiquity.com | Rel-8 | Paolo | 26.967 |  |  |  |
| 566 | 1.161 | Study on Element Operations Systems Function (EOSF) definition | 266d? | 2007-06-07 A | 2008-06-12 A | 100% |  | 2007-06-07 | 2008-06-12 | 266d? |  | finish no earlier than 2008-12-11 | S5 | 2128h | 2128h | OAM7-NIM- EOSF | China Mobile | LI, Jian | Rel-8 | Dionisio | 32.819 |  |  |  |
| 567 | 1.162 | Study on SA5 MTOSI XML Harmonization | 351d? | 2006-05-10 A | 2007-09-12 A | 100% |  | 2006-05-10 | 2007-09-12 | 351d? |  | finish no earlier than 2007-12-14 | S5 | 2808h | 2808h | OAM7-NIM-XML | Nortel | jduguay@nortel.com | Rel-8 | Dionisio | 32.818 |  |  |  |
| 568 | 1.163 | Study on Common Profile Storage (CPS) Framework of User Data for network services and management | 244d? | 2006-07-03 A | 2007-06-07 A | 100% |  | 2006-07-03 | 2007-06-07 | 244d? |  | finish no earlier than 2007-06-07 | S5 | 1952h | 1952h | OAM7-CPS | T-Mobile | ABA, Istvan | Rel-8 | Dionisio | 32.808 |  |  |  |
| 569 | 1.164 | Study on Management for LTE and SAE | 526d? | 2006-12-07 A | 2008-12-11 A | 100% |  | 2006-12-07 | 2008-12-11 | 526d? |  | finish no earlier than 2008-12-11 | S5 | 4208h | 4208h | FS_OAM_LTE_SAE | Ericsson | PETERSEN, Robert | Rel-8 | Dionisio | 32.816 |  |  |  |
| 570 | 1.165 | Study on Charging Aspects of 3GPP System Evolution | 179d? | 2007-04-02 A | 2007-12-06 A | 100% |  | 2007-04-02 | 2007-12-06 | 179d? |  | finish no earlier than 2007-12-06 | S5 | 1432h | 1432h | FS_SAEcharg | Nokia Siemens Networks | GÖRMER, Gerald | Rel-8 | Dionisio | 32.820 |  |  |  |
| 571 | 1.166 | Study on AS-MRFC media server control protocol | 583d? | 2006-03-22 A | 2008-06-13 A | 100% |  | 2006-03-22 | 2008-06-13 | 583d? |  | finish no earlier than 2008-06-13 | C1 | 4664h | 4664h | MRFC | HP | mark.syrett@hp.com | Rel-8 | Frederic | 24.880 |  |  |  |
| 572 | 1.167 | Study on IMS Restoration Procedures | 310d? | 2007-03-26 A | 2008-05-30 A | 100% |  | 2007-03-26 | 2008-05-30 | 310d? |  | finish no earlier than 2008-05-30 | C4 | 2480h | 2480h | FS_IMS_RP | Ericsson | german.blanco@ericsson.com | Rel-8 | Kimmo | 23.820 |  |  |  |
| 573 | 1.168 | Study on IMS Application Server Service Data Descriptions for AS interoperability | 261d? | 2007-09-14 A | 2008-09-12 A | 100% |  | 2007-09-14 | 2008-09-12 | 261d? |  | finish no earlier than 2008-09-12 | C4 | 2088h | 2088h | FS_IMS_ASIO | Alcatel-Lucent | Jean-Jacques Trottin | Rel-8 | Kimmo | 29.864 |  |  |  |
| 574 | 1.169 | Study on Customized Alerting Tone (CAT) solution for voice and video call in CS domain | 261d? | 2007-09-14 A | 2008-09-12 A | 100% |  | 2007-09-14 | 2008-09-12 | 261d? |  |  | C4 | 626.4h | 626.4h | FS_CAT_VVC_CS | China Mobile | zhanghao@chinamobile.com | Rel-8 | Kimmo | 29.882 |  |  |  |
| 575 | 1.170 | Study on InterWorking Function between MAP based and Diameter based interfaces | 266d? | 2007-11-30 A | 2008-12-05 A | 100% |  | 2007-11-30 | 2008-12-05 | 266d? |  | finish no earlier than 2008-12-05 | C4 | 2128h | 2128h | FS_MAP2Diam | Huawei | liming49985@huawei.com | Rel-8 | Kimmo | 29.805 | PCG-21 | CP-38 |  |
| 576 | 1.171 | Study on Scope of future HSPA Evolution for 1.28Mcps TDD | 186d? | 2007-09-14 A | 2008-05-30 A | 100% |  | 2007-09-14 | 2008-05-30 | 186d? |  | finish no earlier than 2008-05-30 | R1 | 1488h | 1488h | FS_RAN-LCRTDDHSPAEvo | RITT | Xu Fei | Rel-8 | Patrick | 25.824 |  | RP-37 |  |
| 577 | 1.172 | Study on Synchronized E-DCH for UTRA FDD | 126d? | 2007-09-14 A | 2008-03-07 A | 100% |  | 2007-09-14 | 2008-03-07 | 126d? |  | finish no earlier than 2008-03-14 | R1 | 1008h | 1008h | FS_RAN-UplinkSync | Nokia Siemens Networks | Karri.Ranta-aho@nsn.com | Rel-8 | Patrick | 25.823 |  | RP-37 |  |
| 578 | 1.173 | Study on Dual-Cell HSDPA operation | 196d? | 2007-08-15 | 2008-12-05 |  |  | 2007-08-15 | 2008-12-05 | 196d? | 330d | finish no earlier than 2008-12-05 | R1 | 1568h |  | FS_RAN-DCHS | Qualcomm | Josef Blanz | Rel-8 | Patrick | 25.825 | PCG-21 | RP-39 |  |
| 579 | 1.174 | Study on Improved network controlled mobility between LTE and 3GPP2/mobile WiMAX radio technologies | 131d? | 2007-06-04 A | 2007-12-03 A | 100% |  | 2007-06-04 | 2007-12-03 | 131d? |  | finish no earlier than 2007-12-03 | R4 | 1048h | 1048h | FS_RAN-LTEmob | Motorola | hao.bi@Motorola.com | Rel-8 | Joern | 36.938 |  |  |  |
| 580 | 1.175 | Study on 3G Home NodeB/eNodeB | 325d? | 2007-03-05 A | 2008-05-30 A | 100% |  | 2007-03-05 | 2008-05-30 | 325d? |  | finish no earlier than 2008-05-30 | R4 | 2600h | 2600h | FS_RAN-HNBeNB | Motorola | Howard Thomas | Rel-8 | Stefania | 25.820 |  |  |  |
| 581 | 1.176 | Study on HS-PDSCH serving cell change enhancements | 60d? | 2007-12-17 A | 2008-03-07 A | 100% |  | 2007-12-17 | 2008-03-07 | 60d? |  | finish no earlier than 2008-06-12 | R4 | 480h | 480h | FS_RAN-HSPDSCH | Qualcomm |  | Rel-8 | Stefania | none | PCG-21 | RP-38 |  |
| 582 | 1.177 | Study on A-interface over IP | 126d? | 2007-08-31 A | 2008-02-22 A | 100% |  | 2007-08-31 | 2008-02-22 | 126d? |  | finish no earlier than 2008-02-22 | GP | 1008h | 1008h | AINTIP | China Mobile, Ericsson | paul.schliwa-bertling@ericsson.com | Rel-8 | Paolo | 43.903 |  |  |  |
| 583 | 1.178 | Study on Multi-User Reusing-One-Slot | 331d? | 2007-11-16 A | 2009-02-20 | 90% | 33.1d? | 2007-11-16 | 2009-02-20 | 331d? | 275d | finish no earlier than 2009-02-20 | GP | 2648h | 2383.2h | MUROS | Nokia Siemens Networks | juergen.hofmann@nsn.com | Rel-8 | Paolo |  |  |  |  |
| 584 | 1.179 | Study on Optimized Transmit Pulse Shape for Downlink EGPRS2-B | 331d? | 2007-11-16 A | 2009-02-20 | 85% | 49.65d? | 2007-11-16 | 2009-02-20 | 331d? | 275d | finish no earlier than 2009-02-20 | G1 | 2648h | 2250.8h | WIDER | RIM, Nokia Siemens Networks | jdwyer@RIM.COM and eddie.riddington@nsn.com | Rel-8 | Paolo | 45.9xx |  |  |  |
| 585 | 1.180 | Deleted - equals 340035 -FS on Service continuity between mobile and WLAN networks | 75d? | 2007-09-03 A | 2007-12-14 A | 100% |  | 2007-09-03 | 2007-12-14 | 75d? |  | finish no earlier than 2007-12-14 | S1 | 600h | 600h | FSSCMobToW | BT | mike.meyerstein@bt.com | Rel-8 | Alain | 22.937 |  | SP-37 | SP-39 |
| 586 | 1.181 | Deleted - Study on Evaluation of LCS Control Plane Solution for EPS | 100d? | 2008-01-14 A | 2008-05-30 A | 100% |  | 2008-01-14 | 2008-05-30 | 100d? |  | finish no earlier than 2009-03-20 | S2 | 800h | 800h | FS_LCS_EPS | SiRF |  | Rel-8 | Maurice | 23.891 | PCG-21 | SP-38 | SP-40 |
| 587 | 1.182 | Release 7 Features | 1d? | 2000-01-03 | 2000-01-03 |  |  | 2000-01-03 | 2000-01-03 | 1d? | 2659d | start no earlier than 2000-01-01 | CP,GP, RP,SP | 8h |  |  |  |  | Rel-7 |  |  |  |  |  |

Notes:
- 553: SA#41 TR 23.882 completed. TR 33.922 for Information
- 554: SA#41 completed
- 555: SA#41 completed
- 556: Moved from Rel-7. SA#41 TR 33.922 for Information
- 557: SA#41 completed. No spin-off activity proposed. [Note: IMS Service Brokering enhancements UID_31088 moved back from R8 to R7 to give a home to 22228CR0036_(Rel-7)_S1-051232. Hence, Rel-7 ISB has Stage 1 only (and is misaligned with Rel-7 Stages 2/3.]
- 558: SA#38 completed
- 559: 08/08/08 TR 23.827 v 0.4.0 no progress for 1 year. MCC recommended FS be completed and 23.827 brought under CR. SA#41 completed (draft TR 23.827 not SA approved/published; TR content implemented in TSs)
- 560: SA#40 completed
- 561: SA#39 completed
- 562: SA#39 completed
- 563: SA#39 completed
- 564: SA#41 completed as Rel-8
- 565: SA#38 completed. Spin-off WID UID_34042 (eCall_Phase2)
- 566: SA#40 completed. SID updated SP-050608=>SP-070307
- 567: SA#37 completed. SID updated SP-050295=>SP-070305
- 568: SA#36 completed. Spin-off New Feature UID_400034 (UDC)
- 569: SA#42 completed
- 570: SA#38 completed
- 571: CT#40 completed. Spin-off New Feature UID_380035 (MRFC_TS)
- 572: CT#40 completed. Spin-off WID UID_400012 (IMS_RP)
- 573: CT#41 completed. Linked to SA5 Study on Common Profile Storage framework UID_320006. Spin-off WID UID_410003 (IMS_ASIO)
- 574: CT#41 completed. Spin-off WID under Feature CAT UID_340029
- 575: CT#41 Spin-off WID UID_410007 (MAP2Diam). CP#42 completed
- 576: SID in RP-070748. RP#40 completed. SR in 080290
- 577: SID in RP-070678. RP#39 completed. SR in RP-080068
- 578: RP#40: SR in RP-080292. SI is on hold. New WID RP-080490 (RANimp-DCHSDPA) UID_400052 aproved.
- 579: SR in RP-070827. RP#38 completed
- 580: SID in RP-070257. RP#40 completed. SR in RP-080289
- 581: SID in RP-071044. SR in RP-080070. The study produced no TR. RP#39 completed. Spin-off New implementation WID in RP-080227
- 582: GP#37 completed. Spin-off implementation Feature AoIP (A-interface over IP) UID_50591
- 583: GP#40 completion target 11/08=>02/09
- 584: GP#40 completion target 11/08=>02/09
- 585: SA#39 stopped
- 586: SA#38 SID approved. SA#40 spin-off Feature UID_400038 (LCS_CPS_EPS). SP-40 FS stopped

| ID | WBS | Task | Type | Duration | Start | Finish | Complete | Remaining | Baseline start | Baseline finish | Baseline duration | Total slack | Constraint | Resources | Work | Actual work | Text1 | Text4 | Text5 | Text6 | Text8 | Text12 | Text7 | Text2 |
| --- | --- | --- | --- | --- | --- | --- | --- | --- | --- | --- | --- | --- | --- | --- | --- | --- | --- | --- | --- | --- | --- | --- | --- | --- |
| 588 | 1.183 | **Identification of Communication Services in IMS** |  | 620d? | 2005-05-02 A | 2007-09-14 A | 100% |  | 2005-05-02 | 2007-09-14 | 620d? |  |  | S2,S1,C1,S5 | 13016h | 13016h | ServID | Ericsson | stephen.terrill@ericsson.com | Rel-7 | Maurice |  |  |  |
| 589 | 1.183.1 | TR on ServID |  | 232d? | 2005-05-02 A | 2006-03-21 A | 100% |  | 2005-05-02 | 2006-03-21 | 232d? |  | finish no earlier than 2006-03-20 | S2 | 1856h | 1856h | ServID | Ericsson | stephen.terrill@ericsson.com | Rel-7 | Maurice |  |  |  |
| 590 | 1.183.2 | Stage 1,2 of ServID |  | 144d? | 2005-11-11 A | 2006-05-31 A | 100% |  | 2005-11-11 | 2006-05-31 | 144d? |  | start no earlier than 2005-11-11 | S1,S2 | 1152h | 1152h | ServID | Ericsson | stephen.terrill@ericsson.com | Rel-7 | Maurice |  |  |  |
| 591 | 1.183.3 | Stage 3 of ServID |  | 250d? | 2006-03-31 A | 2007-03-15 A | 100% |  | 2006-03-31 | 2007-03-15 | 250d? |  | finish no earlier than 2007-03-15 | C1 | 2000h | 2000h | ServID | Ericsson | christer.holmberg@ericsson.com | Rel-7 | Frederic |  |  |  |
| 592 | 1.183.4 | Charging of ServID |  | 381d? | 2006-03-31 A | 2007-09-14 A | 100% |  | 2006-03-31 | 2007-09-14 | 381d? |  | finish no earlier than 2007-09-14 | S5 | 3048h | 3048h | ServID | Orange | alain.bibas@orange-ft.com | Rel-7 | Adrian |  |  |  |
| 593 | 1.184 | **Supporting Globally Routable User Agent URIs in IMS** |  | 415d? | 2005-11-14 A | 2007-06-15 A | 100% |  | 2005-11-14 | 2007-06-15 | 415d? |  |  | S2,S1,C1 | 7760h | 7760h | GRUU | RIM | abuckley@rim.com | Rel-7 | Maurice |  |  |  |
| 594 | 1.184.1 | Deleted - TR on GRUU |  | 219d? | 2005-11-14 A | 2006-09-14 A | 100% |  | 2005-11-14 | 2006-09-14 | 219d? |  | finish no earlier than 2006-09-14 | S2 | 1752h | 1752h | GRUU | RIM | abuckley@rim.com | Rel-7 | Maurice | SP-32 |  |  |
| 595 | 1.184.2 | Stage 1,2 of GRUU |  | 65d? | 2006-07-03 A | 2006-09-29 A | 100% |  | 2006-07-03 | 2006-09-29 | 65d? |  | start no earlier than 2006-07-03 | S1,S2 | 520h | 520h | GRUU | RIM | abuckley@rim.com | Rel-7 | Maurice |  |  |  |
| 596 | 1.184.3 | Stage 3 of GRUU |  | 271d? | 2006-06-02 A | 2007-06-15 A | 100% |  | 2006-06-02 | 2007-06-15 | 271d? |  | finish no earlier than 2007-06-15 | C1 | 2168h | 2168h | GRUU | CableLabs | Bernie McKibben | Rel-7 | Frederic |  |  |  |
| 597 | 1.185 | **Multimedia Telephony Service for IMS** |  | 357d? | 2006-02-01 A | 2007-06-15 A | 100% |  | 2006-02-01 | 2007-06-15 | 357d? |  |  | S1,C1,S4 | 8976h | 8976h | MTSI | Ericsson | peter.bleckert @ericsson.com | Rel-7 | Patrick |  |  |  |
| 598 | 1.185.1 | Stage 1 of MTSI |  | 173d? | 2006-02-01 A | 2006-09-29 A | 100% |  | 2006-02-01 | 2006-09-29 | 173d? |  | start no earlier than 2006-02-01 | S1 | 1384h | 1384h | MTSI-REQ | Ericsson | peter.bleckert @ericsson.com | Rel-7 | Alain |  |  |  |
| 599 | 1.185.2 | Stage 3 of MTSI |  | 330d? | 2006-03-10 A | 2007-06-15 A | 100% |  | 2006-03-10 | 2007-06-15 | 330d? |  | finish no earlier than 2007-06-15 | C1 | 2640h | 2640h | MTSI | Ericsson | christer.holmberg@ericsson.com | Rel-7 | Frederic |  |  |  |
| 600 | 1.185.3 | Media handling and interaction in MTSI |  | 262d? | 2006-03-15 A | 2007-03-15 A | 100% |  | 2006-03-15 | 2007-03-15 | 262d? |  | finish no earlier than 2007-03-15 | S4 | 2096h | 2096h | MTSI-MHI | Ericsson | olle.franceschi@ericsson.com | Rel-7 | Paolo |  |  |  |
| 601 | 1.185.4 | Deleted - duplicates UID7039 - IMS Multimedia Telephony Service | milestone | 0d? | 2007-06-15 A | 2007-06-15 A | 100% |  | 2007-06-15 | 2007-06-15 | 0d? |  | start no earlier than 2007-06-15 | S1 |  |  | MMTEL | Ericsson | peter.bleckert @ericsson.com | Rel-7 | Mike | SP-32 |  |  |
| 602 | 1.186 | Multimedia Telephony Service for IMS (MTSI) - UE Conformance Testing |  | 388d | 2007-09-19 A | 2009-03-13 | 80% | 77.6d | 2007-09-19 | 2009-03-13 | 388d | 260d | finish no earlier than 2009-03-13 | R5 | 624h | 624h | MTSI-UEConfTest | Ericsson, Motorola | Leif.Mattisson@ericsson.com, Jacob.John@motorola.com | Rel-7 | Ingbert |  |  |  |
| 603 | 1.187 | TISPAN requirements for Multimedia Telephony with PSTN/ISDN simulation services |  | 58d? | 2007-09-18 A | 2007-12-06 A | 100% |  | 2007-09-18 | 2007-12-06 | 58d? |  | start no earlier than 2007-09-18 | S1 | 464h | 464h | TMMTEL7 |  |  | Rel-7 |  |  | SP-37 |  |
| 604 | 1.188 | **Maintenance of TISPAN release 1 common IMS** |  | 58d? | 2007-09-18 A | 2007-12-06 A | 100% |  | 2007-09-18 | 2007-12-06 | 58d? |  |  | S2 | 1392h | 1392h | MCIMSTR1 | Ericsson | Raymond Forbes | Rel-7 | Alain |  | SP-38 | PCG-21 |
| 605 | 1.188.1 | SA1 aspects of MCIMSTR1 |  | 58d? | 2007-09-18 A | 2007-12-06 A | 100% |  | 2007-09-18 | 2007-12-06 | 58d? |  | finish no earlier than 2007-12-06 | S1 | 464h | 464h | MCIMSTR1-S1 | Telecom Italia | Marco De Luca | Rel-7 |  |  | SP-38 | PCG-21 |
| 606 | 1.188.2 | SA2 aspects of MCIMSTR1 |  | 58d? | 2007-09-18 A | 2007-12-06 A | 100% |  | 2007-09-18 | 2007-12-06 | 58d? |  | finish no earlier than 2007-12-06 | S2 | 464h | 464h | MCIMSTR1-S2 | Ericsson | Raymond Forbes | Rel-7 |  |  | SP-38 | PCG-21 |
| 607 | 1.189 | **PS domain and IMS impacts for supporting IMS Emergency calls** |  | 1760d? | 2000-09-18 A | 2007-06-15 A | 100% |  | 2000-09-18 | 2007-06-15 | 1760d? |  |  | S2,S1 | 44157h | 44157h | EMC1 | Siemens | Rainer Liebhart | Rel-7 | Maurice |  |  |  |
| 608 | 10.1.1 | Service Requirements for IP-based emergency calls |  | 985d | 2000-09-18 A | 2004-06-25 A | 100% |  | 2000-09-18 | 2004-06-25 | 985d |  | finish no earlier than 2004-06-25 | S1 | 7880h | 7880h | EMC1 | Siemens | Rainer Liebhart | Rel-7 |  |  |  |  |
| 609 | 1.189.2 | Study on Stage 2 for IMS-level solution |  | 668d? | 2003-02-26 A | 2005-09-16 A | 100% |  | 2003-02-26 | 2005-09-16 | 668d? |  | finish no earlier than 2005-09-16 | S2 | 5344h | 5344h | EMC1 | Siemens | Rainer Liebhart | Rel-7 |  |  |  |  |
| 610 | 1.189.3 | Study on Stage 2 for GPRS-level solution |  | 301d? | 2004-10-14 A | 2005-12-08 A | 100% |  | 2004-10-14 | 2005-12-08 | 301d? |  | finish no earlier than 2005-12-08 | S2 | 2408h | 2408h | EMC1 | Siemens | Rainer Liebhart | Rel-7 |  |  |  |  |
| 611 | 1.189.4 | Stage 2 Specification Phase - IMS-level |  | 200d? | 2005-09-05 A | 2006-06-09 A | 100% |  | 2005-09-05 | 2006-06-09 | 200d? |  | finish no earlier than 2006-06-09 | S2 | 1600h | 1600h | EMC1 | Siemens | Rainer Liebhart | Rel-7 |  |  |  |  |
| 612 | 1.189.5 | Deleted - Stage 2 Specification Phase - GPRS-level | milestone | 0d? | 2007-03-02 A | 2007-03-02 A | 100% |  | 2007-03-02 | 2007-03-02 | 0d? |  | start no earlier than 2007-03-02 | S2 |  |  | EMC1 | Siemens | Rainer Liebhart | Rel-7 |  | SP-32 |  |  |

Notes:
- 588: WID approved SA#28. WID updated SA#32
- 589: Text3: 23.816
- 590: Text3: 22.228, 23.228, 23.203
- 591: CT#32 approved WID / Text3: 23.218, 24.229
- 592: Text3: 32.260, 32.298, 32.299
- 593: SA#29 approved WID
- 594: Abandoned
- 595: SA#29 approved WID / Text3: 22.228, 23.228, 23.218, 24.229
- 596: CT#32 approved WID / Text3: 24.229
- 598: Text3: 22.173
- 599: Text3: 24.173
- 600: Text3: 26.114
- 601: Text3: 22.173
- 602: SR in RP-080862. UID_350047->350147. Linked UID_7038 (MTSI). RP#41: WID updated RP-070664=>RP-080605. Target completion 09/08=>03/09 / Text3: 34.123-1/2/3
- 603: Text3: 22.273 (EI 181 002 maintenance)
- 604: Text3: http://www.3gpp.org/specs/TISPAN-IMS-ansfer.htm
- 605: Text3: 22.173, 22.273
- 606: Text3: 23.406, 23.417, 23.508,23.509, 23.511
- 608: Text3: 22.976 (DB shows 04/2003 withdrawn Study on PS domain services and capabilities (az: belongs this really here ?!)
- 609: Text3: 23.867
- 610: Text3: 23.867
- 611: Text3: 23.167, 23.228, 23.060, 23.002, 23.271

| ID | WBS | Task | Type | Duration | Start | Finish | Complete | Baseline start | Baseline finish | Baseline duration | Constraint | Resources | Work | Actual work | Text1 | Text4 | Text5 | Text6 | Text3 | Text8 | Text12 | Text10 |
| --- | --- | --- | --- | --- | --- | --- | --- | --- | --- | --- | --- | --- | --- | --- | --- | --- | --- | --- | --- | --- | --- | --- |
| 613 | 10.1 | **Emergency Call Enhancements for IP& PS Based Calls – stage 3** |  | 375d | 2006-01-09 A | 2007-06-15 A | 100% | 2006-01-09 | 2007-06-15 | 375d |  | C1 | 12845h | 12845h | EMC1 | Ericsson | alf.heidermark@ericsson.com | Rel-7 |  |  |  |  |
| 614 | 10.1.2 | CT1 IMS aspects to support IMS Emergency sessions |  | 350.82d | 2006-01-09 A | 2007-06-15 A | 100% | 2006-01-09 | 2007-06-15 | 350.82d | finish no earlier than 2007-06-15 | C1 | 2806.57h | 2806.57h | EMC1 | Ericsson | alf.heidermark@ericsson.com | Rel-7 | 24.229 |  |  |  |
| 615 | 10.1.2 | Deleted - CT3 IMS aspects to support IMS Emergency sessions |  | 95d | 2006-05-08 A | 2006-09-15 A | 100% | 2006-05-08 | 2006-09-15 | 95d | finish no earlier than 2006-09-15 | C3 | 760h | 760h | EMC1 | Ericsson | alf.heidermark@ericsson.com | Rel-7 | 29.163 | Seung Don | CP-33 |  |
| 616 | 10.1.5 | Deleted - CT3 PS domain aspects to support IMS Emergency sessions |  | 95d | 2006-05-08 A | 2006-09-15 A | 100% | 2006-05-08 | 2006-09-15 | 95d | start no earlier than 2006-05-08 | C3 | 760h | 760h | EMC1 | Ericsson | alf.heidermark@ericsson.com | Rel-7 | 29.061 | Seung Don | CP-33 |  |
| 617 | 10.1.5 | CT1 PS domain aspects to support IMS Emergency sessions |  | 349.9d | 2006-01-09 A | 2007-06-15 A | 100% | 2006-01-09 | 2007-06-15 | 349.9d | finish no earlier than 2007-06-15 | C1 | 2799.2h | 2799.2h | EMC1 | Ericsson | alf.heidermark@ericsson.com | Rel-7 | 24.008, 24.234 |  |  |  |
| 618 | 10.1.5 | CT4 PS domain aspects to support IMS Emergency sessions |  | 365d | 2006-01-09 A | 2007-06-01 A | 100% | 2006-01-09 | 2007-06-01 | 365d | finish no earlier than 2007-06-01 | C4 | 2920h | 2920h | EMC1-GPRSc4 | Ericsson | alf.heidermark@ericsson.com | Rel-7 | 29.060 |  |  |  |
| 619 | 1.190 | IMS Support of Conferencing |  | 355d? | 2005-11-04 A | 2007-03-15 A | 100% | 2005-11-04 | 2007-03-15 | 355d? | finish no earlier than 2007-03-15 | C1 | 2840h | 2840h | IMSconf | Alcatel-Lucent | drage@alcatel-lucent.com | Rel-7 | 24.147, 24.229 | Frederic |  |  |
| 620 | 1.191 | Performance Characterization of VoIMS over HSDPA\EUL channels |  | 713d? | 2005-03-15 A | 2007-12-06 A | 100% | 2005-03-15 | 2007-12-06 | 713d? | finish no earlier than 2007-12-06 | S4 | 5704h | 5704h | VoIMS-PCVoIMS | Alcatel-Lucent | mcgowan@alcatel-lucent.com | Rel-7 | 26.935 | Paolo |  |  |
| 621 | 1.192 | **WLAN-UMTS Interworking Phase 2** |  | 371d? | 2004-01-05 A | 2005-06-07 A | 100% | 2004-01-05 | 2005-06-07 | 371d? |  | S1 | 3888h | 3888h | WLAN2 | Telenor | frederic.paint@telenor.com | Rel-7 | 33.234 (SP-36 SA3 CRs approved) | Michael |  |  |
| 622 | 1.192.1 | Stage 1 on Session Continuity |  | 115d? | 2004-01-05 A | 2004-06-11 A | 100% | 2004-01-05 | 2004-06-11 | 115d? | start no earlier than 2004-01-05 | S1 | 920h | 920h | WLAN-SC |  |  | Rel-7 | 22.234 |  |  | SP-24 |
| 623 | 1.192.2 | Stage 2 on Session Continuity: covered by SAE | milestone | 0d? | 2005-06-07 A | 2005-06-07 A | 100% | 2005-06-07 | 2005-06-07 | 0d? | finish no earlier than 2005-06-07 | S2 |  |  | WLAN-SC |  |  | Rel-7 |  |  |  |  |
| 624 | 1.193 | **WLAN Interworking – Private Network access from WLAN 3GPP IP Access** |  | 252d? | 2005-10-10 A | 2006-09-26 A | 100% | 2005-10-10 | 2006-09-26 | 252d? |  | S2,C1,C3,C4 | 8936h | 8936h | WLANPNA | NEC | Toshiyuki Tamura (tamurato@aj.jp.nec.com) | Rel-7 |  | Maurice |  |  |
| 625 | 1.193.1 | WLAN-PNA - Stage 2 |  | 185d? | 2005-10-10 A | 2006-06-23 A | 100% | 2005-10-10 | 2006-06-23 | 185d? | start no earlier than 2005-10-10 | S2 | 1480h | 1480h | WLANPNA-st2 | NEC | Toshiyuki Tamura (tamurato@aj.jp.nec.com) | Rel-7 | 23.234, 33.234 | Maurice |  |  |
| 626 | 1.193.2 | **WLAN-PNA - Stage 3** |  | 170d? | 2006-02-01 A | 2006-09-26 A | 100% | 2006-02-01 | 2006-09-26 | 170d? |  | C1,C3,C4 | 5440h | 5440h | WLANPNA-st3 | NEC | pierre-jean.muller@nectech.fr | Rel-7 |  | Frederic |  |  |
| 627 | 1.193.2.1 | CT1 aspets for WLAN-PNA |  | 170d? | 2006-02-01 A | 2006-09-26 A | 100% | 2006-02-01 | 2006-09-26 | 170d? | start no earlier than 2006-02-01 | C1 | 1360h | 1360h | WLANPNA-st3 | NEC | pierre-jean.muller@nectech.fr | Rel-7 | 24.234 | Frederic |  |  |
| 628 | 1.193.2.2 | CT3 aspets for WLAN-PNA |  | 170d? | 2006-02-01 A | 2006-09-26 A | 100% | 2006-02-01 | 2006-09-26 | 170d? | start no earlier than 2006-02-01 | C3 | 1360h | 1360h | WLANPNA-st3 | NEC | pierre-jean.muller@nectech.fr | Rel-7 | 29.161 | Frederic |  |  |
| 629 | 1.193.2.3 | Deleted - CT4 aspets for WLAN-PNA |  | 170d? | 2006-02-01 A | 2006-09-26 A | 100% | 2006-02-01 | 2006-09-26 | 170d? | start no earlier than 2006-02-01 | C4 | 1360h | 1360h | WLANPNA-st3 | NEC | pierre-jean.muller@nectech.fr | Rel-7 | 29.234 | Frederic | CP-32 |  |
| 630 | 1.194 | **Enhancements to support QoS provisioning over 3GPP/WLAN Interworking** |  | 520d? | 2005-03-14 A | 2007-03-09 A | 100% | 2005-03-14 | 2007-03-09 | 520d? |  | S2,C4,C1 | 8360h | 8360h | WLANQOS | Samsung | osok.song@samsung.com | Rel-7 |  | Maurice |  |  |
| 631 | 1.194.1 | Deleted - TR on support of QoS on WLAN |  | 232d? | 2005-03-14 A | 2006-01-31 A | 100% | 2005-03-14 | 2006-01-31 | 232d? | start no earlier than 2005-03-14 | S2 | 1856h | 1856h | WLANQOS | Samsung | osok.song@samsung.com | Rel-7 | 23.836 | Maurice | SP-32 |  |
| 632 | 1.194.2 | Stage 2 on support of QoS over 3GPP/WLAN interworking |  | 108d? | 2006-02-01 A | 2006-06-30 A | 100% | 2006-02-01 | 2006-06-30 | 108d? | start no earlier than 2006-02-01 | S2 | 864h | 864h | WLANQOS | Samsung | osok.song@samsung.com | Rel-7 | 23.234 | Maurice |  |  |
| 633 | 1.194.3 | Stage 3 CT4 on support of QoS over 3GPP/WLAN Interworking |  | 121d? | 2006-09-22 A | 2007-03-09 A | 100% | 2006-09-22 | 2007-03-09 | 121d? | finish no earlier than 2007-03-09 | C4 | 968h | 968h | WLANQOS | Huawei | zhang.peng@huawei.com | Rel-7 | 29.234, 23.008 | Kimmo |  |  |
| 634 | 1.194.4 | Stage 3 CT1 on support of QoS over 3GPP/WLAN Interworking |  | 64d? | 2006-09-04 A | 2006-11-30 A | 100% | 2006-09-04 | 2006-11-30 | 64d? | finish no earlier than 2006-11-30 | C1 | 512h | 512h | WLANQOS | Huawei | zhang.peng@huawei.com | Rel-7 | 24.234 | Frederic |  |  |
| 635 | 1.195 | **Location Services enhancements** |  | 906d? | 2004-06-28 A | 2007-12-17 A | 100% | 2004-06-28 | 2007-12-17 | 906d? |  | S1,S2,GP,C4,R2 | 46933.6h | 46933.6h | LCS3 |  |  | Rel-7 |  | Alain |  |  |
| 636 | 1.195.1 | Stage 2 for LCS3 (including IMS emergency location aspects) |  | 446d? | 2004-12-31 A | 2006-09-15 A | 100% | 2004-12-31 | 2006-09-15 | 446d? | finish no earlier than 2006-09-15 | S2 | 3568h | 3568h | LCS3 | SiRF | brodilitz@sirf.com | Rel-7 | 23.271 | Maurice |  |  |
| 637 | 1.195.2 | LCS Enhancements related to Location-Based Services |  | 695d? | 2005-01-03 A | 2007-08-31 A | 100% | 2005-01-03 | 2007-08-31 | 695d? | finish no earlier than 2007-08-31 | GP | 5560h | 5560h | LCS3-LBS | SiRF | kjudge@sirf.com | Rel-7 | 43.059, 44.031, 48.008, 49.031 | Paolo |  |  |
| 638 | 1.195.3 | CT4 aspects for LCS UEPos-LBS |  | 240d? | 2006-01-02 A | 2006-12-01 A | 100% | 2006-01-02 | 2006-12-01 | 240d? | finish no earlier than 2006-12-01 | C4 | 1920h | 1920h | LCS3-UEPos-LBS | SiRF | brodilitz@sirf.com | Rel-7 | 24.030, 24.080, 29.002 | Kimmo |  |  |
| 639 | 1.195.4 | UE positioning - Velocity |  | 394d? | 2005-03-15 A | 2006-09-15 A | 100% | 2005-03-15 | 2006-09-15 | 394d? | finish no earlier than 2006-09-15 | R2 | 3152h | 3152h | LCS3-UEPos-Velocity | SiRF | BRodilitz@SiRF.com | Rel-7 | 25.305, 25.331, 25.410, 25.413, 25.453 | Joern |  |  |
| 640 | 1.195.5 | Inclusion of Uplink TDOA UE positioning method in the UTRAN specifications |  | 849d? | 2004-09-15 A | 2007-12-17 A | 100% | 2004-09-15 | 2007-12-17 | 849d? | finish no earlier than 2007-12-17 | R2 | 6792h | 6792h | LCS3-UEPos-UTDOA | TruePosition | rlgross@trueposition.com | Rel-7 | 25.305, 25.453 | Joern |  |  |

Notes:
- 615: Cancelled for Rel-7 and there is now corresponding Rel-8 WI
- 616: Cancelled for Rel-7 and there is now corresponding Rel-8 WI
- 619: CT#35 revised WID
- 621: Created at TSG#27 by A. Sultan because of WLAN items belonging to Rel-7. az: This WI is an extension of the WLAN-UMTS Interworking Rel-6 (No new WID)
- 625: Approved at SA#29
- 626: Approved at CT#29
- 627: Approved at CT#29
- 628: Approved at CT#29
- 629: CT4#31; no impacts identified, therefore completed. CP-32 stopped
- 630: Moved from FS section Feb 06. SP-30 updated WID
- 631: SP-32 stopped
- 632: SP-30 updated WID
- 633: CP-32 approved WID
- 634: CP-32 approved WID
- 636: SA#27 approved WID.
- 639: Completed Sept 2006; SR in RP-060459
- 640: Completed Nov 2007; SR in RP-070797

| ID | WBS | Task | Type | Duration | Start | Finish | Complete | Baseline start | Baseline finish | Baseline duration | Constraint | Resources | Work | Actual work | Text1 | Text4 | Text5 | Text6 | Text8 | Text12 |
| --- | --- | --- | --- | --- | --- | --- | --- | --- | --- | --- | --- | --- | --- | --- | --- | --- | --- | --- | --- | --- |
| 641 | 1.195.6 | **LCS for 3GPP Interworking WLAN** |  | 700d? | 2004-06-28 A | 2007-03-02 A | 100% | 2004-06-28 | 2007-03-02 | 700d? |  | S1 | 11901.6h | 11901.6h | LCS3-IWLAN | Telcordia | Mike Loushine | Rel-7 | Alain |  |
| 642 | 1.195.6.1 | FS on 3GPP system to WLAN Interworking with LCS |  | 512.7d? | 2004-06-28 A | 2006-06-30 A | 100% | 2004-06-28 | 2006-06-30 | 512.7d? | finish no earlier than 2005-09-29 | S1 | 4101.6h | 4101.6h | LCS3-IWLAN-FSs1 | Telcordia | Mike Loushine, Vijay Varma | Rel-7 | Alain |  |
| 643 | 1.195.6.2 | Delete - Study of work on an LCS architecture for I-WLAN. |  | 180d? | 2006-06-26 A | 2007-03-02 A | 100% | 2006-06-26 | 2007-03-02 | 180d? | finish no earlier than 2007-03-02 | S2 | 1440h | 1440h | LCS3-IWLAN-FSs2 | LG Electronics | dhshim@lge.com ; phede@lge.com | Rel-7 | Maurice | SP-35 |
| 644 | 1.195.6.3 | Stage 2 for LCS architecture for I-WLAN |  | 95d? | 2006-10-23 A | 2007-03-02 A | 100% | 2006-10-23 | 2007-03-02 | 95d? | finish no earlier than 2007-03-02 | S2 | 760h | 760h | LCS3-IWLAN | LG Electronics | dhshim@lge.com ; phede@lge.com | Rel-7 | Maurice |  |
| 645 | 1.195.7 | Deleted - UE positioning Rel-7 |  | 849d? | 2004-09-15 A | 2007-12-17 A | 100% | 2004-09-15 | 2007-12-17 | 849d? |  | RP | 6792h | 6792h | LCS3-UEpos |  |  | Rel-7 |  | RP-38 |
| 646 | 1.195.8 | Deleted - RAN2 aspects for LBS | milestone | 0d? | 2005-06-15 A | 2005-06-15 A | 100% | 2005-06-15 | 2005-06-15 | 0d? | start no earlier than 2005-06-15 | R2 |  |  | LCS3-UEPos-LBS | SiRF | BRodilitz@SiRF.com | Rel-7 | MCC_RAN | RP-31 |
| 647 | 1.196 | **MBMS Enhancements** |  | 625d? | 2005-07-11 A | 2007-11-30 A | 100% | 2005-07-11 | 2007-11-30 | 625d? |  | S1 | 10844.6h | 10844.6h | MBMSE | China Mobile | liuhongyfw@chinamobile.com | Rel-7 | Mike |  |
| 648 | 1.196.1 | Stage 1 of MBMSE |  | 109d? | 2005-07-11 A | 2005-12-08 A | 100% | 2005-07-11 | 2005-12-08 | 109d? | finish no earlier than 2005-12-08 | S1,R1,C3 | 872h | 872h | MBMSE | China Mobile | liuhongyfw@chinamobile.com | Rel-7 | Mike |  |
| 649 | 1.196.2 | MBMS FDD Physical layer Enhancements |  | 117.29d? | 2006-12-15 A | 2007-06-04 A | 100% | 2006-12-15 | 2007-06-04 | 117.29d? | finish no earlier than 2007-06-04 | R1 | 938.32h | 938.32h | MBMSE-RANPhysFDD | Ericsson | Lars.Lindbom@ericsson.com | Rel-7 | Patrick |  |
| 650 | 1.196.3 | MBMS TDD Physical layer Enhancements |  | 117.29d? | 2006-12-15 A | 2007-06-04 A | 100% | 2006-12-15 | 2007-06-04 | 117.29d? | finish no earlier than 2007-06-04 | R1 | 938.32h | 938.32h | MBMSE-RANPhysTDD | IPWireless | Nicholas Anderson | Rel-7 | Patrick |  |
| 651 | 1.196.4 | MBMS Low Chip Rate TDD Physical Layer Enhancement |  | 127d? | 2007-03-16 A | 2007-09-10 A | 100% | 2007-03-16 | 2007-09-10 | 127d? | finish no earlier than 2007-09-10 | R1 | 1016h | 1016h | MBMSE-RANPhysLCRTDD | RITT | Lin Hui | Rel-7 | Patrick |  |
| 652 | 1.196.5 | MBMS Mz interface |  | 260d? | 2006-12-04 A | 2007-11-30 A | 100% | 2006-12-04 | 2007-11-30 | 260d? | finish no earlier than 2007-05-11 | C3 | 2080h | 2080h | MBMSMz | Huawei | Deng Tingting (ttdeng@huawei.com) | Rel-7 | Seung Don |  |
| 653 | 1.197 | MBMS User Service Extensions |  | 392d? | 2005-12-07 A | 2007-06-07 A | 100% | 2005-12-07 | 2007-06-07 | 392d? | finish no earlier than 2007-06-07 | S4 | 3136h | 3136h | MBMSUSE | Ericsson | Thorsten.Lohmar@ericsson.com | Rel-7 | Paolo |  |
| 654 | 1.198 | **Advanced Global Navigation Satellite System (A-GNSS) concept** |  | 830d? | 2004-06-28 A | 2007-08-31 A | 100% | 2004-06-28 | 2007-08-31 | 830d? |  | S1,GP,R2 | 9553.6h | 9553.6h | LCS3-AGNSS | Alcatel | Michel.monnerat@space.alcatel.fr | Rel-7 | Michael |  |
| 655 | 1.198.1 | Towards A-GNSS Concept |  | 811.2d? | 2004-06-28 A | 2007-08-31 A | 100% | 2004-06-28 | 2007-08-31 | 811.2d? | finish no earlier than 2007-08-31 | GP | 6489.6h | 6489.6h | AGNSS-GP | Alcatel | richard.couty@space.alcatel.fr | Rel-7 | Paolo |  |
| 656 | 1.198.2 | Global Navigation Satellite System (GNSS) in UTRAN |  | 383d? | 2005-12-15 A | 2007-06-04 A | 100% | 2005-12-15 | 2007-06-04 | 383d? | finish no earlier than 2007-06-04 | R2 | 3064h | 3064h | LCS3-GNSS-UTRAN | France Telecom | alain.abinakhoul@francetelecom.com | Rel-7 | MCC_RAN |  |
| 657 | 1.198.3 | Deleted - Towards A-GNSS Concept | milestone | 0d? | 2007-02-16 A | 2007-02-16 A | 100% | 2007-02-16 | 2007-02-16 | 0d? | start no earlier than 2007-02-16 | S1 |  |  | GNSS | Alcatel | richard.couty@space.alcatel.fr | Rel-7 | Paolo | SP-34 |
| 658 | 1.199 | A-GPS Minimum Performance |  | 351d? | 2006-04-28 A | 2007-08-31 A | 100% | 2006-04-28 | 2007-08-31 | 351d? | finish no earlier than 2007-08-31 | GP | 2808h | 2808h | GAGR | Spirent | richard.catmur@spirentcom.com | Rel-7 | Paolo |  |
| 659 | 1.200 | **USSD message delivery and transfer to USIM** |  | 376d? | 2004-03-05 A | 2005-08-12 A | 100% | 2004-03-05 | 2005-08-12 | 376d? |  | S1,C6 | 2762.4h | 2762.4h | USSD-USIM | Axalto | Christophe Dubois (cdubois@axalto.com) | Rel-7 | Michael |  |
| 660 | 1.200.1 | Stage 1 |  | 152d? | 2004-03-18 A | 2004-10-15 A | 100% | 2004-03-18 | 2004-10-15 | 152d? | start no earlier than 2004-03-18 | S1 | 1216h | 1216h | USSD-USIM | Axalto | Christophe Dubois (cdubois@axalto.com) | Rel-7 | Michael |  |
| 661 | 1.200.2 | Alignment with requirements regarding USSD usage |  | 193.3d? | 2004-03-05 A | 2005-08-12 A | 100% | 2004-03-05 | 2005-08-12 | 193.3d? | finish no earlier than 2005-08-12 | C6 | 1546.4h | 1546.4h | USSD-USIM | Axalto | Christophe Dubois (cdubois@axalto.com) | Rel-7 | Xavier |  |
| 662 | 1.201 | **Combinational Services** |  | 296d? | 2005-01-17 A | 2006-03-06 A | 100% | 2005-01-17 | 2006-03-06 | 296d? |  | S1,S2,C1,S4 | 5176h | 5176h | CSICS | TeliaSonera | Robert.Frank@teliasonera.com | Rel-7 | Michael |  |
| 663 | 1.201.1 | Stage 1 for CSICS |  | 104d? | 2005-01-17 A | 2005-06-09 A | 100% | 2005-01-17 | 2005-06-09 | 104d? | start no earlier than 2005-01-17 | S1 | 832h | 832h | CSICS | TeliaSonera | Robert.Frank@teliasonera.com | Rel-7 | Michael |  |
| 664 | 1.201.2 | Stage 2 for CSICS |  | 130d? | 2005-01-17 A | 2005-07-15 A | 100% | 2005-01-17 | 2005-07-15 | 130d? | start no earlier than 2005-01-17 | S2 | 1040h | 1040h | CSICS | TeliaSonera | Robert.Frank@teliasonera.com | Rel-7 | Maurice |  |
| 665 | 1.201.3 | Stage 3 for CSICS CN aspects |  | 221d? | 2005-05-02 A | 2006-03-06 A | 100% | 2005-05-02 | 2006-03-06 | 221d? | finish no earlier than 2006-03-06 | C1 | 1768h | 1768h | CSICS | Vodafone | Peter Dawes | Rel-7 | Frederic |  |
| 666 | 1.201.4 | Stage 3 for codec aspects |  | 192d? | 2005-03-15 A | 2005-12-07 A | 100% | 2005-03-15 | 2005-12-07 | 192d? | finish no earlier than 2005-12-07 | S4 | 1536h | 1536h | CSICS-Codec | Ericsson | Per.Frojdh@ericsson.com | Rel-7 | Paolo |  |

Notes:
- 641: Text3: 22.935
- 642: Text3: 22.935
- 643: Updated WID at SA#32 to change "stage 2" to "study" , duplicated UID 320017 deleted. SA#33 TR for Information. extension Granted for Rel-7 until 03/07. Last mention SP-35 Mar 2007 (abandoned ?) / Text3: 23.837
- 644: WID at SA#55 / Text3: 23.234, 23.271, 23.167
- 646: Text3: 25.305, 25.331, 25.410, 25.413, 25.453
- 648: Structure created by MCC to include RAN aspects under SA1 Feature / Text3: 22.146, 22.246, 22.228
- 649: Completed May 2007; SR in RP-070290 / Text3: 25.211, 25.212, 25.213, 25.101, 25.104, 25.331, 25.433, 25.346, 25.306
- 650: Completed May 2007; SR in RP-070291 / Text3: 25.346, 25.221, 25.222, 25.223, 25.224, 25.306, 25.331, 25.402, 25.433, 25.102, 25.105, 25.123
- 651: Completed May 2007; SR in RP-070292 / Text3: 25.346, 25.221, 25.222, 25.223, 25.224, 25.306, 25.331, 25.402, 25.433, 25.102, 25.105, 25.123
- 652: Text3: 29.061
- 653: Text3: 26.346, 26.946
- 655: GP#36 completed
- 656: Completed Sept 2006; SR in RP-070482 / Text3: 25.305, 25.331, 25.306, 25.413, 25.423, 25.433, 25.453, 25.302, 25.215, 25.401, 25.402, 25.450, 25.452
- 658: Text3: 45.005, 51.010
- 660: Text3: 22.090
- 663: Text3: 22.279
- 664: Text3: 23.279
- 665: Text3: 24.879, 24.279, 24.229, 24.008
- 666: Text3: 26.141, 26.235

| ID | WBS | Task | Type | Duration | Start | Finish | Complete | Baseline start | Baseline finish | Baseline duration | Constraint | Resources | Work | Actual work | Text1 | Text4 | Text5 | Text6 | Text8 | Text3 | Text12 |
| --- | --- | --- | --- | --- | --- | --- | --- | --- | --- | --- | --- | --- | --- | --- | --- | --- | --- | --- | --- | --- | --- |
| 667 | 1.202 | **CAMEL Trunk Triggers** |  | 251d? | 2004-12-17 A | 2005-12-05 A | 100% | 2004-12-17 | 2005-12-05 | 251d? |  | S1,C4 | 6024h | 6024h | TTCAMEL | Nortel | Amar Deol (deola@nortelnetworks.com) | Rel-7 | Michael |  |  |
| 668 | 1.202.1 | Stage 1 for CAMEL Trunk Triggers |  | 251d? | 2004-12-17 A | 2005-12-05 A | 100% | 2004-12-17 | 2005-12-05 | 251d? |  | S1 | 2008h | 2008h | TTCAMEL | Nortel | Amar Deol (deola@nortelnetworks.com) | Rel-7 | Michael | 22.078 |  |
| 669 | 1.202.2 | CAMEL Trunk Originated Trigger Detection Points |  | 251d? | 2004-12-17 A | 2005-12-05 A | 100% | 2004-12-17 | 2005-12-05 | 251d? | start no earlier than 2004-12-17 | C4 | 2008h | 2008h | CamelR7 | Nortel | David Hutton (dhutton@nortel.com) | Rel-7 | Kimmo |  |  |
| 670 | 1.203 | **IMS Service Brokering enhancements** |  | 69d? | 2005-12-07 A | 2006-03-13 A | 100% | 2005-12-07 | 2006-03-13 | 69d? |  | S1 | 1104h | 1104h | ISB | Telcordia | jbakker@telcordia.com | Rel-7 | Alain | 22.228 |  |
| 671 | 1.203.1 | Stage 1 for ISB |  | 69d? | 2005-12-07 A | 2006-03-13 A | 100% | 2005-12-07 | 2006-03-13 | 69d? | finish no earlier than 2006-03-13 | S1 | 552h | 552h | ISB-s1 | Telcordia | jbakker@telcordia.com | Rel-7 | Alain | 22.228 |  |
| 672 | 1.204 | **Enhancements of VGCS for public authority officials** |  | 731d? | 2004-08-27 A | 2007-06-15 A | 100% | 2004-08-27 | 2007-06-15 | 731d? |  | S1 | 25920h | 25920h | EVGCS |  |  | Rel-7 | Frederic | 43.068, 44.068, 24.008, 29.002 |  |
| 673 | 1.204.1 | Stage 1 | milestone | 0d? | 2004-08-27 A | 2004-08-27 A | 100% | 2004-08-27 | 2004-08-27 | 0d? | finish no earlier than 2004-08-27 | S1 |  |  | EVGCS | Siemens | joerg.swetina@SIEMENS.COM | Rel-7 | Michael | 42.068, 43.068 |  |
| 674 | 1.204.2 | **Architecture and protocol aspects** |  | 731d? | 2004-08-27 A | 2007-06-15 A | 100% | 2004-08-27 | 2007-06-15 | 731d? |  | C1 | 14904h | 14904h | EVGCS | Siemens | Robert Zaus | Rel-7 |  | 43.068, 44.068 |  |
| 675 | 1.204.2.1 | CT1 aspects of EVGCS |  | 731d? | 2004-08-27 A | 2007-06-15 A | 100% | 2004-08-27 | 2007-06-15 | 731d? | finish no earlier than 2006-09-15 | C1 | 5848h | 5848h | EVGCS | Siemens |  | Rel-7 |  | 43.068, 44.068, 24.008 |  |
| 676 | 1.204.2.2 | CT4 aspects of EVGCS |  | 401d? | 2004-08-27 A | 2006-03-10 A | 100% | 2004-08-27 | 2006-03-10 | 401d? | finish no earlier than 2006-03-10 | C4 | 3208h | 3208h | EVGCS-St23-c4 | Siemens |  | Rel-7 |  | 29.002 |  |
| 677 | 1.204.3 | GERAN2 aspects |  | 646d? | 2004-08-27 A | 2007-02-16 A | 100% | 2004-08-27 | 2007-02-16 | 646d? | finish no earlier than 2007-02-16 | G2 | 5168h | 5168h | EVGCS | Siemens | kenneth.isaacs@roke.co.uk | Rel-7 | Gert |  |  |
| 678 | 1.205 | **Improvements of VGCS for parallel use of services** |  | 523d? | 2005-03-15 A | 2007-03-15 A | 100% | 2005-03-15 | 2007-03-15 | 523d? |  | S1 | 12230.2h | 12230.2h | IVGCS |  |  | Rel-7 |  |  |  |
| 679 | 1.205.1 | Service Requirements for VGCS improvements |  | 62d? | 2005-03-15 A | 2005-06-08 A | 100% | 2005-03-15 | 2005-06-08 | 62d? | finish no earlier than 2005-06-08 | S1 | 496h | 496h | IVGCS | T-Mobile | kurt.bischinger@t-mobile.at | Rel-7 | Michael | 42.068 |  |
| 680 | 1.205.2 | Stage 2 modifications for VGCS improvements |  | 335d? | 2005-12-01 A | 2007-03-14 A | 100% | 2005-12-01 | 2007-03-14 | 335d? | start no earlier than 2005-12-01 | C1 | 2680h | 2680h | IVGCS | T-Mobile | kurt.bischinger@t-mobile.at | Rel-7 |  | 43.068 |  |
| 681 | 1.205.3 | **Protocol aspects** |  | 336d? | 2005-12-01 A | 2007-03-15 A | 100% | 2005-12-01 | 2007-03-15 | 336d? |  | C1 | 5376h | 5376h | IVGCS | T-Mobile | Dieter Jacobsohn | Rel-7 |  | 44.068 |  |
| 682 | 1.205.3.1 | CT1 aspects of IVGCS |  | 336d? | 2005-12-01 A | 2007-03-15 A | 100% | 2005-12-01 | 2007-03-15 | 336d? | finish no earlier than 2007-03-15 | C1 | 2688h | 2688h | IVGCS | T-Mobile |  | Rel-7 |  | 43.068, 44.068 |  |
| 683 | 1.205.3.2 | Deleted - CT4 aspects of IVGCS | milestone | 0d? | 2007-03-09 A | 2007-03-09 A | 100% | 2007-03-09 | 2007-03-09 | 0d? | finish no earlier than 2007-03-09 | C4 |  |  | IVGCS-St3-c4 | T-mobile |  | Rel-7 |  | 29.002 | CP-35 |
| 684 | 1.206 | **OSA Rel-7** |  | 584d? | 2005-03-15 A | 2007-06-08 A | 100% | 2005-03-15 | 2007-06-08 | 584d? |  | S1,C5 | 17920h | 17920h | OSA7 | AePONA | eamonn.murray@aepona.com | Rel-7 | Michael |  |  |
| 685 | 1.206.1 | Service Requirements for OSA Service Broker |  | 62d? | 2005-03-15 A | 2005-06-08 A | 100% | 2005-03-15 | 2005-06-08 | 62d? | finish no earlier than 2005-06-08 | S1 | 496h | 496h | OSA7-SB | AePONA | eamonn.murray@aepona.com | Rel-7 | Michael | 22.127 |  |
| 686 | 1.206.2 | Stage 2 OSA API Service Brokering |  | 156d? | 2006-04-28 A | 2006-12-01 A | 100% | 2006-04-28 | 2006-12-01 | 156d? |  | C5 | 1248h | 1248h | OSA7-SB | AePONA | damian.oneill@aepona.com | Rel-7 | Adrian | 23.198 |  |
| 687 | 1.206.3 | Stage 3 OSA API Service Brokering |  | 156d? | 2006-04-28 A | 2006-12-01 A | 100% | 2006-04-28 | 2006-12-01 | 156d? | finish no earlier than 2006-12-01 | C5 | 1248h | 1248h | OSA7-SB | AePONA | damian.oneill@aepona.com | Rel-7 |  | 29.198-16 |  |
| 688 | 1.206.4 | **OSA Stage 2/3 enhancements** |  | 291d? | 2006-04-28 A | 2007-06-08 A | 100% | 2006-04-28 | 2007-06-08 | 291d? |  | C5 | 10256h | 10256h | OSA7 | AePONA | damian.oneill@aepona.com | Rel-7 | Adrian | 29.198/9, 23.198 |  |
| 689 | 1.206.4.1 | Parlay X Message Broadcast Web Service |  | 156d? | 2006-04-28 A | 2006-12-01 A | 100% | 2006-04-28 | 2006-12-01 | 156d? | finish no earlier than 2006-12-01 | C5 | 1248h | 1248h | OSA7 | ETRI |  | Rel-7 |  | 29.199-15, 23.198 |  |
| 690 | 1.206.4.2 | Parlay X Geocoding Web Service |  | 156d? | 2006-04-28 A | 2006-12-01 A | 100% | 2006-04-28 | 2006-12-01 | 156d? | finish no earlier than 2006-12-01 | C5 | 1248h | 1248h | OSA7 | ETRI |  | Rel-7 |  | 29.199-16, 23.198 |  |
| 691 | 1.206.4.3 | Parlay X Application driven QoS Web Service |  | 226d? | 2006-04-28 A | 2007-03-09 A | 100% | 2006-04-28 | 2007-03-09 | 226d? | finish no earlier than 2007-03-09 | C5 | 1808h | 1808h | OSA7 | BT |  | Rel-7 |  | 29.199-17, 23.198 |  |
| 692 | 1.206.4.4 | Parlay-X Device Capabilities and Configuration |  | 162d? | 2006-10-26 A | 2007-06-08 A | 100% | 2006-10-26 | 2007-06-08 | 162d? | finish no earlier than 2007-06-09 | C5 | 1296h | 1296h | OSA7 | Telenor |  | Rel-7 |  | 29.199-18, 23.198 |  |
| 693 | 1.206.4.5 | Parlay-X Multimedia Streaming Session Management Web Service |  | 97d? | 2006-10-26 A | 2007-03-09 A | 100% | 2006-10-26 | 2007-03-09 | 97d? | start no earlier than 2006-10-26 | C5 | 776h | 776h | OSA7 | Telenor |  | Rel-7 |  | 29.199-19, 23.198 |  |
| 694 | 1.206.4.6 | Parlay-X Multimedia Multicast Control Web Service |  | 97d? | 2006-10-26 A | 2007-03-09 A | 100% | 2006-10-26 | 2007-03-09 | 97d? | start no earlier than 2006-10-26 | C5 | 776h | 776h | OSA7 | ETRI |  | Rel-7 |  | 29.199-20, 23.198 |  |
| 695 | 1.206.4.7 | OSA API Conference Call Control SCF |  | 97d? | 2006-10-26 A | 2007-03-09 A | 100% | 2006-10-26 | 2007-03-09 | 97d? | start no earlier than 2006-10-26 | C5 | 776h | 776h | OSA7 | Ericsson |  | Rel-7 |  | 29.198-04-5, 23.198 |  |

Notes:
- 670: No CR submitted in rel-8 (according to CR database).
- 671: No Rel-8 changes
- 679: "completeed" as from Chris S' e-mail
- 680: Updated by CT1 chair
- 681: Previous name (before CT32) was Architecture and protocol aspects
- 682: end date updated by CT1-chairman after CT#33
- 683: CT4#33 stage 2 solution is still open. ...
- 685: az: WID URL corrected
- 688: CT#34: WID updated. Completion 12/06 =>03/07

| ID | WBS | Task | Type | Duration | Start | Finish | Complete | Baseline start | Baseline finish | Baseline duration | Constraint | Resources | Work | Actual work | Text1 | Text4 | Text5 | Text6 | Text8 | Text3 | Text12 |
| --- | --- | --- | --- | --- | --- | --- | --- | --- | --- | --- | --- | --- | --- | --- | --- | --- | --- | --- | --- | --- | --- |
| 696 | 1.207 | **Selective Disabling of UE Capabilities** |  | 624.36d? | 2005-01-24 A | 2007-06-15 A | 100% | 2005-01-24 | 2007-06-15 | 624.36d? |  | S1,S2,C1 | 12351.7h | 12351.7h | SDoUE | Motorola | Nigel.Barnes@motorola.com | Rel-7 | Michael |  |  |
| 697 | 1.207.1 | Stage 1 of SDoUE |  | 393.6d? | 2005-01-24 A | 2006-12-08 A | 100% | 2005-01-24 | 2006-12-08 | 393.6d? | finish no earlier than 2006-12-08 | S1 | 3148.8h | 3148.8h | SDoUE-CR | Motorola | Nigel.Barnes@motorola.com | Rel-7 | Michael | 22.011 |  |
| 698 | 1.207.2 | Deleted - TR on different possible architectures |  | 195d? | 2005-03-21 A | 2005-12-16 A | 100% | 2005-03-21 | 2005-12-16 | 195d? | finish no earlier than 2005-12-16 | S2 | 1560h | 1560h | SDoUE-FS | Vodafone | Gavin.Wong@vodafone.com | Rel-7 | Maurice | 23.805 abandonned at SP-30; descendant C1 24.305 | SP-30 |
| 699 | 1.207.3 | Stage 3 of SDoUE |  | 331d? | 2006-03-10 A | 2007-06-15 A | 100% | 2006-03-10 | 2007-06-15 | 331d? | finish no earlier than 2007-06-15 | C1 | 2648h | 2648h | SDoUE | Ericsson | christian.herrero@ericsson.com | Rel-7 | Frederic | 24.305 |  |
| 700 | 1.208 | **Network selection enhancements (NSP)** |  | 328d? | 2006-03-15 A | 2007-06-15 A | 100% | 2006-03-15 | 2007-06-15 | 328d? |  | S1 | 6320h | 6320h | NSP-CR | O2 | chris.friel@o2.com | Rel-7 | Michael | 22.101, 22.011, 23.122, 24.008, 25.304, 31.102, 45.008 |  |
| 701 | 1.208.1 | Stage 1 of NSP |  | 191d? | 2006-03-15 A | 2006-12-06 A | 100% | 2006-03-15 | 2006-12-06 | 191d? | start no earlier than 2006-03-15 | S1 | 1528h | 1528h | NSP-TS | O2 | chris.friel@o2.com | Rel-7 | Michael | 22.101, 22.011, 23.122, 24.008, 25.304, 31.102, 45.008 |  |
| 702 | 1.208.2 | Procedural aspects of NSP |  | 271d? | 2006-06-02 A | 2007-06-15 A | 100% | 2006-06-02 | 2007-06-15 | 271d? | finish no earlier than 2007-06-15 | C1 | 2168h | 2168h | NSP-CR | Motorola | Andrew Howell | Rel-7 | Frederic | 23.122, 24.008, 31.102 |  |
| 703 | 1.209 | Network selection enhancements (NSP) - UE Conformance Testing |  | 396d? | 2007-06-01 A | 2008-12-05 A | 100% | 2007-06-01 | 2008-12-05 | 396d? | finish no earlier than 2008-12-05 | R5 | 3168h | 3168h | NSP-CR_UEConTest | Nokia | jarkko.hellsten@nokia.com | Rel-7 | Ingbert | 34.108, 34.123-1, 34.123-2, 34.123-3 |  |
| 704 | 1.210 | **Access Class Barring and Overload Protection** |  | 650d? | 2004-03-15 A | 2006-09-08 A | 100% | 2004-03-15 | 2006-09-08 | 650d? |  | S2,C1 | 3568h | 3568h | ACBOP | Vodafone | Chris Pudney | Rel-7 | Maurice | 23.898 |  |
| 705 | 1.210.1 | TR on Stage 2 |  | 274d? | 2004-03-15 A | 2005-03-31 A | 100% | 2004-03-15 | 2005-03-31 | 274d? | finish no earlier than 2005-03-31 | S2 | 2192h | 2192h | ACBOP | NTT DoCoMo | Jean-Jacques Davidian (davidian@docomo.fr) | Rel-7 |  | 23.898 |  |
| 706 | 1.210.2 | Stage 3 CN aspects of ACBOP |  | 172d? | 2005-06-06 A | 2006-01-31 A | 100% | 2005-06-06 | 2006-01-31 | 172d? | start no earlier than 2005-06-06 | C1 | 1376h | 1376h | ACBOP |  |  | Rel-7 |  | 24.008 |  |
| 707 | 1.210.3 | Deleted - Potential impact on Iu interface Overload functionality | milestone | 0d? | 2004-03-15 A | 2004-03-15 A | 100% | 2004-03-15 | 2004-03-15 | 0d? | finish no earlier than 2004-03-15 | RP |  |  | ACBOP |  |  | Rel-7 |  | 25.413 | RP-25 |
| 708 | 1.210.4 | Deleted - Extra ACBOP information in RAN | milestone | 0d? | 2004-03-15 A | 2004-03-15 A | 100% | 2004-03-15 | 2004-03-15 | 0d? | finish no earlier than 2004-03-15 | RP |  |  | ACBOP |  |  | Rel-7 |  | 25.331 | RP-25 |
| 709 | 1.210.5 | Deleted - Extra ACBOP information in GERAN | milestone | 0d? | 2006-09-08 A | 2006-09-08 A | 100% | 2006-09-08 | 2006-09-08 | 0d? | start no earlier than 2006-09-08 | GP |  |  | ACBOP |  |  | Rel-7 | Gert | 44.018 | RP-33 |
| 710 | 1.211 | **System enhancements for fixed broadband access to IMS** |  | 876d? | 2003-11-05 A | 2007-03-15 A | 100% | 2003-11-05 | 2007-03-15 | 876d? |  | S2,S3,S5,C1,C3,C4 | 36656h | 36656h | FBI |  |  | Rel-7 | Maurice |  |  |
| 711 | 1.211.1 | **TISPAN Rel 1 related aspects** |  | 873d? | 2003-11-05 A | 2007-03-09 A | 100% | 2003-11-05 | 2007-03-09 | 873d? |  | S2 | 31568h | 31568h | FBI-TIS1 |  |  | Rel-7 |  |  |  |
| 712 | 1.211.1.1 | Stage 2 of FBI for TISPAN R1 |  | 365d? | 2004-10-14 A | 2006-03-08 A | 100% | 2004-10-14 | 2006-03-08 | 365d? | start no earlier than 2004-10-14 | S2 | 2920h | 2920h | FBI-TIS1 |  |  | Rel-7 | Maurice |  |  |
| 713 | 1.211.1.2 | **Protocol impact of FBI for TISPAN R1** |  | 873d? | 2003-11-05 A | 2007-03-09 A | 100% | 2003-11-05 | 2007-03-09 | 873d? |  | C1 | 20720h | 20720h | FBI-TIS1 | Siemens | Peter Leis | Rel-7 | Frederic |  |  |
| 714 | 1.211.1.2.1 | CT1 aspects of FBI for TISPAN R1 |  | 802d? | 2003-11-05 A | 2006-11-30 A | 100% | 2003-11-05 | 2006-11-30 | 802d? | finish no earlier than 2006-11-30 | C1 | 6416h | 6416h | FBI-TIS1 | Siemens | Peter Leis | Rel-7 | Andrijana | 24.819, 24.229 |  |
| 715 | 1.211.1.2.2 | CT3 aspects of FBI for TISPAN R1 |  | 808d? | 2003-11-05 A | 2006-12-08 A | 100% | 2003-11-05 | 2006-12-08 | 808d? | finish no earlier than 2006-12-08 | C3 | 6464h | 6464h | FBI-TIS1 | Siemens | Peter Leis | Rel-7 | Andrijana | 29.163, 29.209 |  |
| 716 | 1.211.1.2.3 | CT4 aspects of FBI for TISPAN R1 |  | 301d? | 2006-01-13 A | 2007-03-09 A | 100% | 2006-01-13 | 2007-03-09 | 301d? | finish no earlier than 2007-03-09 | C4 | 2408h | 2408h | FBI-TIS1-st3-c4 | Siemens | Peter Leis | Rel-7 | Andrijana | 29.229 |  |
| 717 | 1.211.1.3 | Security Enhancements for FBI |  | 118d? | 2005-06-28 A | 2005-12-08 A | 100% | 2005-06-28 | 2005-12-08 | 118d? | start no earlier than 2005-06-28 | S3 | 944h | 944h | FBI-ISE | Ericsson | Bengt.Sahlin@ericsson.com | Rel-7 | Dionisio | 33.203 |  |
| 718 | 1.211.2 | **PacketCable Related aspects** |  | 291d? | 2006-02-01 A | 2007-03-15 A | 100% | 2006-02-01 | 2007-03-15 | 291d? |  | S2,S5,C1 | 5088h | 5088h | FBI-PCBL | CableLabs | Bernie McKibben | Rel-7 |  |  |  |
| 719 | 1.211.2.1 | Stage 1,2 of FBI for PacketCable |  | 228d? | 2006-02-01 A | 2006-12-15 A | 100% | 2006-02-01 | 2006-12-15 | 228d? | finish no earlier than 2006-12-15 | S2 | 1824h | 1824h | FBI-PCBL | CableLabs | Bernie McKibben | Rel-7 |  | 22.228, 23.228 |  |
| 720 | 1.211.2.2 | Protocol impact of FBI for PacketCable |  | 228d? | 2006-05-01 A | 2007-03-15 A | 100% | 2006-05-01 | 2007-03-15 | 228d? | finish no earlier than 2007-03-15 | C1 | 1824h | 1824h | FBI-PCBL |  |  | Rel-7 |  |  |  |
| 721 | 1.211.2.3 | SA5 Charging aspects of FBI for PacketCable |  | 180d? | 2006-03-31 A | 2006-12-07 A | 100% | 2006-03-31 | 2006-12-07 | 180d? | finish no earlier than 2006-12-07 | S5 | 1440h | 1440h | FBI-PCBL-CH | CableLabs | Bernie McKibben | Rel-7 | Adrian | 32.240, 32.260, 32.298, 32.299 |  |

Notes:
- 696: Moved from FS section Feb 06
- 697: Moved from FS section Feb 06
- 698: Moved from FS section Feb 06. Abandoned at SP-30
- 703: SR in RP-080819. RP#42 completed. Linked to UID_7041 (NSP-CR).
- 706: NEW - inserted on 2/9/2004
- 714: end date updated by CT1-chairman after CT#33
- 716: CT4#32: a set of CRs on FBI for cable labs
- 717: Duplicated entry ("ACCSEC2", "Access Security Enhancements", SP-040865) deleted by A.Sultan
- 721: 03/2006 SA#31 WID approved

| ID | WBS | Task | Type | Duration | Start | Finish | Complete | Baseline start | Baseline finish | Baseline duration | Constraint | Resources | Work | Actual work | Text1 | Text4 | Text5 | Text6 | Text8 | Text3 | Text12 |
| --- | --- | --- | --- | --- | --- | --- | --- | --- | --- | --- | --- | --- | --- | --- | --- | --- | --- | --- | --- | --- | --- |
| 722 | 1.212 | **Support of SMS over generic 3GPP IP access** |  | 696d? | 2004-10-14 A | 2007-06-15 A | 100% | 2004-10-14 | 2007-06-15 | 696d? |  | S2,C4,C1 | 12408h | 12408h | SMSIP | Huawei | zhangwenlin@huawei.com | Rel-7 | Maurice |  |  |
| 723 | 1.212.1 | FS on SMSIP |  | 173d? | 2004-10-14 A | 2005-06-13 A | 100% | 2004-10-14 | 2005-06-13 | 173d? | start no earlier than 2004-10-14 | S2 | 1384h | 1384h | SMSIP | Huawei | zhangwenlin@huawei.com | Rel-7 |  | 23.804 |  |
| 724 | 1.212.2 | Stage 2 for SMSIP |  | 333d? | 2005-06-08 A | 2006-09-15 A | 100% | 2005-06-08 | 2006-09-15 | 333d? | finish no earlier than 2006-09-15 | S2 | 2664h | 2664h | SMSIP | Huawei | zhangwenlin@huawei.com | Rel-7 |  | 23.204 |  |
| 725 | 1.212.3 | **Stage 3 for SMSIP** |  | 527d? | 2005-06-08 A | 2007-06-15 A | 100% | 2005-06-08 | 2007-06-15 | 527d? |  | C4,C1 | 8360h | 8360h | SMSIP-St3 | Nokia | jari.jansson@nokia.com | Rel-7 |  |  |  |
| 726 | 1.212.3.1 | CT1 aspects for SMSIP |  | 527d? | 2005-06-08 A | 2007-06-15 A | 100% | 2005-06-08 | 2007-06-15 | 527d? | finish no earlier than 2007-06-15 | C1 | 4216h | 4216h | SMSIP | Nokia | jari.jansson@nokia.com | Rel-7 |  | 23.040, 24.229 |  |
| 727 | 1.212.3.2 | CT4 aspects for SMSIP |  | 518d? | 2005-06-08 A | 2007-06-01 A | 100% | 2005-06-08 | 2007-06-01 | 518d? | finish no earlier than 2007-06-01 | C4 | 4144h | 4144h | SMSIP-St3-c4 | Nokia | jari.jansson@nokia.com | Rel-7 |  | 23.008, 29.002 |  |
| 728 | 1.213 | **Evolution of Policy Control and Charging** |  | 817d? | 2004-10-14 A | 2007-11-30 A | 100% | 2004-10-14 | 2007-11-30 | 817d? |  | S2,S5,C3,C1 | 30336h | 30336h | PCC | Nokia | balazs.bertenyi@nokia.com | Rel-7 | Maurice |  |  |
| 729 | 1.213.1 | Deleted - TR for PCC |  | 315d? | 2004-10-14 A | 2005-12-29 A | 100% | 2004-10-14 | 2005-12-29 | 315d? | finish no earlier than 2005-12-28 | S2 | 2520h | 2520h | PCC | Nokia | balazs.bertenyi@nokia.com | Rel-7 |  | 23.803 | SP-33 |
| 730 | 1.213.2 | Stage 2 for PCC |  | 315d? | 2005-07-04 A | 2006-09-15 A | 100% | 2005-07-04 | 2006-09-15 | 315d? | finish no earlier than 2006-09-15 | S2 | 2520h | 2520h | PCC | Nokia | balazs.bertenyi@nokia.com | Rel-7 |  | 23.203 |  |
| 731 | 1.213.3 | Evolution of policy control and flow based bearer level charging |  | 109d? | 2006-08-01 A | 2006-12-29 A | 100% | 2006-08-01 | 2006-12-29 | 109d? | start no earlier than 2006-08-01 | S2 | 872h | 872h | PCC | Nokia | balazs.bertenyi@nokia.com | Rel-7 |  | 23.207, 23.002, 23.228 |  |
| 732 | 1.213.4 | SA5 Charging aspects of PCC |  | 316d? | 2006-03-31 A | 2007-06-15 A | 100% | 2006-03-31 | 2007-06-15 | 316d? | finish no earlier than 2007-06-15 | S5 | 2528h | 2528h | PCC-CH | Orange | alain.bibas@orange-ft.com | Rel-7 | Adrian | 32.250, 32.251, 32.298, 32.299 |  |
| 733 | 1.213.5 | Gx reference point for Policy and Charging Control |  | 521d? | 2005-12-02 A | 2007-11-30 A | 100% | 2005-12-02 | 2007-11-30 | 521d? | finish no earlier than 2007-09-14 | C3 | 4168h | 4168h | PCC-Gx | Siemens | thomas.belling@siemens.com | Rel-7 | Seung Don | 29.212 (not progressed to Rel-7: 29.210, 29.207, 29.208) |  |
| 734 | 1.213.6 | **Rx reference point for PCC CT3 aspects** |  | 521d? | 2005-12-02 A | 2007-11-30 A | 100% | 2005-12-02 | 2007-11-30 | 521d? |  | C3,C1 | 11192h | 11192h | PCC-Rx | Ericsson | j.javier.pastor@ericsson.com | Rel-7 | Seung Don |  |  |
| 735 | 1.213.6.1 | PCC-Rx CT3 aspects |  | 521d? | 2005-12-02 A | 2007-11-30 A | 100% | 2005-12-02 | 2007-11-30 | 521d? | finish no earlier than 2007-09-14 | C3 | 4168h | 4168h | PCC-Rx-c3 | Ericsson | j.javier.pastor@ericsson.com | Rel-7 | Seung Don | 29.213, 29.214 (not progressed to Rel-7: 29.209, 29.211) |  |
| 736 | 1.213.6.2 | PCC-Rx CT1 aspects |  | 357d? | 2005-12-02 A | 2007-06-15 A | 100% | 2005-12-02 | 2007-06-15 | 357d? | finish no earlier than 2007-06-15 | C1 | 2856h | 2856h | PCC-Rx-Gx-c1 | Ericsson | j.javier.pastor@ericsson.com | Rel-7 |  | 24.229 |  |
| 737 | 1.214 | **Voice call continuity between CS and IMS (incl. I-WLAN)** |  | 641d? | 2004-12-31 A | 2007-06-15 A | 100% | 2004-12-31 | 2007-06-15 | 641d? |  | S2,S1,S5,C1,C4 | 12224h | 12224h | VCC | Alcatel-Lucent | andybennett@Alcatel-Lucent.com | Rel-7 | Maurice |  |  |
| 738 | 1.214.1 | TR for VCC |  | 245d? | 2004-12-31 A | 2005-12-08 A | 100% | 2004-12-31 | 2005-12-08 | 245d? | finish no earlier than 2005-12-08 | S2 | 1960h | 1960h | VCC | Alcatel-Lucent | andybennett@Alcatel-Lucent.com | Rel-7 |  | 23.806 |  |
| 739 | 1.214.2 | Stage 1 for VCC |  | 140d? | 2005-03-17 A | 2005-09-28 A | 100% | 2005-03-17 | 2005-09-28 | 140d? | finish no earlier than 2005-09-28 | S1 | 1120h | 1120h | VCC | Alcatel-Lucent | andybennett@Alcatel-Lucent.com | Rel-7 | Mike | 22.101 |  |
| 740 | 1.214.3 | Stage 2 for VCC |  | 264d? | 2005-09-06 A | 2006-09-08 A | 100% | 2005-09-06 | 2006-09-08 | 264d? | finish no earlier than 2006-09-08 | S2 | 2112h | 2112h | VCC | Alcatel-Lucent | andybennett@Alcatel-Lucent.com | Rel-7 |  | 23.206 |  |
| 741 | 1.214.4 | SA5 Charging aspects of VCC |  | 325d? | 2006-03-17 A | 2007-06-14 A | 100% | 2006-03-17 | 2007-06-14 | 325d? | finish no earlier than 2007-06-14 | S5 | 2600h | 2600h | VCC-CH | Orange | alain.bibas@orange-ft.com | Rel-7 | Adrian | 32.250, 32.260 |  |
| 742 | 1.214.5 | **Stage 3 for VCC** |  | 358d? | 2006-02-01 A | 2007-06-15 A | 100% | 2006-02-01 | 2007-06-15 | 358d? |  | C1,C4 | 4432h | 4432h | VCC | Alcatel-Lucent | drage@alcatel-lucent.com | Rel-7 |  |  |  |
| 743 | 1.214.5.1 | CT1 aspects of VCC |  | 358d? | 2006-02-01 A | 2007-06-15 A | 100% | 2006-02-01 | 2007-06-15 | 358d? | finish no earlier than 2007-06-15 | C1 | 2864h | 2864h | VCC | Alcatel-Lucent | drage@alcatel-lucent.com | Rel-7 | Frederic | 24.206, 24.216 |  |
| 744 | 1.214.5.2 | CT4 aspects of VCC |  | 196d? | 2006-06-09 A | 2007-03-09 A | 100% | 2006-06-09 | 2007-03-09 | 196d? | start no earlier than 2006-06-09 | C4 | 1568h | 1568h | VCC-St3-c4 | Alcatel-Lucent | drage@alcatel-ucent.com | Rel-7 | Kimmo | 23.003 |  |
| 745 | 1.214.5.3 | Deleted - CT3 aspects of VCC | milestone | 0d? | 2006-11-02 A | 2006-11-02 A | 100% | 2006-11-02 | 2006-11-02 | 0d? | finish no earlier than 2006-11-02 | C3 |  |  | VCC | Alcatel-Lucent | drage@lucent.com | Rel-7 |  | 29.163 | CP-33 |

Notes:
- 722: SA#33 updated WID (removed MMS)
- 723: SA#33 updated WID
- 724: SA#33 updated WID
- 725: CT#34 updated WID
- 726: CT#34 updated WID
- 727: CT#34 updated WID
- 728: SP-29 approved WID. SP-31 updated WID adding SA5 charging. 23.125 will be discontinued from Rel-7.
- 729: SP-30: S2 has no intention for TR completion
- 730: SP-29 approved WID. SP-31 updated WID. 23.125 will be discontinued from Rel-7.
- 731: SP-29 approved WID. SP-31 updated WID. 23.125 will be discontinued from Rel-7.
- 732: SP-31 updated WID with SA5 charging.
- 734: WID approved at CT#30, Revised at CT#31, Revised at CT#33
- 737: WID approved SA#27; updated SA#28; updated SA#32
- 741: 03/2006 SA#31 WID approved

| ID | WBS | Task | Type | Duration | Start | Finish | Complete | Baseline start | Baseline finish | Baseline duration | Constraint | Resources | Work | Actual work | Text1 | Text4 | Text5 | Text6 | Text8 | Text3 | Text12 |
| --- | --- | --- | --- | --- | --- | --- | --- | --- | --- | --- | --- | --- | --- | --- | --- | --- | --- | --- | --- | --- | --- |
| 746 | 1.215 | **One Tunnel solution for Optimisation of Packet Data Traffic** |  | 418d? | 2006-03-27 A | 2007-10-31 A | 100% | 2006-03-27 | 2007-10-31 | 418d? |  | S2 | 7048h | 7048h | OPTUNEL | Nokia | antti.j.pasanen@nokia.com | Rel-7 | Maurice |  |  |
| 747 | 1.215.1 | Deleted - Study on Stage 2 for One Tunnel solution |  | 125d? | 2006-03-27 A | 2006-09-15 A | 100% | 2006-03-27 | 2006-09-15 | 125d? | finish no earlier than 2005-09-12 | S2 | 1000h | 1000h | OPTUNEL-Study | Nokia | antti.j.pasanen@nokia.com | Rel-7 | Maurice | 23.809 | SP-34 |
| 748 | 1.215.2 | One Tunnel Deployment Guideline |  | 268d? | 2006-10-23 A | 2007-10-31 A | 100% | 2006-10-23 | 2007-10-31 | 268d? | finish no earlier than 2007-10-31 | S2 | 2144h | 2144h | OPTUNEL-Guide | Huawei | lan.liu@huawei.com | Rel-7 | Maurice | 23.919 |  |
| 749 | 1.215.3 | Stage 2 specification for One Tunnel solution |  | 70d? | 2006-09-11 A | 2006-12-15 A | 100% | 2006-09-11 | 2006-12-15 | 70d? | finish no earlier than 2006-12-15 | S2 | 560h | 560h | OPTUNEL-Stage2 | Nokia | antti.j.pasanen@nokia.com | Rel-7 | Maurice | 23.060 |  |
| 750 | 1.216 | **CSI Terminating Session handling** |  | 267d? | 2006-06-08 A | 2007-06-15 A | 100% | 2006-06-08 | 2007-06-15 | 267d? |  | S2,C1 | 4728h | 4728h | CSItermS | Samsung | Osok Song | Rel-7 | Maurice |  |  |
| 751 | 1.216.1 | Stage 2 of CStermS |  | 192d? | 2006-06-08 A | 2007-03-02 A | 100% | 2006-06-08 | 2007-03-02 | 192d? | start no earlier than 2006-06-08 | S2 | 1536h | 1536h | CSItermS | Samsung | Osok Song | Rel-7 | Maurice | 23.279 |  |
| 752 | 1.216.2 | Stage 3 of CStermS |  | 132d? | 2006-12-14 A | 2007-06-15 A | 100% | 2006-12-14 | 2007-06-15 | 132d? | finish no earlier than 2007-06-15 | C1 | 1056h | 1056h | CSItermS | Samsung | chenho.chin@samsung.com | Rel-7 | Frederic | 24.229, 24.279 |  |
| 753 | 1.216.3 | Deleted - duplicated with UID 340015 -Stage 3 CSI Terminating Session handling | milestone | 0d? | 2007-03-09 A | 2007-03-09 A | 100% | 2007-03-09 | 2007-03-09 | 0d? | start no earlier than 2007-03-09 | C1 |  |  | CSItermS | Samsung | chenho.chin@samsung.com | Rel-7 | Frederic | 24.229, 24.179, 24.279 | CP-34 |
| 754 | 1.217 | Liberty Alliance and 3GPP Security Interworking |  | 451d? | 2005-03-10 A | 2006-11-30 A | 100% | 2005-03-10 | 2006-11-30 | 451d? | finish no earlier than 2006-11-30 | S3 | 3608h | 3608h | LibSec | Nokia | Silke.Holtmanns@NOKIA.COM | Rel-7 | Maurice | 33.980 |  |
| 755 | 1.218 | Trust Requirements for Open Platforms in 3GPP |  | 499d? | 2005-01-03 A | 2006-11-30 A | 100% | 2005-01-03 | 2006-11-30 | 499d? | finish no earlier than 2006-11-30 | S3 | 3992h | 3992h | TrustOP | Nokia | Silke.Holtmanns@NOKIA.COM | Rel-7 | Michael | 33.905 |  |
| 756 | 1.219 | Development of UEA2 and UIA2 |  | 268d? | 2004-12-01 A | 2005-12-09 A | 100% | 2004-12-01 | 2005-12-09 | 268d? | finish no earlier than 2005-12-09 | S3 | 2144h | 2144h | AlgUEA2 | TeliaSonera | per.christoffersson@teliasonera.com | Rel-7 | Michael | 35.919, 35.215, 35.216, 35.217, 35.218 |  |
| 757 | 1.220 | Lawful Interception in the 3GPP Rel-7 architecture |  | 118d? | 2005-06-28 A | 2005-12-08 A | 100% | 2005-06-28 | 2005-12-08 | 118d? | start no earlier than 2005-06-28 | S3 | 944h | 944h | LI-7A | BMWI | berthold.wilhelm@regtp.de | Rel-7 | Mike | 33.106, 33.107, 33.108 |  |
| 758 | 1.221 | Key establishment between a UICC and a terminal |  | 201.45d? | 2005-12-07 A | 2006-09-28 A | 100% | 2005-12-07 | 2006-09-28 | 201.45d? | finish no earlier than 2006-09-28 | S3 | 1611.6h | 1611.6h | KeyEstUTerm | Gemalto | mireille.pauliac@gemplus.com | Rel-7 |  | 33.110 |  |
| 759 | 1.222 | NDS Authentication Framework Extension for Transport Layer Security |  | 50d? | 2006-09-28 A | 2006-12-06 A | 100% | 2006-09-28 | 2006-12-06 | 50d? | finish no earlier than 2006-09-28 | S3 | 400h | 400h | NDSAFTLS | Nokia | tiina.s.koskinen@nokia.com | Rel-7 | Michael | 33.310 |  |
| 760 | 1.223 | **Security enhancements** |  | 319d? | 2005-09-12 A | 2006-11-30 A | 100% | 2005-09-12 | 2006-11-30 | 319d? |  | S3,C1,C4 | 4856h | 4856h | SEC7 |  |  | Rel-7 |  |  |  |
| 761 | 1.223.1 | HTTPS connection between a UICC and a NAF |  | 1d? | 2005-09-12 A | 2005-09-12 A | 100% | 2005-09-12 | 2005-09-12 | 1d? | start no earlier than 2005-09-12 | S3,C1 | 8h | 8h | SEC7-HSUN | Gemalto | JSeif@axalto.com, mireille.pauliac@gemplus.com | Rel-7 |  | 33.918, 33.222, 24.109 |  |
| 762 | 1.223.2 | 2G GBA: 2G SIM usage in 3GPP GAA framework |  | 61d? | 2005-09-12 A | 2005-12-05 A | 100% | 2005-09-12 | 2005-12-05 | 61d? | finish no earlier than 2005-12-05 | S3 | 488h | 488h | SEC7-2GGBA | Nokia | Silke.Holtmanns@nokia.com | Rel-7 |  | 33.920, 33.220 |  |
| 763 | 1.223.3 | Generic Authentication Architecture usage extensions and optimisations |  | 319d? | 2005-09-12 A | 2006-11-30 A | 100% | 2005-09-12 | 2006-11-30 | 319d? | finish no earlier than 2006-11-30 | S3 | 2552h | 2552h | SEC7-GAA2 | Nokia | Silke.Holtmanns@nokia.com | Rel-7 |  | 33.220, 29.109, 24.109, (33.223 goes to R8) |  |
| 764 | 1.223.4 | **SS7 TCAP security Gateway** |  | 241d? | 2005-09-12 A | 2006-08-14 A | 100% | 2005-09-12 | 2006-08-14 | 241d? |  | S3,C4 | 1808h | 1808h | SEC7-NDS-TCAPsec | Siemens | marc.blommaert@siemens.com | Rel-7 |  |  |  |
| 765 | 1.223.4.1 | SA3 aspects of SEC7-NDS-TCAPsec |  | 130d? | 2005-09-12 A | 2006-03-10 A | 100% | 2005-09-12 | 2006-03-10 | 130d? | finish no earlier than 2006-03-10 | S3 | 1040h | 1040h | SEC7-NDS-TCAPsec-SA3 | Siemens | marc.blommaert@siemens.com | Rel-7 |  | 33.204 |  |
| 766 | 1.223.4.2 | TCAPsec Gateway |  | 96d? | 2006-04-03 A | 2006-08-14 A | 100% | 2006-04-03 | 2006-08-14 | 96d? | start no earlier than 2006-04-01 | C4 | 768h | 768h | SEC7-TCAP | Siemens | Ulrich.wiehe@gksag.de | Rel-7 | Kimmo | 29.204, 29.002 |  |
| 767 | 1.224 | IMS Stage 3 IETF Protocol alignment |  | 589d? | 2004-12-10 A | 2007-03-15 A | 100% | 2004-12-10 | 2007-03-15 | 589d? | finish no earlier than 2007-03-15 | C1 | 4712h | 4712h | IMSProtoc |  |  | Rel-7 |  | 24.930 |  |
| 768 | 1.225 | **Interoperability between VGCS/VBS and A/Gb flexibility** |  | 253d? | 2006-03-22 A | 2007-03-09 A | 100% | 2006-03-22 | 2007-03-09 | 253d? |  | C1,C4 | 3296h | 3296h | VGCSFlex | Siemens | robert.zaus@siemens.com | Rel-7 | Frederic |  |  |
| 769 | 1.225.1 | CT1 aspects of VGCSFlex |  | 159d? | 2006-03-22 A | 2006-10-30 A | 100% | 2006-03-22 | 2006-10-30 | 159d? | finish no earlier than 2006-10-30 | C1 | 1272h | 1272h | VGCSFlex | Siemens | robert.zaus@siemens.com | Rel-7 |  | 43.068, 43.069 |  |
| 770 | 1.225.2 | CT4 aspects of VGCSFlex |  | 253d? | 2006-03-22 A | 2007-03-09 A | 100% | 2006-03-22 | 2007-03-09 | 253d? | finish no earlier than 2007-03-09 | C4 | 2024h | 2024h | VGCSFlex-c4 | Siemens | robert.zaus@siemens.com | Rel-7 |  | 29.002 |  |
| 771 | 1.226 | DIAMETER on the GGSN Gi interface |  | 586d? | 2004-09-10 A | 2006-12-08 A | 100% | 2004-09-10 | 2006-12-08 | 586d? | finish no earlier than 2006-12-08 | C3 | 4688h | 4688h | DIAMGi | Vodafone | Nico.Gabriele@vodafone.com | Rel-7 | Seung Don | 29.061 |  |
| 772 | 1.227 | DIAMETER on the PDG Wi interface |  | 586d? | 2004-09-10 A | 2006-12-08 A | 100% | 2004-09-10 | 2006-12-08 | 586d? | finish no earlier than 2006-12-08 | C3 | 4688h | 4688h | DIAMWi | Vodafone | Nico.Gabriele@vodafone.com | Rel-7 | Seung Don | 29.161 |  |
| 773 | 1.228 | Interworking between the 3GPP CS domain with BICC or ISUP as signalling protocol and external SIP-I networks |  | 478d? | 2006-09-22 A | 2008-07-22 A | 100% | 2006-09-22 | 2008-07-22 | 478d? | finish no earlier than 2007-09-14 | C3 | 3824h | 3824h | ExtSIPI | Siemens | thomas.belling@SIEMENS.COM | Rel-7 | Seung Don | 29.164 |  |
| 774 | 1.229 | PDU multiplexing at Nb Interface with IP transport |  | 427d? | 2006-12-04 A | 2008-07-22 A | 100% | 2006-12-04 | 2008-07-22 | 427d? | start no earlier than 2006-12-04 | C3 | 3416h | 3416h | NbIPMux | Alcatel-Lucent | Jean.Rzeznik@alcatel-lucent.fr | Rel-7 | Seung Don | 29.414 |  |

Notes:
- 747: S2#52 CREATED. TR for Info SP-33. SP-34: S2 Report intention to discontinue TR
- 748: S2#55 CREATED: SP-34 Approved and extension request granted until 03/07
- 749: S2#52 CREATED
- 750: Triggered by the abandoned Study UID_32117
- 752: CP-34 approved WID. CP-35 updated WID
- 753: CP-34 approved WID
- 754: WID approved SA#27.
- 755: WID approved SA#26.
- 756: WID approved SA#26, Dependant on Funding Availability.
- 759: TLS profile is moved to Rel-8
- 763: 33.223 goes to R8
- 767: TR 24.930: Signalling flows for the session setup in the IM CN subsystem based on Session Initiation Protocol (SIP)
- 774: 08/03/2007 08:00

| ID | WBS | Task | Type | Duration | Start | Finish | Complete | Baseline start | Baseline finish | Baseline duration | Constraint | Resources | Work | Actual work | Text1 | Text4 | Text5 | Text6 | Text8 | Text12 |
| --- | --- | --- | --- | --- | --- | --- | --- | --- | --- | --- | --- | --- | --- | --- | --- | --- | --- | --- | --- | --- |
| 775 | 1.230 | **Mp (MRFC - MRFP) interface** |  | 345d? | 2006-02-13 A | 2007-06-08 A | 100% | 2006-02-13 | 2007-06-08 | 345d? |  | C4,C1 | 4384h | 4384h | Mp | Ericsson | philip.hodges@ericsson.com | Rel-7 | Kimmo |  |
| 776 | 1.230.1 | CT1 aspects of Mp |  | 1d | 2006-02-13 A | 2006-02-13 A | 100% | 2006-02-13 | 2006-02-13 | 1d | finish no earlier than 2006-02-13 | C1 | 8h | 8h | Mp | Ericsson | philip.hodges@ericsson.com | Rel-7 |  |  |
| 777 | 1.230.2 | Deleted - CT3 aspects of Mp |  | 1d | 2006-09-22 A | 2006-09-22 A | 100% | 2006-09-22 | 2006-09-22 | 1d | start no earlier than 2006-09-22 | C3 | 8h | 8h | Mp | Ericsson | philip.hodges@ericsson.com | Rel-7 |  | CP-33 |
| 778 | 1.230.3 | Procedures description |  | 201d? | 2006-06-02 A | 2007-03-09 A | 100% | 2006-06-02 | 2007-03-09 | 201d? | finish no earlier than 2007-03-09 | C4 | 1608h | 1608h | Mp-PROCc4 | Huawei | Chen Cheng | Rel-7 | Kimmo |  |
| 779 | 1.230.4 | Stage 3 |  | 345d | 2006-02-13 A | 2007-06-08 A | 100% | 2006-02-13 | 2007-06-08 | 345d | finish no earlier than 2007-06-08 | C4 | 2760h | 2760h | Mp-St3c4 | Ericsson | philip.hodges@ericsson.com | Rel-7 | Kimmo |  |
| 780 | 1.231 | Routeing of MT-SMs via the HPLMN |  | 71d? | 2006-12-01 A | 2007-03-09 A | 100% | 2006-12-01 | 2007-03-09 | 71d? | finish no earlier than 2007-03-09 | C4,C1 | 568h | 568h | SMSviaH | Vodafone | Nick.Russell@vodafone.com | Rel-7 | Kimmo |  |
| 781 | 1.232 | Mobile Termination whilst the MS is moving to another MSC |  | 60d? | 2007-03-09 A | 2007-05-31 A | 100% | 2007-03-09 | 2007-05-31 | 60d? | start no earlier than 2007-03-09 | C4 | 480h | 480h | MTmovMS | Alcatel-Lucent | bruno.landais@alcatel-lucent.fr | Rel-7 |  |  |
| 782 | 1.233 | ISIM API for Java Card |  | 620d? | 2005-03-14 A | 2007-07-27 A | 100% | 2005-03-14 | 2007-07-27 | 620d? | finish no earlier than 2007-07-27 | C6 | 4960h | 4960h | APIJAVA | Sun | Sebastian Hans | Rel-7 | Gaby |  |
| 783 | 1.234 | High speed interface between the UICC and the ME |  | 311d? | 2006-09-22 A | 2007-11-30 A | 100% | 2006-09-22 | 2007-11-30 | 311d? | finish no earlier than 2007-11-30 | C6 | 2488h | 2488h | HSI | Gemalto | jacques.seif@GEMALTO.COM | Rel-7 | Gaby |  |
| 784 | 1.235 | Video Codec Performance Requirements |  | 634d? | 2005-01-03 A | 2007-06-07 A | 100% | 2005-01-03 | 2007-06-07 | 634d? | finish no earlier than 2007-06-07 | S4 | 5072h | 5072h | VICPer | Siemens | juergen.pandel@siemens.com | Rel-7 | Paolo |  |
| 785 | 1.236 | Dynamic and Interactive Multimedia Scenes |  | 583d? | 2005-03-15 A | 2007-06-07 A | 100% | 2005-03-15 | 2007-06-07 | 583d? | finish no earlier than 2007-06-07 | S4 | 4664h | 4664h | DIMS | Streamezzo | gaelle.martin-cocher@streamezzo.com | Rel-7 | Paolo |  |
| 786 | 1.237 | 3G-324M Video Telephony Call Setup Times Improvements |  | 341d? | 2005-06-08 A | 2006-09-27 A | 100% | 2005-06-08 | 2006-09-27 | 341d? | finish no earlier than 2006-09-27 | S4 | 2728h | 2728h | VTCSTI | Vodafone | edward.hall@vodafone.co.uk | Rel-7 | Paolo |  |
| 787 | 1.238 | **Optimizations for Multimedia Telephony over IMS** |  | 0d? | 2005-09-28 A | 2005-09-28 A | 100% | 2005-09-28 | 2005-09-28 | 0d? |  | S4 |  |  | OMTIMS | Ericsson | olle.franceschi@ericsson.com | Rel-7 | Paolo |  |
| 788 | 1.238.1 | Deleted - Characterisation of Adaptive Jitter Management Performance for VoIP Services | milestone | 0d? | 2005-09-28 A | 2005-09-28 A | 100% | 2005-09-28 | 2005-09-28 | 0d? | start no earlier than 2007-03-15 | S4 |  |  | OMTIMS-CAJMP | Lucent | dhuo@lucent.com | Rel-7 | Paolo | SP-35 |
| 789 | 1.239 | End-to-End Multimedia Services Performance Metrics |  | 382d? | 2005-09-28 A | 2007-03-15 A | 100% | 2005-09-28 | 2007-03-15 | 382d? | finish no earlier than 2007-03-15 | S4 | 3056h | 3056h | E2EMSPM | China Mobile | zhangyanyf@chinamobile.com | Rel-7 | Paolo |  |
| 790 | 1.240 | Packet Switched Streaming Enhancements |  | 261d? | 2006-06-08 A | 2007-06-07 A | 100% | 2006-06-08 | 2007-06-07 | 261d? | finish no earlier than 2007-06-07 | S4 | 2088h | 2088h | PSSe | Ericsson | olle.franceschi@ericsson.com | Rel-7 | Paolo |  |
| 791 | 1.241 | **OAM&P** |  | 472.86d? | 2005-09-02 A | 2007-06-26 A | 100% | 2005-09-02 | 2007-06-26 | 472.86d? |  | S5 | 82725.8h | 82725.8h | OAM7 | Huawei | Christian.Toche@huawei.com | Rel-7 | Adrian |  |
| 792 | 1.241.1 | **Network Infrastructure Management** |  | 465d? | 2005-09-02 A | 2007-06-14 A | 100% | 2005-09-02 | 2007-06-14 | 465d? |  | S5 | 41800h | 41800h | OAM7-NIM |  |  | Rel-7 |  |  |
| 793 | 1.241.1.1 | Enhance NRM to accommodate NGN (IMS as basis of the Next Generation Network) |  | 465d? | 2005-09-02 A | 2007-06-14 A | 100% | 2005-09-02 | 2007-06-14 | 465d? | finish no earlier than 2007-06-14 | S5 | 3720h | 3720h | OAM7-NIM | Motorola |  | Rel-7 |  |  |
| 794 | 1.241.1.2 | Co-operative Element Management interface (CO-OP) (Study + Implementation) |  | 400d? | 2005-09-02 A | 2007-03-15 A | 100% | 2005-09-02 | 2007-03-15 | 400d? | finish no earlier than 2007-03-15 | S5 | 3200h | 3200h | OAM7-NIM | Motorola |  | Rel-7 |  |  |
| 795 | 1.241.1.3 | Network Management (NM) Itf-N performance criteria |  | 465d? | 2005-09-02 A | 2007-06-14 A | 100% | 2005-09-02 | 2007-06-14 | 465d? | finish no earlier than 2007-06-14 | S5 | 3720h | 3720h | OAM7-NIM | China Mobile |  | Rel-7 |  |  |
| 796 | 1.241.1.4 | Delta synchronization between IRP Manager and IRP Agent (Study + Implementation) |  | 465d? | 2005-09-02 A | 2007-06-14 A | 100% | 2005-09-02 | 2007-06-14 | 465d? | finish no earlier than 2007-06-14 | S5 | 3720h | 3720h | OAM7-NIM | Siemens |  | Rel-7 |  |  |
| 797 | 1.241.1.5 | Subscription Management (SuM) IRP Solution Sets |  | 330d? | 2005-09-02 A | 2006-12-07 A | 100% | 2005-09-02 | 2006-12-07 | 330d? | finish no earlier than 2006-12-07 | S5 | 2640h | 2640h | OAM7-NIM | Ericsson |  | Rel-7 |  |  |
| 798 | 1.241.1.6 | Integration Reference Point (IRP) Security Management |  | 400d? | 2005-09-02 A | 2007-03-15 A | 100% | 2005-09-02 | 2007-03-15 | 400d? | finish no earlier than 2007-03-15 | S5 | 3200h | 3200h | OAM7-NIM | Huawei | Christian.Toche@huawei.com | Rel-7 |  |  |
| 799 | 1.241.1.7 | Partial suspension of Itf-N during maintenance/testing (Study + Implementation) |  | 465d? | 2005-09-02 A | 2007-06-14 A | 100% | 2005-09-02 | 2007-06-14 | 465d? | finish no earlier than 2007-06-14 | S5 | 3720h | 3720h | OAM7-NIM | Siemens |  | Rel-7 |  |  |
| 800 | 1.241.1.8 | Deleted - Management of Legacy Equipment |  | 336d? | 2005-09-02 A | 2006-12-15 A | 100% | 2005-09-02 | 2006-12-15 | 336d? | finish no earlier than 2006-12-15 | S5 | 2688h | 2688h | OAM7-NIM | Siemens |  | Rel-7 |  | SP-35 |
| 801 | 1.241.1.9 | Deleted - Rules for Vendor Specific Extensions |  | 400d? | 2005-09-02 A | 2007-03-15 A | 100% | 2005-09-02 | 2007-03-15 | 400d? | finish no earlier than 2007-03-15 | S5 | 3200h | 3200h | OAM7-NIM | Siemens |  | Rel-7 |  | SP-35 |
| 802 | 1.241.1.10 | Backward and Forward Compatibility of IRP systems |  | 465d? | 2005-09-02 A | 2007-06-14 A | 100% | 2005-09-02 | 2007-06-14 | 465d? | finish no earlier than 2007-06-14 | S5 | 3720h | 3720h | OAM7-NIM | Ericsson |  | Rel-7 |  |  |
| 803 | 1.241.1.11 | Repeater Network Resource Model (NRM) definition |  | 214d? | 2006-02-13 A | 2006-12-07 A | 100% | 2006-02-13 | 2006-12-07 | 214d? | finish no earlier than 2006-12-07 | S5 | 1712h | 1712h | OAM7-NIM | China Mobile |  | Rel-7 |  |  |
| 804 | 1.241.1.12 | UTRAN radio channel power monitoring |  | 284d? | 2006-02-13 A | 2007-03-15 A | 100% | 2006-02-13 | 2007-03-15 | 284d? | finish no earlier than 2007-03-15 | S5 | 2272h | 2272h | OAM7-NIM | China Mobile |  | Rel-7 |  |  |
| 805 | 1.241.1.13 | Notification XML Schema |  | 71d? | 2006-12-07 A | 2007-03-15 A | 100% | 2006-12-07 | 2007-03-15 | 71d? | finish no earlier than 2007-03-15 | S5 | 568h | 568h | OAM7-NIM | Huawei | Christian.Toche@huawei.com | Rel-7 |  |  |

Notes:
- 776: Text3: 24.229
- 777: CT#34: CT3 not involved in Mp interface definition / Text3: 29.162
- 778: Text3: 23.333
- 779: Text3: 29.333
- 780: WID approved in CT#34 / Text3: 23.040, 29.002
- 781: Text3: 23.008, 23.012, 23.018, 23.078, 23.079, 29.002
- 782: reported complete when checked after CT6#44 / Text3: 31.103, 102 241
- 783: Following ETSI publication of TS 102 600, expected to be completed at CT6#45 / Text3: 31.101
- 784: Text3: 26.234, 26.235, 26.346, 26.140, 26.902
- 785: Text3: 26.140, 26.142, 26.234, 26.244, 23.346
- 786: Text3: 26.911
- 787: Text3: 26.235, 26.236
- 788: SP-35 stopped
- 789: Text3: 26.944
- 790: Text3: 26.234, 26.244
- 793: Text3: 32.731/2/3/5, 32.631/2/3/5
- 794: Text3: 32.806, 32.814, 32.101
- 795: Text3: 32.811
- 796: Text3: 32.391/2/3/5
- 797: Text3: 32.307/317/607/667/665, 32.101, 32.175
- 798: Text3: 32.372/3/5, 32.111,32.30x,32.32x,32.33x,32.34x,32.35x,32.36x,32.41x,32.60x,32.61x,32.66x
- 799: Text3: 32.381/2/3/5
- 800: Request to TSG#35 to STOP the WI / Text3: new 32.xxx
- 801: Request to TSG#35 to STOP the WI / Text3: 32.62n; For n = 1 to 5
- 802: Submit extension Sheet for TSG#35 Approval / Text3: 32.154
- 803: Text3: 32.721/2/3/5
- 804: Text3: 32.405, 32.64n; For n = 1 to 5
- 805: 12/2006 SA#34 WID approved / Text3: New 32.325/345/365/415, CR to 32.335/615/665

| ID | WBS | Task | Type | Duration | Start | Finish | Complete | Baseline start | Baseline finish | Baseline duration | Constraint | Resources | Work | Actual work | Text1 | Text6 | Text4 | Text12 | Text5 | Text8 |
| --- | --- | --- | --- | --- | --- | --- | --- | --- | --- | --- | --- | --- | --- | --- | --- | --- | --- | --- | --- | --- |
| 806 | 1.241.2 | **Performance Management** |  | 465d? | 2005-09-02 A | 2007-06-14 A | 100% | 2005-09-02 | 2007-06-14 | 465d? |  | S5 | 22992h | 22992h | OAM7-PM | Rel-7 |  |  |  |  |
| 807 | 1.241.2.1 | Performance measurements definition for CN CS |  | 400d? | 2005-09-02 A | 2007-03-15 A | 100% | 2005-09-02 | 2007-03-15 | 400d? | finish no earlier than 2007-03-15 | S5 | 3200h | 3200h | OAM7-PM | Rel-7 | China Mobile |  |  |  |
| 808 | 1.241.2.2 | Enhancement UTRAN performance measurements definition |  | 465d? | 2005-09-02 A | 2007-06-14 A | 100% | 2005-09-02 | 2007-06-14 | 465d? | finish no earlier than 2007-06-14 | S5 | 3720h | 3720h | OAM7-PM | Rel-7 | China Mobile |  |  |  |
| 809 | 1.241.2.3 | Add TDD specific counters in Performance measurement |  | 330d? | 2005-09-02 A | 2006-12-07 A | 100% | 2005-09-02 | 2006-12-07 | 330d? | finish no earlier than 2006-12-15 | S5 | 2640h | 2640h | OAM7-PM | Rel-7 | CATT |  |  |  |
| 810 | 1.241.2.4 | ATM bearer network Performance measurements |  | 400d? | 2005-09-02 A | 2007-03-15 A | 100% | 2005-09-02 | 2007-03-15 | 400d? | finish no earlier than 2007-03-15 | S5 | 3200h | 3200h | OAM7-PM | Rel-7 | ZTE |  |  |  |
| 811 | 1.241.2.5 | Performance measurements definition for IMS |  | 465d? | 2005-09-02 A | 2007-06-14 A | 100% | 2005-09-02 | 2007-06-14 | 465d? | finish no earlier than 2007-06-14 | S5 | 3720h | 3720h | OAM7-PM | Rel-7 | China Mobile |  |  |  |
| 812 | 1.241.2.6 | HSDPA performance measurements |  | 349d? | 2006-02-13 A | 2007-06-14 A | 100% | 2006-02-13 | 2007-06-14 | 349d? | finish no earlier than 2007-06-14 | S5 | 2792h | 2792h | OAM7-PM | Rel-7 | China Mobile |  |  |  |
| 813 | 44.5 | **Trace Management** |  | 472.86d? | 2005-09-02 A | 2007-06-26 A | 100% | 2005-09-02 | 2007-06-26 | 472.86d? |  | S5 | 14150.9h | 14150.9h | OAM7-Trace | Rel-7 | Vodafone |  |  |  |
| 814 | 1.241.3.1 | End-to-end Service Level tracing for IMS |  | 350d? | 2005-11-11 A | 2007-03-15 A | 100% | 2005-11-11 | 2007-03-15 | 350d? | finish no earlier than 2007-03-15 | S5 | 2800h | 2800h | OAM7-Trace | Rel-7 | Vodafone | SP-31 |  |  |
| 815 | 1.241.3.2 | Trace record content for UTRAN TDD |  | 330d? | 2005-09-02 A | 2006-12-07 A | 100% | 2005-09-02 | 2006-12-07 | 330d? | finish no earlier than 2006-12-07 | S5 | 2640h | 2640h | OAM7-Trace | Rel-7 | Nokia |  |  |  |
| 816 | 1.241.3.3 | IRP for Subscriber and Equipment Trace Management |  | 465d? | 2005-09-02 A | 2007-06-14 A | 100% | 2005-09-02 | 2007-06-14 | 465d? | finish no earlier than 2007-06-14 | S5 | 3720h | 3720h | OAM7-Trace | Rel-7 | Nokia |  |  |  |
| 817 | 1.241.3.4 | Deleted - SIP enhancements for trace | milestone | 0d? | 2007-06-15 A | 2007-06-26 A | 100% | 2007-06-15 | 2007-06-26 | 0d? | start no earlier than 2007-06-15 | C1 |  |  | OAM7-Trace | Rel-7 |  | CP-32 |  |  |
| 818 | 1.241.3.5 | Deleted - duplicated with UID 35063 - IRP for Subscriber and Equipment Trace Management |  | 336d? | 2005-09-02 A | 2006-12-15 A | 100% | 2005-09-02 | 2006-12-15 | 336d? | finish no earlier than 2006-12-15 | S5 | 2688h | 2688h | OAM7-Trace | Rel-7 | Nokia | SP-33 |  |  |
| 819 | 1.242 | **Charging Management small Enhancements Rel-7** |  | 279d? | 2006-05-22 A | 2007-06-14 A | 100% | 2006-05-22 | 2007-06-14 | 279d? |  | S5 | 5952h | 5952h | CH7 | Rel-7 | Orange |  | alain.bibas@francetelecom.com | Adrian |
| 820 | 1.242.1 | Alternate Charged Party (ACP) for IMS |  | 279d? | 2006-05-22 A | 2007-06-14 A | 100% | 2006-05-22 | 2007-06-14 | 279d? | finish no earlier than 2007-06-14 | S5 | 2232h | 2232h | CH7-IMS-ACP | Rel-7 | Lucent |  | njmazzarella@alcatel-lucent.com |  |
| 821 | 1.242.2 | Align 3GPP Charging with OMA PoC Enabler Release 2.0 |  | 186d? | 2006-09-28 A | 2007-06-14 A | 100% | 2006-09-28 | 2007-06-14 | 186d? | finish no earlier than 2007-06-14 | S5 | 1488h | 1488h | CH7-PoC | Rel-7 | Siemens |  | gerald.goermer@siemens.com | Adrian |
| 822 | 8.5 | **Multiple Input Multiple Output antennas (MIMO)** |  | 1177d? | 2003-03-14 A | 2007-09-17 A | 100% | 2003-03-14 | 2007-09-17 | 1177d? |  | R1 | 40272h | 40272h | MIMO | Rel-7 | Alcatel-Lucent |  | hchuang@Alcatel-Lucent.com | Patrick |
| 823 | 1.243.1 | MIMO - Physical layer |  | 915d? | 2003-09-12 A | 2007-03-15 A | 100% | 2003-09-12 | 2007-03-15 | 915d? | finish no earlier than 2007-03-15 | R1 | 7320h | 7320h | MIMO-Phys | Rel-7 | Alcatel-Lucent |  | hchuang@Alcatel-Lucent.com | Patrick |
| 824 | 1.243.2 | MIMO - Layer 2,3 aspects |  | 915d? | 2003-09-12 A | 2007-03-15 A | 100% | 2003-09-12 | 2007-03-15 | 915d? | finish no earlier than 2007-03-15 | R2 | 7320h | 7320h | MIMO-L23 | Rel-7 | Alcatel-Lucent |  | hchuang@Alcatel-Lucent.com | Joern |
| 825 | 1.243.3 | MIMO - Iub/Iur Protocol Aspects |  | 1045d? | 2003-03-14 A | 2007-03-15 A | 100% | 2003-03-14 | 2007-03-15 | 1045d? | finish no earlier than 2007-03-15 | R3 | 8360h | 8360h | MIMO-IurIub | Rel-7 | Alcatel-Lucent |  | hchuang@Alcatel-Lucent.com | Juergen |
| 826 | 1.243.4 | MIMO - RF Radio Transmission/Reception, System Performance Requirements and Conformance Testing |  | 982d? | 2003-12-12 A | 2007-09-17 A | 100% | 2003-12-12 | 2007-09-17 | 982d? | finish no earlier than 2007-09-17 | R4 | 7856h | 7856h | MIMO-RF | Rel-7 | Alcatel-Lucent |  | ngm@Alcatel-Lucent.com | Stefania |
| 827 | 1.244 | **Rel-7 Improvements of the Radio Interface** |  | 709d? | 2004-09-15 A | 2007-06-04 A | 100% | 2004-09-15 | 2007-06-04 | 709d? |  | RP | 29696h | 29696h | RInImp | Rel-7 |  |  |  | Juergen |
| 828 | 1.244.1 | Extended UMTS 1.7/2.1 GHz |  | 198d? | 2006-03-15 A | 2006-12-15 A | 100% | 2006-03-15 | 2006-12-15 | 198d? | finish no earlier than 2006-12-15 | R4 | 1584h | 1584h | RInImp-UMTS1721Ext | Rel-7 | Ericsson |  | johan.skold@ericsson.com | Stefania |
| 829 | 1.244.2 | UMTS 2.6 GHz 7.68 Mcps TDD |  | 67d? | 2006-06-15 A | 2006-09-15 A | 100% | 2006-06-15 | 2006-09-15 | 67d? | finish no earlier than 2006-09-15 | R4 | 536h | 536h | RInImp-UMTS26VHCRTDD | Rel-7 | IPWireless |  | Shin Horng Wong (shwong@ipwireless.com) | Stefania |
| 830 | 1.244.3 | UMTS 2.6 GHz |  | 195d? | 2004-09-15 A | 2005-06-14 A | 100% | 2004-09-15 | 2005-06-14 | 195d? | finish no earlier than 2005-06-14 | R4 | 1560h | 1560h | RInImp-UMTS2600 | Rel-7 | Nokia |  | jussi.numminen@nokia.com | Stefania |
| 831 | 1.244.4 | UMTS 2.6 GHz TDD |  | 261d? | 2004-12-15 A | 2005-12-14 A | 100% | 2004-12-15 | 2005-12-14 | 261d? | finish no earlier than 2005-12-15 | R4 | 2088h | 2088h | RInImp-UMTS2600TDD | Rel-7 | IPWireless |  | Shin Horng Wong ( (shwong@IPWIRELESS.COM) | Stefania |
| 832 | 1.244.5 | UMTS 900 MHz |  | 261d? | 2004-12-15 A | 2005-12-14 A | 100% | 2004-12-15 | 2005-12-14 | 261d? | finish no earlier than 2005-12-15 | R4 | 2088h | 2088h | RInImp-UMTS900 | Rel-7 | Nortel |  | Yannick Li (yli@nortelnetworks.com) | Stefania |
| 833 | 1.244.6 | UMTS 1700 MHz |  | 197d? | 2005-03-15 A | 2005-12-14 A | 100% | 2005-03-15 | 2005-12-14 | 197d? | finish no earlier than 2005-12-15 | R4 | 1576h | 1576h | RInImp-UMTS1700 | Rel-7 | NTT DoCoMo |  | nakamurata@NTTDOCOMO.CO.JP | Stefania |
| 834 | 1.244.7 | UE Antenna Performance Evaluation Method and Requirements |  | 644d? | 2004-12-15 A | 2007-06-04 A | 100% | 2004-12-15 | 2007-06-04 | 644d? | finish no earlier than 2007-06-04 | R4 | 5152h | 5152h | RInImp-UEAnt | Rel-7 | TeliaSonera |  | Christian.Bergljung@TeliaSonera.com | Stefania |
| 835 | 1.244.8 | Improved Performance Requirements for HSDPA UE based on Rx Diversity (type 1) & LMMSE equalizer (type 2) | milestone | 0d? | 2005-03-15 A | 2005-03-15 A | 100% | 2005-03-15 | 2005-03-15 | 0d? | finish no earlier than 2005-03-15 | R4 |  |  | RInImp-HSPerf-Type3 | Rel-7 | Cingular |  | marc.grant@cingular.com | Stefania |

Notes:
- 807: Text3: 32.407, 32.408
- 808: Submit extension Sheet for TSG#35 Approval / Text3: 32.405
- 809: Text3: 32.405
- 810: Text3: No impact on 32.404, 32.405, 32.406, 32.407
- 811: Submit extension Sheet for TSG#35 Approval / Text3: 32.404,32.409,32.437, 32.632/3/4/5
- 812: Submit extension Sheet for TSG#35 Approval / Text3: 32.405
- 814: 07/2005: OMA (Stage 1), Stage 2/3 SA5, CT1/3/4 / Text3: CR 32.101, 32.421/2/3.
- 815: Text3: CR 32.421/2/3.
- 816: Submit extension Sheet for TSG#35 Approval / Text3: 32.441/2/3/5, CRs 32.632/3/5
- 817: combined with UID 11067
- 818: Text3: 32.421,32.422,32.423. 3 new 32.4x1,2,3
- 819: Text3: 32.2xy
- 820: Text3: 32.240, 32.260, 32.298, 32.299
- 821: 09/2006 SA#33 WID approved / Text3: 32.240, 32.272, 32.299, 32.298
- 822: Completed Sep 2007; SR in RP-070037and RP-070531 / Text3: 25.876, 25.996
- 823: Completed Sep 2007; SR in RP-070037 / Text3: 25.211, 25.212, 25.213, 25.214, 25.215, 25.221
- 824: Completed Sep 2007; SR in RP-070037 / Text3: 25.876
- 825: Completed Sep 2007; SR in RP-070037
- 826: Completed Sep 2007; SR in RP-070531
- 827: Generic feature
- 828: Completed Dec 2006; SR in RP-060681 / Text3: 25.806, 25.101, 25.104, 25.133, 24.141, 25.331, 25.306, 25.307, 25.423, 25.461, 25.463, 34.121
- 829: Completed Sep 2006; SR in RP-060451 / Text3: 25.102, 25.105, 25.123, 25.113, 25.142, 34.124
- 830: Completed Jun 2005, SR in RP-050184 / Text3: 25.101, 25.104, 25.133, 25.141, 25.331, 25.942, 25.306, 25.307, 34.121
- 831: Completed Dec 2005, SR in RP-050661 / Text3: 25.102, 25.105, 25.113, 25.123, 25.142, 25.331, 25.942, 25.306, 25.307, 34.122, 34.124
- 832: Completed Dec 2005, SR in RP-050662 / Text3: 25.101, 25.104, 25.113, 25.133, 25.141, 25.331, 25.942, 25.306, 25.307, 34.121
- 833: Completed Dec 2005; SR in RP-050824 / Text3: 25.101, 25.104, 25.113, 25.133, 25.141, 25.306, 25.307, 25.331, 34.121
- 834: RP#36 (May 2007) completed. SR in RP-070281 / Text3: 25.101, 25.963
- 835: Completed Mar 2006, SR in RP-060015 / Text3: 25.101

| ID | WBS | Task | Type | Duration | Start | Finish | Complete | Baseline start | Baseline finish | Baseline duration | Constraint | Deadline | Resources | Work | Actual work | Text1 | Text4 | Text5 | Text6 | Text8 | Text12 | Text10 |
| --- | --- | --- | --- | --- | --- | --- | --- | --- | --- | --- | --- | --- | --- | --- | --- | --- | --- | --- | --- | --- | --- | --- |
| 836 | 1.244.9 | **Additional minimum UE performance requirement for non-HSDPA channels based on type 1 enhanced receiver (Rx Diversity)** |  | 327d? | 2005-09-15 A | 2006-12-15 A | 100% | 2005-09-15 | 2006-12-15 | 327d? |  |  | R4 | 7344h | 7344h | RInImp-RxDiv | Qualcomm | Serge Willenegger (sergew@qualcomm.com) | Rel-7 | Stefania |  |  |
| 837 | 1.244.9.1 | Additional minimum UE performance requirement for DL physical channels in support of DCH/HS-DSCH operation based on type 1 enhanced receiver (RX-Diversity) |  | 195d? | 2005-09-15 A | 2006-06-14 A | 100% | 2005-09-15 | 2006-06-14 | 195d? | finish no earlier than 2006-06-15 |  | R4 | 1560h | 1560h | RInImp-RxDiv-DCH | Cingular | marc.grant@cingular.com | Rel-7 | Stefania |  |  |
| 838 | 1.244.9.2 | Additional minimum UE performance requirement for downlink physical channels in support of MTCH and MCCH operation based on type 1 enhanced receiver (Rx-Diversity) |  | 198d? | 2006-03-15 A | 2006-12-15 A | 100% | 2006-03-15 | 2006-12-15 | 198d? | finish no earlier than 2006-12-15 |  | R4 | 1584h | 1584h | RInImp-RxDiv-MBMS | Qualcomm | Serge Willenegger (sergew@qualcomm.com) | Rel-7 | Stefania |  |  |
| 839 | 1.244.9.3 | Additional minimum UE performance requirement for downlink physical channels in support of E-DCH operation based on type 1 enhanced receiver (Rx-Diversity) |  | 198d? | 2006-03-15 A | 2006-12-15 A | 100% | 2006-03-15 | 2006-12-15 | 198d? | finish no earlier than 2006-12-15 |  | R4 | 1584h | 1584h | RInImp-RxDiv-EDCH | Qualcomm | Serge Willenegger (sergew@qualcomm.com) | Rel-7 | Stefania |  |  |
| 840 | 1.244.10 | Deleted Improved support of gaming over HSDPA/EDCH |  | 262d? | 2005-12-15 A | 2006-12-15 A | 100% | 2005-12-15 | 2006-12-15 | 262d? | finish no earlier than 2006-12-15 |  | R2 | 2096h | 2096h | RInImp-Gaming | Cingular | don.zelmer@cingular.com | Rel-7 | MCC_RAN | RP-34 |  |
| 841 | 1.244.11 | Deleted (not approved at PCG) - UMTS 2.6 GHz FDD DL External | milestone | 0d? | 2005-09-15 A | 2005-09-15 A | 100% | 2005-09-15 | 2005-09-15 | 0d? | finish no earlier than 2005-09-15 |  | R4 |  |  | RInImp-UMTS2600Ext | T-mobile | han.van.bussel@t-mobile.de | Rel-7 | Stefania | RP-31 |  |
| 842 | 1.245 | **Rel-7 Improvements of the Radio Interface - UE Conformance Testing** |  | 741d? | 2005-11-11 A | 2008-09-12 A | 100% | 2005-11-11 | 2008-09-12 | 741d? |  |  | R5 | 17568h | 17568h | RInImp-UEConTest |  |  | Rel-7 | Ingbert |  |  |
| 843 | 16.5.1 | UE conformance testing for UMTS 2600 MHz |  | 146d | 2005-11-11 A | 2006-06-02 A | 100% | 2005-11-11 | 2006-06-02 | 146d | finish no earlier than 2006-06-02 | 2006-06-02 | R5 | 1168h | 1168h | RInImp-UMTS2600_Test | Nokia | Aleksi Heino | Rel-7 | Ingbert |  | Fri 7/11/05 |
| 844 | 16.5.1 | UE Conformance Test for UMTS 900 MHz (band VIII) |  | 146d | 2005-11-11 A | 2006-06-02 A | 100% | 2005-11-11 | 2006-06-02 | 146d | finish no earlier than 2006-06-02 | 2006-06-02 | R5 | 1168h | 1168h | RInImp-UMTS900_Test | Qualcomm | hanye@qualcomm.com | Rel-7 | Ingbert |  | Fri 11/03/05 |
| 845 | 1.245.3 | Conformance Test Aspects – Improved Performance of HSDPA Receiver type 3 |  | 191d? | 2006-03-10 A | 2006-12-01 A | 100% | 2006-03-10 | 2006-12-01 | 191d? | finish no earlier than 2006-12-01 |  | R5 | 1528h | 1528h | RInImp-HSPerf-Type3_Test | Motorola | carolyn.taylor@motorola.com | Rel-7 | Ingbert |  |  |
| 846 | 1.245.4 | UE antenna Over The Air (OTA) conformance testing |  | 518d? | 2006-09-20 A | 2008-09-12 A | 100% | 2006-09-20 | 2008-09-12 | 518d? | finish no earlier than 2008-09-12 |  | R5 | 4144h | 4144h | RInImp-UEAnt_Test | Nokia | Aleksi.Heino@nokia.com | Rel-7 | Ingbert |  |  |
| 847 | 1.245.5 | UE conformance testing for FDD Inter-Band Operation |  | 131d? | 2006-06-02 A | 2006-12-01 A | 100% | 2006-06-02 | 2006-12-01 | 131d? | finish no earlier than 2006-12-01 |  | R5 | 1048h | 1048h | RInImp-InterBand_Test | NEC, Motorola | Jacob.John@motorola.com | Rel-7 | Ingbert |  |  |
| 848 | 1.245.6 | Conformance Test Aspects – Extended UMTS 1.7/2.1 GHz |  | 131d? | 2006-12-01 A | 2007-06-01 A | 100% | 2006-12-01 | 2007-06-01 | 131d? | finish no earlier than 2007-06-01 |  | R5 | 1048h | 1048h | RInImp-UEConTest_UMTS1721Ext | Motorola | carolyn.taylor@motorola.com | Rel-7 | Ingbert |  |  |
| 849 | 1.245.7 | Conformance Test Aspects – Minimum UE performance requirement for downlink physical channels in support of E-DCH operation based on type 1 enhanced receiver (Rx-Diversity) |  | 136d? | 2007-06-01 A | 2007-12-07 A | 100% | 2007-06-01 | 2007-12-07 | 136d? | finish no earlier than 2007-12-07 |  | R5 | 1088h | 1088h | RInImp-UEConTest_RxDivEDCH | Motorola | carolyn.taylor@motorola.com | Rel-7 | Ingbert |  |  |
| 850 | 1.245.8 | Conformance Test Aspects – Minimum UE performance requirement for downlink physical channels in support of MTCGH and MCCH operation based on type 1 enhanced receiver (Rx-Diversity) |  | 201d? | 2007-06-01 A | 2008-03-07 A | 100% | 2007-06-01 | 2008-03-07 | 201d? | finish no earlier than 2008-03-07 |  | R5 | 1608h | 1608h | RInImp-UEConTest_RxDivMBMS | Ericsson | leif.mattisson@ericsson.com | Rel-7 | Ingbert |  |  |
| 851 | 1.246 | **Rel-7 RAN improvements** |  | 653d? | 2004-12-15 A | 2007-06-15 A | 100% | 2004-12-15 | 2007-06-15 | 653d? |  |  | RP | 29920h | 29920h | RANimp |  |  | Rel-7 | Juergen |  |  |
| 852 | 1.246.1 | Optimisation of channelisation code utilisation for 1.28 Mcps TDD |  | 523d? | 2004-12-15 A | 2006-12-15 A | 100% | 2004-12-15 | 2006-12-15 | 523d? | finish no earlier than 2006-12-15 |  | R1 | 4184h | 4184h | RANimp-RABSE-CodOptLCRTDD | UTStarcom | Ka Leong Lo (kaleong.lo@UTSTAR.COM) | Rel-7 | Patrick |  |  |
| 853 | 1.246.2 | Delay optimisation for procedures applicable to CS and PS Connections |  | 394d? | 2005-03-15 A | 2006-09-15 A | 100% | 2005-03-15 | 2006-09-15 | 394d? | finish no earlier than 2006-09-15 |  | R2 | 3152h | 3152h | RANimp-DelayOpt | Nokia | juho.pirskanen@nokia.com | Rel-7 | Joern |  |  |
| 854 | 1.246.3 | Improved support of IMS Realtime Services using HSDPA/HSUPA |  | 197d? | 2005-03-15 A | 2005-12-14 A | 100% | 2005-03-15 | 2005-12-14 | 197d? | start no earlier than 2005-03-15 |  | R2 | 1576h | 1576h | RANimp-IMSRealTime | Cingular | don.zelmer@CINGULAR.COM | Rel-7 | Joern |  |  |
| 855 | 1.246.4 | UE Performance Requirements for MBMS (TDD) |  | 328d? | 2005-03-15 A | 2006-06-15 A | 100% | 2005-03-15 | 2006-06-15 | 328d? | finish no earlier than 2006-06-15 |  | R4 | 2624h | 2624h | MBMS-RAN-RF-TDD | IPwireless | shwong@ipwireless.com | Rel-7 | Stefania |  |  |
| 856 | 1.246.5 | Continuous connectivity for packet data users |  | 524d? | 2005-03-14 A | 2007-03-15 A | 100% | 2005-03-14 | 2007-03-15 | 524d? | finish no earlier than 2007-03-15 |  | R1 | 4192h | 4192h | RANimp-CPC | Siemens | Joern.Krause@siemens.com | Rel-7 | Patrick |  |  |
| 857 | 1.246.6 | Extended WCDMA Cell Range |  | 198d? | 2006-03-15 A | 2006-12-15 A | 100% | 2006-03-15 | 2006-12-15 | 198d? | finish no earlier than 2006-12-15 |  | R3 | 1584h | 1584h | RANimp-ExtCell | Ericsson | Muhammad Kazmi | Rel-7 | Juergen |  |  |
| 858 | 1.246.7 | 7.68 Mcps TDD Enhanced Uplink |  | 198d? | 2006-03-15 A | 2006-12-15 A | 100% | 2006-03-15 | 2006-12-15 | 198d? | finish no earlier than 2006-12-15 |  | R1 | 1584h | 1584h | RANimp-VHCRTDD-EDCH | IPwireless | nanderson@ipwireless.com | Rel-7 | Patrick |  |  |
| 859 | 1.246.8 | Enhanced CELL_FACH State in FDD |  | 181d? | 2006-09-25 A | 2007-06-04 A | 100% | 2006-09-25 | 2007-06-04 | 181d? | finish no earlier than 2007-06-04 |  | R2 | 1448h | 1448h | RANimp-EnhState | Nokia | juho.pirskanen@nokia.com | Rel-7 | Joern |  |  |
| 860 | 1.246.9 | 64QAM for HSDPA (FDD) |  | 110d? | 2006-12-15 A | 2007-06-04 A | 100% | 2006-12-15 | 2007-06-04 | 110d? | finish no earlier than 2007-06-04 |  | R1 | 880h | 880h | RANimp-64QamDownlink | Ericsson | Johan.Bergman@ericsson.com | Rel-7 | Patrick |  |  |
| 861 | 1.246.10 | Improved L2 support for high data rates |  | 122d? | 2006-12-15 A | 2007-06-04 A | 100% | 2006-12-15 | 2007-06-04 | 122d? | finish no earlier than 2007-06-04 |  | R2 | 976h | 976h | RANimp-L2DataRates | Ericsson | Janne.Peisa@ericsson.com | Rel-7 | Joern |  |  |
| 862 | 1.246.11 | Introduction of 16QAM in HSUPA (FDD) |  | 110d? | 2006-12-15 A | 2007-06-04 A | 100% | 2006-12-15 | 2007-06-04 | 110d? | finish no earlier than 2007-06-04 |  | R1 | 880h | 880h | RANimp-16QamUplink | Nokia | karri.ranta-aho@nokia.com | Rel-7 | Patrick |  |  |

Notes:
- 836: BB contains 3 WTs / Text3: 25.101
- 837: Completed Jun 2006, SR in RP-060235 / Text3: 25.101
- 838: Completed Dec 2006, SR in RP-060678 / Text3: 25.101
- 839: Completed Dec 2006, SR in RP-060679 / Text3: 25.101
- 840: RP#34 (Dec 2006) stopped. SR in RP-060680
- 841: This item was conditionnaly approved pending decision of PCG 16 who decided not to approve it / Text3: 25.101, 25.104, 25.133, 25.141, 25.331, 25.942, 25.306, 25.307, 34.121
- 842: 05/08: Linked to Feature UID_20028 (RInImp)
- 843: Text3: 34.108, 34.121
- 844: Text3: 34.108, 34.121
- 845: Text3: 34.121, 34.108
- 846: SR in RP-080535. RP#41 completed (GERAN aspects might need to be included later) / Text3: 34.114
- 847: Text3: 34.108, 34.123-1, 34.123-2, 34.123-3
- 848: Text3: 34.108, 34.121-1, 34.121-2
- 850: SR in RP-080056
- 851: Generic feature
- 852: Completed Dec 2006; SR in RP-060682
- 853: Completed Sep 2006; SR in RP-060453 / Text3: 25.815, 25.321, 25.322, 25.331
- 854: Closed Dec 2005; SR in RP-050667
- 855: Completed Sep 2006; SR in RP-060477 / Text3: 25.102, 25.123
- 856: Completed at Mar 2007; SR in RP-070033 / Text3: 25.903, 25.201, 25.211, 25.212, 25.214, 25.308, 25.321, 25.331, 25.423, 25.433, 25.101, 25.133
- 857: Completed Dec 2006; SR in RP-060685 / Text3: 25.133, 25.423, 25.425, 25.433, 25.435, 25.453, 25.331
- 858: Completed Dec 2006; SR in RP-060684 / Text3: 25.201, 25.202, 25.221, 25.222, 25.223, 25.224, 25.225, 25.331, 23.321, 25.306, 25.302, 25.401, 25.420, 25.423, 25.427, 25.433, 25.102, 25.105, 25.142
- 859: Completed May 2007; SR in RP-070286 / Text3: 25.308, 25.304, 25.306, 25.321, 25.331, 25.433, 25.435, 25.423, 25.425,
- 860: Completed May 2007; SR in RP-070287 / Text3: 25.308, 25.211, 25.212, 25.213, 25.306, 25.331, 25.433, 25.435, 25.423, 25.425, 25.101, 25.104, 25.141
- 861: Completed May 2007; SR in RP-070289 / Text3: 25.301, 25.308,25.306, 25.321, 25.322, 25.331, 25.433, 25.435, 25.423, 25.425, 25.999
- 862: Completed May 2007; SR in RP-070288 / Text3: 25.319, 25.101, 25.104, 25.133, 25.141, 25.211, 25.212, 25.213, 25.214, 25.306, 25.321, 25.331, 25.423, 25.433

| ID | WBS | Task | Duration | Start | Finish | Complete | Remaining | Baseline start | Baseline finish | Baseline duration | Total slack | Constraint | Resources | Work | Actual work | Text1 | Text4 | Text5 | Text6 | Text8 |
| --- | --- | --- | --- | --- | --- | --- | --- | --- | --- | --- | --- | --- | --- | --- | --- | --- | --- | --- | --- | --- |
| 863 | 1.246.12 | **Interface to control Tower Mounted Amplifiers (TMAs)** | 101d? | 2007-01-26 A | 2007-06-15 A | 100% |  | 2007-01-26 | 2007-06-15 | 101d? |  |  | R3 | 1616h | 1616h | RANImp-TMA | Vodafone | alexej.kulakov@vodafone.com | Rel-7 | Juergen |
| 864 | 1.246.12.1 | OAM aspects to Interface to control TMAs | 101d? | 2007-01-26 A | 2007-06-15 A | 100% |  | 2007-01-26 | 2007-06-15 | 101d? |  | finish no earlier than 2007-06-15 | S5 | 808h | 808h | RANImp-TMA-OAM | Vodafone | Adrian.Neal@vodafone.com | Rel-7 | Adrian |
| 865 | 1.247 | **Rel-7 RAN improvements - UE Conformance Testing** | 648d? | 2006-09-20 A | 2009-03-13 | 97% | 22.58d? | 2006-09-20 | 2009-03-13 | 648d? | 260d |  | R5 | 23296h | 20512.8h | RANimp-UEConTest |  |  | Rel-7 | Ingbert |
| 866 | 1.247.1 | Conformance Test Aspects - 3.84 Mcps and 7.68 Mcps TDD Enhanced Uplink | 518d? | 2006-09-20 A | 2008-09-12 A | 100% |  | 2006-09-20 | 2008-09-12 | 518d? |  | finish no earlier than 2008-09-12 | R5 | 4144h | 4144h | RANimp-UEConTest_EDCHTDH | IPWireless | tspeight@ipwireless.com | Rel-7 | Ingbert |
| 867 | 1.247.2 | Conformance Test Aspects – 64QAM for HSDPA (FDD) | 257d? | 2007-03-09 A | 2008-03-03 A | 100% |  | 2007-03-09 | 2008-03-03 | 257d? |  | finish no earlier than 2008-03-03 | R5 | 2056h | 2056h | RANimp-UEConTest_64QamDownlink | Ericsson | leif.mattisson@ericsson.com | Rel-7 | Ingbert |
| 868 | 1.247.3 | Conformance Test Aspects – 16QAM for HSUPA (FDD) | 321d? | 2007-03-09 A | 2008-05-30 A | 100% |  | 2007-03-09 | 2008-05-30 | 321d? |  | finish no earlier than 2008-05-30 | R5 | 2568h | 2568h | RANimp-UEConTest_16QamUplink | Motorola | carolyn.taylor@motorola.com | Rel-7 | Ingbert |
| 869 | 1.247.4 | Conformance Test Aspects – Improved L2 support for high data rates | 321d? | 2007-03-09 A | 2008-05-30 A | 100% |  | 2007-03-09 | 2008-05-30 | 321d? |  | finish no earlier than 2008-05-30 | R5 | 2568h | 2568h | RANimp-UEConTest_L2DataRates | Ericsson | leif.mattisson@ericsson.com | Rel-7 | Ingbert |
| 870 | 1.247.5 | Conformance Test Aspects – Continuous connectivity for packet data users | 321d? | 2007-03-09 A | 2008-05-30 A | 100% |  | 2007-03-09 | 2008-05-30 | 321d? |  | finish no earlier than 2008-05-30 | R5 | 2568h | 2568h | RANimp-UEConTest_CPC | Nokia | jarkko.hellsten@nokia.com | Rel-7 | Ingbert |
| 871 | 1.247.6 | Conformance Test Aspects – Enhanced CELL_FACH state in FDD | 526d? | 2007-03-09 A | 2009-03-13 | 85% | 78.9d? | 2007-03-09 | 2009-03-13 | 526d? | 260d | finish no earlier than 2009-03-13 | R5 | 4208h | 3576.8h | RANimp–UEConTest_EnhancedCellFACHState | Nokia | jarkko.hellsten@nokia.com | Rel-7 | Ingbert |
| 872 | 1.248 | **7.68Mcps TDD option** | 457d? | 2004-09-15 A | 2006-06-15 A | 100% |  | 2004-09-15 | 2006-06-15 | 457d? |  |  | RP | 19824h | 19824h | VHCRTDD | IPwireless | Martin Beale (mbeale@ipwireless.com) | Rel-7 | Juergen |
| 873 | 1.248.1 | VHCRTDD: Stage 2 | 391d? | 2004-09-15 A | 2006-03-15 A | 100% |  | 2004-09-15 | 2006-03-15 | 391d? |  | finish no earlier than 2006-03-15 | R1 | 3128h | 3128h | VHCRTDD-Stage2 | IPwireless | Martin Beale (mbeale@ipwireless.com) | Rel-7 | MCC_RAN |
| 874 | 1.248.2 | VHCRTDD: Physical Layer | 391d? | 2004-09-15 A | 2006-03-15 A | 100% |  | 2004-09-15 | 2006-03-15 | 391d? |  | finish no earlier than 2006-03-15 | R1 | 3128h | 3128h | VHCRTDD-Phys | IPwireless | Martin Beale (mbeale@ipwireless.com) | Rel-7 | MCC_RAN |
| 875 | 1.248.3 | VHCRTDD: Layer 2 and layer 3 protocol aspects | 391d? | 2004-09-15 A | 2006-03-15 A | 100% |  | 2004-09-15 | 2006-03-15 | 391d? |  | finish no earlier than 2006-03-15 | R2 | 3128h | 3128h | VHCRTDD-L23 | IPwireless | drichards@ipwireless.com | Rel-7 | MCC_RAN |
| 876 | 1.248.4 | VHCRTDD: UTRAN Iub/Iur Protocol Aspects | 391d? | 2004-09-15 A | 2006-03-15 A | 100% |  | 2004-09-15 | 2006-03-15 | 391d? |  | finish no earlier than 2006-03-15 | R3 | 3128h | 3128h | VHCRTDD-IurIub | IPwireless | Peter Legg (plegg@ipwireless.com) | Rel-7 | MCC_RAN |
| 877 | 1.248.5 | VHCRTDD: RF Radio Transmission/ Reception, System Performance Requirements and Conformance Testing | 457d? | 2004-09-15 A | 2006-06-15 A | 100% |  | 2004-09-15 | 2006-06-15 | 457d? |  | finish no earlier than 2006-06-15 | R4 | 3656h | 3656h | VHCRTDD-RF | IPwireless | Shin Horng Wong (shwong@ipwireless.com) | Rel-7 | MCC_RAN |
| 878 | 1.249 | **3.84 Mcps TDD Enhanced Uplink** | 394d? | 2005-03-15 A | 2006-09-15 A | 100% |  | 2005-03-15 | 2006-09-15 | 394d? |  |  | RP | 18384h | 18384h | EDCHTDD | IPwireless | nanderson@ipwireless.com | Rel-7 | Juergen |
| 879 | 1.249.1 | EDCHTDD: Stage 2 | 328d? | 2005-03-15 A | 2006-06-15 A | 100% |  | 2005-03-15 | 2006-06-15 | 328d? |  | finish no earlier than 2006-06-15 | R2 | 2624h | 2624h | EDCHTDD-Stage2 | IPwireless | nanderson@ipwireless.com | Rel-7 | MCC_RAN |
| 880 | 1.249.2 | EDCHTDD: Physical Layer | 394d? | 2005-03-15 A | 2006-09-15 A | 100% |  | 2005-03-15 | 2006-09-15 | 394d? |  | finish no earlier than 2006-09-15 | R1 | 3152h | 3152h | EDCHTDD-Phys | IPwireless | nanderson@ipwireless.com | Rel-7 | MCC_RAN |
| 881 | 1.249.3 | EDCHTDD: Layer 2 and 3 Protocol Aspects | 394d? | 2005-03-15 A | 2006-09-15 A | 100% |  | 2005-03-15 | 2006-09-15 | 394d? |  | finish no earlier than 2006-09-15 | R2 | 3152h | 3152h | EDCHTDD-L23 | IPwireless | drichards@ipwireless.com | Rel-7 | MCC_RAN |
| 882 | 1.249.4 | EDCHTDD: UTRAN Iub/Iur Protocol Aspects | 394d? | 2005-03-15 A | 2006-09-15 A | 100% |  | 2005-03-15 | 2006-09-15 | 394d? |  | finish no earlier than 2006-09-15 | R3 | 3152h | 3152h | EDCHTDD-IurIub | Interdigital | jim.miller@interdigital.com | Rel-7 | MCC_RAN |
| 883 | 1.249.5 | EDCHTDD: RF Radio Transmission/ Reception, System Performance Requirements and Conformance Testing | 394d? | 2005-03-15 A | 2006-09-15 A | 100% |  | 2005-03-15 | 2006-09-15 | 394d? |  | finish no earlier than 2006-09-15 | R4 | 3152h | 3152h | EDCHTDD-RF | IPwireless | Shin Horng Wong (shwong@ipwireless.com) | Rel-7 | MCC_RAN |
| 884 | 1.250 | **1.28 Mcps TDD Enhanced Uplink** | 328d? | 2006-03-15 A | 2007-06-15 A | 100% |  | 2006-03-15 | 2007-06-15 | 328d? |  |  | RP | 11536h | 11536h | LCRTDD-EDCH | CATT | Haijing Hu | Rel-7 | Juergen |
| 885 | 1.250.1 | 1.28 Mcps TDD Enhanced Uplink: Physical Layer | 262d? | 2006-03-15 A | 2007-03-15 A | 100% |  | 2006-03-15 | 2007-03-15 | 262d? |  | finish no earlier than 2007-03-15 | R1 | 2096h | 2096h | LCRTDD-EDCH-Phys | CATT | Ke Wang | Rel-7 | MCC_RAN |
| 886 | 1.250.2 | 1.28 Mcps TDD Enhanced Uplink: Layer 2 and 3 Protocol Aspects | 262d? | 2006-03-15 A | 2007-03-15 A | 100% |  | 2006-03-15 | 2007-03-15 | 262d? |  | finish no earlier than 2007-03-15 | R2 | 2096h | 2096h | LCRTDD-EDCH-L23 | CATT | Haiyang Quan | Rel-7 | MCC_RAN |
| 887 | 1.250.3 | 1.28 Mcps TDD Enhanced Uplink: UTRAN Iub/Iur Protocol Aspects | 262d? | 2006-03-15 A | 2007-03-15 A | 100% |  | 2006-03-15 | 2007-03-15 | 262d? |  | finish no earlier than 2007-03-15 | R3 | 2096h | 2096h | LCRTDD-EDCH-IubIur | CATT | Yincheng Zhang | Rel-7 | MCC_RAN |
| 888 | 1.250.4 | 1.28 Mcps TDD Enhanced Uplink: RF Radio Transmission/ Reception, System Performance Requirements and Conformance Testing | 328d? | 2006-03-15 A | 2007-06-15 A | 100% |  | 2006-03-15 | 2007-06-15 | 328d? |  | finish no earlier than 2007-06-15 | R4 | 2624h | 2624h | LCRTDD-EDCH-RF | CATT | Yuexia Song | Rel-7 | MCC_RAN |
| 889 | 1.251 | 1.28 Mcps TDD Enhanced Uplink - UE Conformance Testing | 257d? | 2007-09-20 A | 2008-09-12 A | 100% |  | 2007-09-20 | 2008-09-12 | 257d? |  | finish no earlier than 2008-09-11 | R5 | 624h | 624h | LCRTDD-EDCH-UEConTest | CATT | chenxiaozhong@datangmobile.cn | Rel-7 | Ingbert |
| 890 | 1.252 | MS Antenna Performance Evaluation Method and Requirements | 731d? | 2005-01-28 A | 2007-11-16 A | 100% |  | 2005-01-28 | 2007-11-16 | 731d? |  | finish no earlier than 2007-11-16 | GP | 5848h | 5848h | APEMR | TeliaSonera | Ulf.Tegth@teliasonera.com | Rel-7 | Paolo |

Notes:
- 863: Completed Mar 2007; SR in RP-070140
- 864: SA#36 Jun 2007 completed / Text3: 32.642/3/5 – Align with RAN 25.466
- 865: 05/08: Linked to Feature UID_20029 (RANimp)
- 866: SR in RP-080536. RP#41 completed / Text3: 34.108, 34.122, 34.123-1, 34.123-2, 34.123-3
- 867: SR in RP-080059. RP#39 completed. / Text3: 34.108, 34.121-1, 34.121-2, 34.123-1, 34.123-2, 34.123-3
- 868: SR in RP-080281. RP#40 completed / Text3: 34.108, 34.121-1, 34.121-2, 34.123-1, 34.123-2, 34.123-3
- 869: SR in RP-080256. RP#40 completed / Text3: 34.108, 34.123-1, 34.123-2, 34.123-3
- 870: SR in RP-080282. RP#40 completed / Text3: 34.108, 34.121-1, 34.121-2, 34.123-1, 34.123-2, 34.123-3
- 871: SR in RP-080820. RP#41 WID Updated RP-070425=>RP-080730. Target completion 09/08=>03/09 / Text3: 34.108, 34.123-1, 34.123-2, 34.123-3
- 872: Completed Dec 2006, SR in RP-060684
- 873: Feature completed and closed at RP#33 with the presentation of the test WI / Text3: 25.202
- 874: Feature completed and closed at RP#33 with the presentation of the test WI / Text3: 25.221, 25.222, 25.223, 25.224,25.225
- 875: Feature completed and closed at RP#33 with the presentation of the test WI / Text3: 25.301, 25.302, 25.305, 25.306, 25.321, 25.331
- 876: Feature completed and closed at RP#33 with the presentation of the test WI / Text3: 25.401, 25.420, 25.423, 25.425, 25.427, 25.430, 25.433, 25.435
- 877: Feature completed and closed at RP#33 with the presentation of the test WI / Text3: 25.102, 25.105, 25.123, 25.133, 25.142
- 878: Completed Sep 2006, SR in RP-060462
- 880: Text3: 25.201, 25.221,25.222, 25.223, 25.224, 25.225
- 881: Text3: 25.301, 25.302, 25.306, 25.321, 25.331
- 882: Text3: 25.401, 25.420, 25.423, 25.427, 25.430, 25.433, 25.435
- 883: Text3: 25.102, 25.105, 25.123, 25.142
- 884: Completed May 2007; SR in RP-070038 and RP-070296
- 885: Text3: 25.201, 25.221, 25.222, 25.223, 25.224, 25.225
- 886: Text3: 25.301, 25.302, 25.306, 25.321, 25.331
- 887: Text3: 25.401, 25.420, 25.423, 25.425, 25.427, 25.430, 25.433, 25.435
- 888: Text3: 25.102, 25.105, 25.123, 25.142
- 889: UID_350046->350146. 05/08: Linked to Feature UID_20055 (LCRTDD-EDCH). SR in RP-080539. RP#41 completed / Text3: 34.108, 34.122, 34.123-1/2/3
- 890: GP#36 completed for R7 / Text3: 25.914, 25.144, 45.005

| ID | WBS | Task | Type | Duration | Start | Finish | Complete | Remaining | Baseline start | Baseline finish | Baseline duration | Total slack | Constraint | Resources | Work | Actual work | Text1 | Text4 | Text5 | Text6 | Text8 | Text12 |
| --- | --- | --- | --- | --- | --- | --- | --- | --- | --- | --- | --- | --- | --- | --- | --- | --- | --- | --- | --- | --- | --- | --- |
| 891 | 1.253 | **Lower 700 MHz Inclusion in the GERAN Specifications** |  | 390d? | 2005-01-03 A | 2006-06-30 A | 100% |  | 2005-01-03 | 2006-06-30 | 390d? |  |  | GP | 7632h | 7632h | GSM710 | UTC | dcotton@mtview.union-tel.com | Rel-7 | Paolo |  |
| 892 | 1.253.1 | Inclusion of the 698 – 746 MHz band into GERAN core specifications |  | 129d? | 2005-01-03 A | 2005-06-30 A | 100% |  | 2005-01-03 | 2005-06-30 | 129d? |  | finish no earlier than 2005-06-30 | G1 | 1032h | 1032h | GSM710-core |  |  | Rel-7 | Paolo |  |
| 893 | 1.253.2 | G1 aspects of GSM710 |  | 217.5d? | 2005-08-31 A | 2006-06-30 A | 100% |  | 2005-08-31 | 2006-06-30 | 217.5d? |  | finish no earlier than 2006-06-30 | G1 | 1740h | 1740h | GSM-710-test |  |  | Rel-7 | Paolo |  |
| 894 | 1.253.3 | G3 aspects of GSM710 |  | 217.5d? | 2005-08-31 A | 2006-06-30 A | 100% |  | 2005-08-31 | 2006-06-30 | 217.5d? |  | finish no earlier than 2006-06-30 | G3 | 1740h | 1740h | GSM-710-test |  |  | Rel-7 | Stoyan |  |
| 895 | 1.254 | **Support of Conversational Services in A/Gb mode via the PS domain** |  | 626d? | 2005-04-08 A | 2007-08-31 A | 100% |  | 2005-04-08 | 2007-08-31 | 626d? |  |  | GP | 15442.8h | 15442.8h | SCSAGB | Ericsson | gunnar.hedby@ericsson.com | Rel-7 | Paolo |  |
| 896 | 1.254.1 | Minimise the transfer delay between the SGSN and the MS |  | 604.95d? | 2005-04-08 A | 2007-08-31 A | 100% |  | 2005-04-08 | 2007-08-31 | 604.95d? |  | finish no earlier than 2007-08-31 | GP | 4839.6h | 4839.6h | SCSAGB-MTD | Ericsson | gunnar.hedby@ericsson.com | Rel-7 | Paolo |  |
| 897 | 1.254.2 | Definition of radio resource management functionality |  | 626d? | 2005-04-08 A | 2007-08-31 A | 100% |  | 2005-04-08 | 2007-08-31 | 626d? |  | finish no earlier than 2007-08-31 | G1 | 5008h | 5008h | SCSAGB-RRM | Ericsson | gunnar.hedby@ericsson.com | Rel-7 | Paolo |  |
| 898 | 1.254.3 | Support of Conversational Services in A/Gb mode via the PS domain – RLC Non-Persistent mode |  | 101d? | 2006-06-30 A | 2006-11-17 A | 100% |  | 2006-06-30 | 2006-11-17 | 101d? |  | finish no earlier than 2006-11-17 | G2 | 808h | 808h | SCSAGB-RLCNP | Ericsson | gunnar.hedby@ericsson.com | Rel-7 | Gert |  |
| 899 | 1.254.4 | Deleted- Radio Channel Support | milestone | 0d? | 2006-07-17 A | 2006-07-17 A | 100% |  | 2006-07-17 | 2006-07-17 | 0d? |  | start no earlier than 2006-07-17 | G2 |  |  | SCSAGB-RCHS | Ericsson | gunnar.hedby@ericsson.com | Rel-7 | Gert | SP-32 |
| 900 | 1.254.5 | Deleted- Modifications to FLO | milestone | 0d? | 2006-07-17 A | 2006-07-17 A | 100% |  | 2006-07-17 | 2006-07-17 | 0d? |  | start no earlier than 2006-07-17 | G2 |  |  | SCSAGB-FLO | Ericsson | gunnar.hedby@ericsson.com | Rel-7 | Gert | SP-32 |
| 901 | 1.255 | **Addition of new frequency band to GSM (T-GSM810)** |  | 626d? | 2005-04-08 A | 2007-08-31 A | 100% |  | 2005-04-08 | 2007-08-31 | 626d? |  |  | GP | 12112h | 12112h | TGSM810 | Huawei | chende@huawei.com | Rel-7 | Paolo |  |
| 902 | 1.255.1 | Changes to core specification |  | 106d? | 2005-04-08 A | 2005-09-02 A | 100% |  | 2005-04-08 | 2005-09-02 | 106d? |  | finish no earlier than 2005-09-02 | GP | 848h | 848h | TGSM810-Core | Huawei | chende@huawei.com | Rel-7 | Paolo |  |
| 903 | 1.255.2 | Changes to MS testing specification |  | 626d? | 2005-04-08 A | 2007-08-31 A | 100% |  | 2005-04-08 | 2007-08-31 | 626d? |  | finish no earlier than 2007-08-31 | G3 | 5008h | 5008h | TGSM810-MStest | Huawei | chende@huawei.com | Rel-7 | Stoyan |  |
| 904 | 1.255.3 | Changes to BTS testing specification |  | 156d? | 2005-04-08 A | 2005-11-11 A | 100% |  | 2005-04-08 | 2005-11-11 | 156d? |  | finish no earlier than 2005-11-11 | G1 | 1248h | 1248h | TGSM810-BTStest | Huawei | chende@huawei.com | Rel-7 | Paolo |  |
| 905 | 1.256 | **Handover of dedicated and shared resources while in dual transfer mode** |  | 421d? | 2005-04-08 A | 2006-11-17 A | 100% |  | 2005-04-08 | 2006-11-17 | 421d? |  |  | GP | 12672h | 12672h | HODSRDTM | Nokia | rami.vaittinen@nokia.com | Rel-7 | Paolo |  |
| 906 | 1.256.1 | Handover of dedicated and shared resources while in dual transfer mode |  | 321d? | 2005-04-08 A | 2006-06-30 A | 100% |  | 2005-04-08 | 2006-06-30 | 321d? |  | finish no earlier than 2006-06-30 | G2 | 2568h | 2568h | HODSRDTM-G2 | Nokia | rami.vaittinen@nokia.com | Rel-7 | Gert |  |
| 907 | 1.256.2 | MS Conformance Testing |  | 421d? | 2005-04-08 A | 2006-11-17 A | 100% |  | 2005-04-08 | 2006-11-17 | 421d? |  | finish no earlier than 2006-11-17 | G3 | 3368h | 3368h | HODSRDTM-Mstest | Nokia | rami.vaittinen@nokia.com | Rel-7 | Stoyan |  |
| 908 | 1.256.3 | BTS conformance testing |  | 421d? | 2005-04-08 A | 2006-11-17 A | 100% |  | 2005-04-08 | 2006-11-17 | 421d? |  | finish no earlier than 2006-11-17 | G1 | 3368h | 3368h | HODSRDTM-BTStest | Nokia | rami.vaittinen@nokia.com | Rel-7 | Paolo |  |
| 909 | 1.257 | **Mobile Station Receive Diversity (DARP Phase II)** |  | 526d? | 2005-11-11 A | 2007-11-16 A | 100% |  | 2005-11-11 | 2007-11-16 | 526d? |  |  | GP | 16360h | 16360h | MSRD2 | Nokia | kent.pedersen@nokia.com | Rel-7 | Paolo |  |
| 910 | 1.257.1 | Performance Requirements for Mobile Station Receive Diversity, DARP Phase II |  | 331d? | 2005-11-11 A | 2007-02-16 A | 100% |  | 2005-11-11 | 2007-02-16 | 331d? |  | finish no earlier than 2007-02-16 | GP | 2648h | 2648h | MSRD2-PerfReq | Nokia | kent.pedersen@nokia.com | Rel-7 | Paolo |  |
| 911 | 1.257.2 | Capability signalling of Mobile Station Receive Diversity, DARP Phase II |  | 331d? | 2005-11-11 A | 2007-02-16 A | 100% |  | 2005-11-11 | 2007-02-16 | 331d? |  | finish no earlier than 2007-02-16 | GP | 2648h | 2648h | MSRD2-CapSig | Nokia | kent.pedersen@nokia.com | Rel-7 | Paolo, Gert |  |
| 912 | 1.257.3 | Test Scenarios for Mobile Station Receive Diversity, DARP Phase II |  | 331d? | 2005-11-11 A | 2007-02-16 A | 100% |  | 2005-11-11 | 2007-02-16 | 331d? |  | finish no earlier than 2007-02-16 | GP | 2648h | 2648h | MSRD2-TestSc | Nokia | kent.pedersen@nokia.com | Rel-7 | Paolo |  |
| 913 | 1.257.4 | MS conformance test of DARP Phase II (MSRD) |  | 526d? | 2005-11-11 A | 2007-11-16 A | 100% |  | 2005-11-11 | 2007-11-16 | 526d? |  | finish no earlier than 2007-11-16 | GP | 4208h | 4208h | MSRD2-Msconf | Nokia | kent.pedersen@nokia.com | Rel-7 | Paolo, Stoyan |  |
| 914 | 1.258 | **Downlink Dual Carrier** |  | 741d? | 2006-01-20 A | 2008-11-21 | 73% | 196.64d? | 2006-01-20 | 2008-11-21 | 741d? | 340d |  | GP | 16152h | 10725.7h | GDCDL | Nokia Siemens Networks | leonardo.provvedi@roke.co.uk | Rel-7 | Paolo |  |
| 915 | 1.258.1 | Downlink Dual Carrier Stage 2 |  | 116d? | 2006-01-20 A | 2006-06-30 A | 100% |  | 2006-01-20 | 2006-06-30 | 116d? |  | finish no earlier than 2006-06-30 | G1 | 928h | 928h | GDCDL-Stage2 | Nokia Siemens Networks | leonardo.provvedi@roke.co.uk | Rel-7 | Paolo |  |
| 916 | 1.258.2 | Downlink Dual Carrier Stage 3 |  | 421d? | 2006-01-20 A | 2007-08-31 A | 100% |  | 2006-01-20 | 2007-08-31 | 421d? |  | finish no earlier than 2007-08-31 | G1 | 3368h | 3368h | GDCDL-Stage2 | Nokia Siemens Networks | leonardo.provvedi@roke.co.uk | Rel-7 | Paolo |  |
| 917 | 1.258.3 | Downlink Dual Carrier – MS Conformance Test |  | 370.5d? | 2006-01-20 A | 2008-11-21 | 35% | 240.82d? | 2006-01-20 | 2008-11-21 | 370.5d? | 340d | finish no earlier than 2008-11-21 | G2; G1 | 5928h | 2074.8h | GDCDL-Stage3 | Nokia Siemens Networks | leonardo.provvedi@roke.co.uk | Rel-7 | Ingbert |  |
| 918 | 1.259 | Support of SIGTRAN in GERAN |  | 116d? | 2006-01-20 A | 2006-06-30 A | 100% |  | 2006-01-20 | 2006-06-30 | 116d? |  | finish no earlier than 2006-06-30 | G3new | 928h | 928h | GDCDL-MStest | Ericsson | peter.ostrup@ericsson.com | Rel-7 | Paolo |  |

Notes:
- 891: Text3: 24.008, 43.022, 44.018, 44.118, 45, 001, 45.005, 51.010, 51.021
- 892: Completed / Text3: 24.008, 43.022, 44.018, 44.118, 45, 001, 45.005,
- 893: Text3: 51.021
- 894: Text3: 51.010
- 895: Originally started Nov. 2003 as GP-030443
- 898: Text3: 43.955, 43.064, 44.060, 45.001, 45.002, 45.003, 45.005, 45.010, 51.010, 51.021
- 901: Text3: 45.005, 45.050, 24.008, 45.008, 45.001, 43.022, 43.030, 44.018, 44.060, 51.010-1, 51.021
- 902: Text3: 45.005, 45.050, 24.008, 45.008, 45.001, 43.022, 43.030, 44.018, 44.060
- 903: Text3: 51010-1
- 904: Text3: 51021
- 905: Started at GERP#24
- 906: Started at GERP#24 / Text3: 43.055, 44.018, 44.060
- 907: Stopped, no work done / Text3: 51-010
- 908: Stopped, no work done / Text3: 51.026
- 909: GP#37 completed. / Text3: 24.008, 45.005, 51.010
- 910: Text3: 45.005
- 911: Text3: 24.008
- 912: Text3: 45.005
- 913: Text3: 51.010
- 914: GP#30 completed / Text3: 24.008, 43.055, 43.064, 44.018, 44.060, 45.001, 45.002, 45.005, 45.008, 51.010
- 915: GP#35 completed / Text3: 43.055, 43.064
- 916: Text3: 24.008, 44.018, 44.060, 45.001, 45.002, 45.005, 45.008
- 917: GP#40 target completion 11/08=>09/09 / Text3: 51.010
- 918: Text3: 48.001, 48.006, 43.059, 49.031

| ID | WBS | Task | Type | Duration | Start | Finish | Complete | Remaining | Baseline start | Baseline finish | Baseline duration | Total slack | Constraint | Resources | Work | Actual work | Text1 | Text4 | Text5 | Text6 | Text8 | Text12 |
| --- | --- | --- | --- | --- | --- | --- | --- | --- | --- | --- | --- | --- | --- | --- | --- | --- | --- | --- | --- | --- | --- | --- |
| 919 | 1.260 | **Latency Reductions** |  | 306d? | 2006-06-30 A | 2007-08-31 A | 100% |  | 2006-06-30 | 2007-08-31 | 306d? |  |  | GP | 7344h | 7344h | LATRED | Ericsson | Hakan.Persson@Ericsson.com | Rel-7 | Paolo |  |
| 920 | 1.260.1 | Improved Ack/Nack reporting |  | 306d? | 2006-06-30 A | 2007-08-31 A | 100% |  | 2006-06-30 | 2007-08-31 | 306d? |  | finish no earlier than 2007-08-31 | G2 | 2448h | 2448h | LATRED-ACKNAR | Ericsson | Hakan.Persson@Ericsson.com | Rel-7 | Gert |  |
| 921 | 1.260.2 | Reduced TTI |  | 306d? | 2006-06-30 A | 2007-08-31 A | 100% |  | 2006-06-30 | 2007-08-31 | 306d? |  | finish no earlier than 2007-08-31 | G2 | 2448h | 2448h | LATRED-REDTTI | Ericsson | Hakan.Persson@Ericsson.com | Rel-7 | Gert |  |
| 922 | 1.261 | PS Handover between GERAN/UTRAN mode and GAN Mode |  | 166d? | 2006-06-30 A | 2007-02-16 A | 100% |  | 2006-06-30 | 2007-02-16 | 166d? |  | finish no earlier than 2007-02-16 | G2 | 1328h | 1328h | GUGAN | Ericsson | John.Diachina@Ericsson.com | Rel-7 | Gert |  |
| 923 | 1.262 | **Higher Uplink performance for GERAN Evolution** |  | 641d? | 2006-09-08 A | 2009-02-20 | 74% | 167.64d? | 2006-09-08 | 2009-02-20 | 641d? | 275d |  | GP | 26696h | 16077.8h | HUGE | Nokia Siemens Networks, Ericsson | eddie.riddington@nokia.com, stefan.g.eriksson@ericsson.com | Rel-7 | Paolo |  |
| 924 | 1.262.1 | Stage 2 of HUGE |  | 261d? | 2006-09-08 A | 2007-09-07 A | 100% |  | 2006-09-08 | 2007-09-07 | 261d? |  | finish no earlier than 2007-09-07 | G1 | 2088h | 2088h | HUGE-Stage2 | Nokia Siemens Networks, Ericsson | eddie.riddington@nokia.com, stefan.g.eriksson@ericsson.com | Rel-7 | Paolo |  |
| 925 | 1.262.2 | Layer 1 Support of HUGE |  | 381d? | 2006-09-08 A | 2008-02-22 A | 100% |  | 2006-09-08 | 2008-02-22 | 381d? |  | finish no earlier than 2008-02-22 | G1 | 3048h | 3048h | HUGE-Layer1 | Nokia Siemens Networks, Ericsson | eddie.riddington@nokia.com, stefan.g.eriksson@ericsson.com | Rel-7 | Paolo |  |
| 926 | 1.262.3 | Layer 2/3 Support of HUGE |  | 256d? | 2006-09-08 A | 2007-08-31 A | 100% |  | 2006-09-08 | 2007-08-31 | 256d? |  | finish no earlier than 2007-08-31 | G2 | 2048h | 2048h | HUGE-Layer23 | Nokia Siemens Networks, Ericsson | eddie.riddington@nokia.com, stefan.g.eriksson@ericsson.com | Rel-7 | Gert |  |
| 927 | 1.262.4 | Performance requirements |  | 516d? | 2006-09-08 A | 2008-08-29 A | 100% |  | 2006-09-08 | 2008-08-29 | 516d? |  | finish no earlier than 2008-08-29 | G1 | 4128h | 4128h | HUGE-Perfreq | Nokia Siemens Networks, Ericsson | eddie.riddington@nokia.com, stefan.g.eriksson@ericsson.com | Rel-7 | Paolo |  |
| 928 | 1.262.5 | MS Conformance Test |  | 641d? | 2006-09-08 | 2009-02-20 |  |  | 2006-09-08 | 2009-02-20 | 641d? | 275d | finish no earlier than 2009-02-20 | G3new | 5128h |  | HUGE-Mstest | Nokia Siemens Networks, Ericsson | eddie.riddington@nokia.com, stefan.g.eriksson@ericsson.com | Rel-7 | Ingbert |  |
| 929 | 1.262.6 | BTS Conformance Test |  | 641d? | 2006-09-08 A | 2009-02-20 | 90% | 64.1d? | 2006-09-08 | 2009-02-20 | 641d? | 275d | finish no earlier than 2009-02-20 | G1 | 5128h | 4615.2h | HUGE-BTStest | Nokia Siemens Networks, Ericsson | eddie.riddington@nokia.com, stefan.g.eriksson@ericsson.com | Rel-7 | Paolo |  |
| 930 | 1.263 | **REduced symbol Duration, Higher Order modulation and Turbo coding (RED HOT) for downlink** |  | 591d? | 2006-11-17 A | 2009-02-20 | 62% | 221.92d? | 2006-11-17 | 2009-02-20 | 591d? | 275d |  | GP | 18440h | 8618.67h | REDHOT | Ericsson, Nokia Siemens Networks, Marvell | stefan.g.eriksson@ericsson.com | Rel-7 | Paolo |  |
| 931 | 1.263.1 | Stage 2 for REDHOT |  | 206d? | 2006-11-17 A | 2007-08-31 A | 100% |  | 2006-11-17 | 2007-08-31 | 206d? |  | finish no earlier than 2007-08-31 | G1 | 1648h | 1648h | REDHOT-Stage2 | Ericsson, Nokia Siemens Networks, Marvell | stefan.g.eriksson@ericsson.com | Rel-7 | Paolo |  |
| 932 | 1.263.2 | Stage 3 for REDHOT |  | 391d? | 2006-11-17 A | 2008-05-16 A | 100% |  | 2006-11-17 | 2008-05-16 | 391d? |  | finish no earlier than 2008-05-16 | G1 | 3128h | 3128h | REDHOT-Stage3 | Ericsson, Nokia Siemens Networks, Marvell | stefan.g.eriksson@ericsson.com | Rel-7 | Paolo |  |
| 933 | 1.263.3 | MS Conformance Tests |  | 591d? | 2006-11-17 | 2009-02-20 |  |  | 2006-11-17 | 2009-02-20 | 591d? | 275d | finish no earlier than 2009-02-20 | G3new | 4728h |  | REDHOT-Mstest | Ericsson | stefan.g.eriksson@ericsson.com | Rel-7 | Ingbert |  |
| 934 | 1.263.4 | BTS Conformance Tests |  | 526d? | 2006-11-17 A | 2008-11-21 | 90% | 52.6d? | 2006-11-17 | 2008-11-21 | 526d? | 340d | finish no earlier than 2008-11-21 | G1 | 4208h | 3787.2h | REDHOT-BTStest | Ericsson, Nokia Siemens Networks, Marvell | stefan.g.eriksson@ericsson.com | Rel-7 | Paolo |  |
| 935 | 1.264 | (Small) Technical Enhancements and Improvements for Rel-7 | milestone | 0d? | 2007-03-26 A | 2007-03-26 A | 100% |  | 2007-03-26 | 2007-03-26 | 0d? |  | start no earlier than 2007-03-26 | All |  |  | TEI7 |  |  | Rel-7 |  |  |
| 936 | 1.265 | **Deleted - PS domain and IMS support for IMS Emergency sessions** |  | 63.69d? | 2006-06-23 A | 2006-09-21 A | 100% |  | 2006-06-23 | 2006-09-21 | 63.69d? |  |  | S2 |  |  | IMS-EMER | Nokia | curt.c.wong@nokia.com | Rel-7 | Maurice | SP-30 |
| 937 | 1.265.1 | Deleted - IMS aspects to support IMS Emergency sessions | milestone | 0d? | 2006-06-23 A | 2006-09-21 A | 100% |  | 2006-06-23 | 2006-09-21 | 0d? |  | start no earlier than 2006-06-23 | S2 |  |  | IMS-EMER | Nokia | curt.c.wong@nokia.com | Rel-7 | Maurice | SP-30 |
| 938 | 1.265.2 | Deleted - PS domain aspects to support IMS Emergency sessions | milestone | 0d? | 2006-06-23 A | 2006-09-21 A | 100% |  | 2006-06-23 | 2006-09-21 | 0d? |  | start no earlier than 2006-06-23 | S2 |  |  | IMS-EMER | Nokia | curt.c.wong@nokia.com | Rel-7 | Maurice | SP-30 |
| 939 | 1.266 | Deleted - Covered by SI - Personal Network (PN) and Personal Area Network (PAN) | milestone | 0d? | 2005-12-08 A | 2005-12-20 A | 100% |  | 2005-12-08 | 2005-12-20 | 0d? |  | start no earlier than 2005-12-08 | S1 |  |  | PNPAN | Vodafone | armin.toepfer@vodafone.com | Rel-7 | Mike | SP-30 |
| 940 | 1.267 | Deleted - Covered by SI - Multimedia Telephony Capabilities for IMS | milestone | 0d? | 2005-12-08 A | 2005-12-20 A | 100% |  | 2005-12-08 | 2005-12-20 | 0d? |  | start no earlier than 2005-12-08 | S1 |  |  | MITE | Ericsson | peter.bleckert @ericsson.com | Rel-7 | Mike | SP-30 |
| 941 | 1.268 | Deleted - Covered by SI - Transferring of emergency Call data | milestone | 0d? | 2005-12-08 A | 2005-12-08 A | 100% |  | 2005-12-08 | 2005-12-08 | 0d? |  | start no earlier than 2005-12-08 | S1 |  |  | eCALL | Motorola | steven.vardy@motorola.com | Rel-7 | Mike | SP-30 |
| 942 | 1.269 | Deleted - Covered by SI - MBMS Enhancements | milestone | 0d? | 2005-12-08 A | 2005-12-08 A | 100% |  | 2005-12-08 | 2005-12-08 | 0d? |  | start no earlier than 2005-12-08 | S1 |  |  | MBMSE | China Mobile | liuhongyfw@chinamobile.com | Rel-7 | Mike | SP-30 |

Notes:
- 919: Text3: 45.001, 45.002, 45.003, 45.005, 45.010, 43.055, 43.064, 44.060, 51.010-1, 51.021
- 920: Text3: 45.001, 45.002, 45.003, 45.005, 45.010, 43.055, 43.064, 44.060, 51.010-1, 51.021
- 921: Text3: 45.001, 45.002, 45.003, 45.005, 45.010, 43.055, 43.064, 44.060, 51.010-1, 51.021
- 922: Text3: 43.318, 44.318, 43.129, 25.306, 24.008, 44.060, 25.331, 51.010
- 923: extension sheet in GP-071567 / Text3: 24.008, 43.055, 43.064, 44.018, 44.060, 45.001, 45.002, 45.003, 45.004, 45.005, 45.008, 45.010, 51.010, 51.021
- 924: GP#35 completed / Text3: 43.055, 43.064
- 925: GP#37 completed / Text3: 45.001, 45.002, 45.003, 45.004, 45.008
- 926: GP#35 completed / Text3: 24.008, 44.018, 44.060
- 927: GP#39 completed / Text3: 45.005
- 928: Completion target 05/08=>02/09. GP#40 stagnating at 0% / Text3: 51.010
- 929: GP#40 Target completion 05/08=>11/08=>02/09 / Text3: 51.021
- 930: extension sheet in GP-071565 / Text3: 24.008, 43.064, 43.055, 44.018, 44.060, 45.001, 45.002, 45.003, 45.004, 45.005, 45.008, 51.010, 51.021
- 931: GP#35 completed / Text3: 43.055, 43.064
- 932: GP#38 completed / Text3: 24.008, 44.018, 44.060, 45.001, 45.002, 45.003, 45.004, 45.005, 45.008
- 933: 08/08=>02/09 / Text3: 51.010
- 934: GP#40 completion target 05/08=>11/08=>02/09 / Text3: 51.021
- 935: Text3: CP-070260
- 936: Approved at SA#29 / Text3: 23.867, 23.abc, 23.060, 23.002, 23.271
- 937: Approved at SA#29 / Text3: 23.867, 23.abc, 23.060, 23.002, 23.271
- 938: Approved at SA#29 / Text3: 23.867, 23.abc, 23.060, 23.002, 23.271

| ID | WBS | Task | Type | Duration | Start | Finish | Complete | Baseline start | Baseline finish | Baseline duration | Total slack | Constraint | Resources | Work | Actual work | Text1 | Text6 | Text8 | Text12 | Text3 | Text4 | Text5 |
| --- | --- | --- | --- | --- | --- | --- | --- | --- | --- | --- | --- | --- | --- | --- | --- | --- | --- | --- | --- | --- | --- | --- |
| 943 | 1.270 | **Deleted - VoIMS bearer related enhancements** |  | 0d? | 2006-07-21 A | 2006-07-21 A | 100% | 2006-07-21 | 2006-07-21 | 0d? |  |  | S2 |  |  | VoIMS | Rel-7 | Maurice | SP-32 |  |  |  |
| 944 | 1.270.1 | Deleted - FS on enhancement of radio performance for VoIMS | milestone | 0d? | 2006-07-21 A | 2006-07-21 A | 100% | 2006-07-21 | 2006-07-21 | 0d? |  | start no earlier than 2006-07-21 | S2 |  |  | VoIMS | Rel-7 | Maurice | SP-32 | 23.807 | Nortel | Laurence Lautier (lautierl@nortel.com) |
| 945 | 1.271 | Release 7 Feasibility Studies |  | 1d? | 2000-01-03 | 2000-01-03 |  | 2000-01-03 | 2000-01-03 | 1d? | 2659d |  | CP,GP, RP,SP | 8h |  |  | Rel-7 |  |  |  |  |  |
| 946 | 1.272 | **Study on Multimedia Telephony Capabilities for IMS** |  | 276d? | 2005-07-11 A | 2006-07-31 A | 100% | 2005-07-11 | 2006-07-31 | 276d? |  |  | S1 | 4353.6h | 4353.6h | MITE | Rel-7 | Alain |  | 22.973 | Ericsson | peter.bleckert @ericsson.com |
| 947 | 1.272.1 | Deleted covered by UID_31082 - Study of (MITe) - IMS Multimedia Telephony Communication Enabler and supplementary services |  | 276d? | 2005-07-11 A | 2006-07-31 A | 100% | 2005-07-11 | 2006-07-31 | 276d? |  | start no earlier than 2005-07-11 | S1 | 2208h | 2208h | MITE | Rel-7 | Alain | SP-28 | 22.973 | Ericsson | peter.bleckert @ericsson.com |
| 948 | 1.273 | Study on Behaviour of Multi system UEs |  | 384d? | 2004-06-28 A | 2005-12-15 A | 100% | 2004-06-28 | 2005-12-15 | 384d? |  | start no earlier than 2004-06-28 | S1 | 3072h | 3072h | BMSU | Rel-7 | Alain |  | 22.936 | Qualcomm | dwilliams@qualcomm.com |
| 949 | 1.274 | Study on Combining CS calls and IMS sessions |  | 189d? | 2004-06-28 A | 2005-03-17 A | 100% | 2004-06-28 | 2005-03-17 | 189d? |  | start no earlier than 2004-06-28 | S1 | 1512h | 1512h | IRTSD-CS_IMS | Rel-7 | Alain |  | 22.979 |  | FRANK, Robert |
| 950 | 1.275 | Study on All-IP Network |  | 188d? | 2004-06-28 A | 2005-03-16 A | 100% | 2004-06-28 | 2005-03-16 | 188d? |  | start no earlier than 2004-06-28 | S1 | 1504h | 1504h | FS_AIPN | Rel-7 | Alain |  | 22.978 | NTT DoCoMo | c.masyu@nttdocomo.co.jp |
| 951 | 1.276 | Study on Videotelephony teleservice |  | 231d? | 2005-03-01 A | 2006-01-17 A | 100% | 2005-03-01 | 2006-01-17 | 231d? |  |  | S1 | 1848h | 1848h | VidTel | Rel-7 | Alain |  | 22.903 | T-Mobile | kurt.bischinger@t-mobile.at |
| 952 | 1.277 | Study on Network Selection Principles |  | 193d? | 2005-03-15 A | 2005-12-08 A | 100% | 2005-03-15 | 2005-12-08 | 193d? |  |  | S1 | 1544h | 1544h | NetSel | Rel-7 | Alain |  | 22.811 | O2 | chris.friel@o2.com |
| 953 | 1.278 | Study on Multimedia Priority Service |  | 851d? | 2003-03-28 A | 2006-06-30 A | 100% | 2003-03-28 | 2006-06-30 | 851d? |  | finish no earlier than 2005-12-16 | S1 | 6808h | 6808h | PRIOR-MM | Rel-7 | Alain |  | 22.953 | Telcordia | jgarraha@telcordia.com |
| 954 | 1.279 | Study on Transferring of emergency Call data |  | 190d? | 2005-07-11 A | 2006-03-31 A | 100% | 2005-07-11 | 2006-03-31 | 190d? |  | finish no earlier than 2005-12-08 | S1 | 1520h | 1520h | eCALL | Rel-7 | Mike |  | 22.967 | Motorola | steven.vardy@motorola.com |
| 955 | 1.280 | Study on Enhancement of E2E QoS |  | 281.4d? | 2004-06-28 A | 2005-09-15 A | 100% | 2004-06-28 | 2005-09-15 | 281.4d? |  | finish no earlier than 2005-12-01 | S2 | 2251.2h | 2251.2h | QoS7 | Rel-7 | Maurice |  | 23.802 | Huawei | Robert Jaksa |
| 956 | 1.281 | Study on Bandwidth Saving at Nb Interface with IP transport |  | 261d? | 2006-03-10 A | 2007-03-09 A | 100% | 2006-03-10 | 2007-03-09 | 261d? |  | finish no earlier than 2007-03-09 | C3 | 2088h | 2088h | BSNbIP | Rel-7 | Seung Don |  | 29.814 | Siemens | thomas.belling@siemens.com |
| 957 | 1.282 | Study on Routeing of MT-SMs via the HPLMN |  | 301d? | 2005-10-07 A | 2006-12-01 A | 100% | 2005-10-07 | 2006-12-01 | 301d? |  | finish no earlier than 2006-12-01 | C4 | 2408h | 2408h | SMS7 | Rel-7 | Kimmo |  | 23.840 | Vodafone | Nick.Russell@vodafone.com |
| 958 | 1.283 | Study on the TCAPsec Gateway concept |  | 96d? | 2005-10-28 A | 2006-03-10 A | 100% | 2005-10-28 | 2006-03-10 | 96d? |  | finish no earlier than 2006-03-10 | C4 | 768h | 768h | SEC7-TCAP | Rel-7 | Kimmo |  | 29.800 | Siemens | Ulrich.wiehe@gksag.de |
| 959 | 1.284 | Study on using M2PA in 3GPP network |  | 318d? | 2006-03-22 A | 2007-06-08 A | 100% | 2006-03-22 | 2007-06-08 | 318d? |  | finish no earlier than 2007-06-08 | C4 | 2544h | 2544h | FS-M2PA | Rel-7 | Kimmo |  | 29.801 | China Mobile | zhaoyuyi@chinamobile.com |
| 960 | 1.285 | **Study on Support of (G)MSC-S - (G)MSC-S Nc Interface based on the SIP-I protocol** |  | 350d? | 2006-05-15 A | 2007-09-14 A | 100% | 2006-05-15 | 2007-09-14 | 350d? |  |  | C4 | 7800h | 7800h | NcSIP | Rel-7 | Kimmo |  | 29.802 | Vodafone | david.hutton@vodafone.com |
| 961 | 1.285.1 | CT4 aspects of NcSIP |  | 275d? | 2006-05-15 A | 2007-06-01 A | 100% | 2006-05-15 | 2007-06-01 | 275d? |  | finish no earlier than 2007-06-01 | C4 | 2200h | 2200h | NcSIP | Rel-7 | Kimmo |  | 29.802 | Vodafone | david.hutton@vodafone.com |
| 962 | 1.285.2 | CT3 aspects of NcSIP |  | 350d? | 2006-05-15 A | 2007-09-14 A | 100% | 2006-05-15 | 2007-09-14 | 350d? |  | finish no earlier than 2007-09-14 | C3 | 2800h | 2800h | NcSIP | Rel-7 |  |  | 29.802 | Ericsson | ragnar.huslende@ericsson.com |
| 963 | 1.286 | Study on SOAP/HTTP IRP Solution Sets |  | 330d? | 2005-09-02 A | 2006-12-07 A | 100% | 2005-09-02 | 2006-12-07 | 330d? |  | finish no earlier than 2006-12-07 | S5 | 2640h | 2640h | OAM7-NIM-XML | Rel-7 | Adrian |  | 32.809 | Nortel |  |
| 964 | 1.287 | Study on Itf-N Implementation Conformance Statement (ICS) template |  | 400d? | 2005-09-02 A | 2007-03-15 A | 100% | 2005-09-02 | 2007-03-15 | 400d? |  | finish no earlier than 2007-03-15 | S5 | 3200h | 3200h | OAM7-NIM-ICS | Rel-7 | Adrian |  | 32.812 | China Mobile |  |
| 965 | 1.288 | Study on IRP Information Model |  | 400d? | 2005-09-02 A | 2007-03-15 A | 100% | 2005-09-02 | 2007-03-15 | 400d? |  | finish no earlier than 2007-03-15 | S5 | 3200h | 3200h | OAM7-NIM-IM | Rel-7 | Adrian |  | 32.810 | Motorola |  |
| 966 | 1.289 | Study on Evolved UTRA and UTRAN |  | 458d? | 2004-12-15 A | 2006-09-15 A | 100% | 2004-12-15 | 2006-09-15 | 458d? |  | finish no earlier than 2006-09-15 | RP | 3664h | 3664h | RANFS-Evo | Rel-7 | Juergen |  | 25.912 | NTT DoCoMo | nakamurata@NTTDOCOMO.CO.JP |
| 967 | 1.290 | Study on Performance Evaluation of the UE behaviour in high speed trains with speeds up to 350 kmph |  | 328d? | 2005-03-15 A | 2006-06-15 A | 100% | 2005-03-15 | 2006-06-15 | 328d? |  | finish no earlier than 2006-06-15 | R4 | 2624h | 2624h | RANFS-HSTrains | Rel-7 | Stefania |  | none | Vodafone | Mike.vogel@vodafone.com,tim.frost@vodafone.com |
| 968 | 1.291 | Study on UTRA Tower Mounted Amplifier (FDD) |  | 195d? | 2005-06-15 A | 2006-03-14 A | 100% | 2005-06-15 | 2006-03-14 | 195d? |  | finish no earlier than 2006-03-15 | R4 | 1560h | 1560h | RANFS-TMA | Rel-7 | Stefania |  | 25.818 | Ericsson | Klas.Sjerling@ericsson.com |
| 969 | 1.292 | Study on Continuous connectivity for packet data users |  | 132d? | 2005-03-15 A | 2005-09-15 A | 100% | 2005-03-15 | 2005-09-15 | 132d? |  | finish no earlier than 2005-09-15 | R1 | 1056h | 1056h | RANFS-cont-packet | Rel-7 | Patrick |  | none | Siemens | joerg.gustrau@siemens.com |
| 970 | 1.293 | Study on Improvement of the Multimedia Broadcast Multicast Service (MBMS) in UTRAN |  | 262d? | 2005-12-15 A | 2006-12-15 A | 100% | 2005-12-15 | 2006-12-15 | 262d? |  | finish no earlier than 2006-12-15 | R2 | 2096h | 2096h | RANFS-MBMSImp | Rel-7 | Joern |  | 25.905 | LG Electronics | leego@lge.com |
| 971 | 1.294 | Study on Performance Improvements in Small Cells using HSDPA/EDCH |  | 131d? | 2005-12-15 A | 2006-06-15 A | 100% | 2005-12-15 | 2006-06-15 | 131d? |  | finish no earlier than 2006-06-15 | R4 | 1048h | 1048h | SMALLCELLS | Rel-7 | Stefania |  | none | Cingular | marc.grant@cingular.com |
| 972 | 1.295 | Study on Further Improved Performance Requirements for UMTS/HSDPA UE (FDD) |  | 383d? | 2005-12-15 A | 2007-06-04 A | 100% | 2005-12-15 | 2007-06-04 | 383d? |  | finish no earlier than 2007-06-04 | R4 | 3064h | 3064h | RANFS-IC | Rel-7 | Stefania |  | 25.963 | Cingular | marc.grant@cingular.com |
| 973 | 1.296 | Study on Scope of future FDD HSPA Evolution |  | 394d? | 2006-03-15 A | 2007-09-17 A | 100% | 2006-03-15 | 2007-09-17 | 394d? |  | finish no earlier than 2007-09-17 | RP | 3152h | 3152h | RANFS-HSPAEvo | Rel-7 | Juergen |  | 25.999 | Cingular | don.zelmer@cingular.com |
| 974 | 1.297 | Study on Dynamically reconfiguring a FDD UE receiver to reduce power consumption when desired Quality of Service is met | milestone | 0d? | 2007-06-22 A | 2007-06-22 A | 100% | 2007-06-22 | 2007-06-22 | 0d? |  |  | R4 |  |  | FSUEPow | Rel-7 | Stefania |  | 25.906 | Nokia | Chris.callender@nokia.com, tiina.s.koskinen@nokia.com |
| 975 | 1.298 | Study on Future GERAN Evolution |  | 486d? | 2005-04-08 A | 2007-02-16 A | 100% | 2005-04-08 | 2007-02-16 | 486d? |  | finish no earlier than 2007-02-16 | GP | 3888h | 3888h | FGE | Rel-7 | Paolo |  | 45.912 | Nokia | eddie.riddington@nokia.com |
| 976 | 1.299 | Study on GAN Enhancements | milestone | 0d? | 2007-08-31 A | 2007-08-31 A | 100% | 2007-08-31 | 2007-08-31 | 0d? |  | start no earlier than 2007-08-31 | GP |  |  | EGAN | Rel-7 | Paolo |  | 43.902 | T-Mobile | janne.linkola@t-mobile.com |
| 977 | 1.300 | Deleted - covered by UID33027 - IMS security extensions | milestone | 0d? | 2005-12-08 A | 2005-12-08 A | 100% | 2005-12-08 | 2005-12-08 | 0d? |  | start no earlier than 2005-12-08 | S3 |  |  | IMS-SE | Rel-7 | Mike | SP-30 |  | Ericsson | Bengt.Sahlin@ericsson.com |
| 978 | 1.301 | Deleted - covered by 32108 - Study of work on an LCS architecture for I-WLAN | milestone | 0d? | 2006-12-08 A | 2006-12-08 A | 100% | 2006-12-08 | 2006-12-08 | 0d? |  | start no earlier than 2006-12-08 | S2 |  |  | IMS-SE | Rel-7 | Maurice | SP-33 |  | LG Electronics | Donghee Shim dhshim@lge.com ; phede@lge.com |

Notes:
- 943: Created by MCC to group all VoIMS related items, after consultation of chairs
- 944: WID approved SA#28: SA2#52: CLOSED - To be removed from the work plan
- 946: Spin-off Feature UID_7038 (MTSI)
- 947: Duplicate entry with 31082
- 950: 25/07/08 Moved as FS to Rel-7 out of the stopped Rel-8 Feature UID_31067 Deleted - All-IP Network (AIPN)
- 952: Spin-off Feature Network selection enhancements (NSP-CR) UID_7041
- 953: Spin-off Feature PRIOR UID_340044
- 956: Moved to FS at CT32 (in line with slides)
- 957: Previously known as "Study of a SMS Centre for MT SMS"
- 958: TR 29.800 content moved to TS 29.204 under implementation WI UID_310005 TCAPsec Gateway
- 963: SA#34 completed
- 964: SA#35 completed
- 965: SA#35 completed
- 966: RP#33 (Sep 2006) completed. SR in RP-060472
- 967: RP#32 (Jun 2006) completed. SR in RP-060412
- 968: RP#31 (Mar 2006) completed. SR in RP-060035
- 969: RP#29 (Sep 2006) completed. SR in RP-050427
- 970: RP#34 (Dec 2006) completed. SR in RP-060692
- 971: RP#32 (Jun 2006) closed (no progress). SR in RP-060263
- 972: RP#36 (May 2007) completed. SR in RP-070499
- 973: RP#37 (Sep 2007) completed. SR in RP-070533
- 974: RP#37 (Sep 2007) completed. SR in RP-070534
- 976: GP#35 completed
- 978: S2#52: Entry created

| ID | WBS | Task | Type | Duration | Start | Finish | Complete | Baseline start | Baseline finish | Baseline duration | Total slack | Constraint | Resources | Work | Actual work | Text1 | Text6 | Text12 | Text3 | Text4 | Text5 | Text8 | Text11 |
| --- | --- | --- | --- | --- | --- | --- | --- | --- | --- | --- | --- | --- | --- | --- | --- | --- | --- | --- | --- | --- | --- | --- | --- |
| 979 | 1.302 | **Deleted: Study on applicability of GALILEO for LCS** |  | 0d? | 2005-06-30 A | 2005-06-30 A | 100% | 2005-06-30 | 2005-06-30 | 0d? |  |  | S2 |  |  | Galileo | Rel-7 | SP-25 |  |  |  |  |  |
| 980 | 1.302.1 | Deleted - TR on Stage 2 | milestone | 0d? | 2005-06-30 A | 2005-06-30 A | 100% | 2005-06-30 | 2005-06-30 | 0d? |  | finish no earlier than 2005-06-30 | S2 |  |  | Galileo | Rel-7 | SP-25 |  |  |  |  |  |
| 981 | 1.302.2 | Deleted - GERAN review of the TR | milestone | 0d? | 2005-06-30 A | 2005-06-30 A | 100% | 2005-06-30 | 2005-06-30 | 0d? |  | start no earlier than 2005-06-30 | GP |  |  | Galileo | Rel-7 | SP-26 |  |  |  |  |  |
| 982 | 16.7 | **Deleted - IMS Local services** |  | 0d? | 2006-01-06 A | 2006-01-06 A | 100% | 2006-01-06 | 2006-01-06 | 0d? |  |  | S2 |  |  | IMSLocal | Rel-7 | SP-28 | 23.228 |  |  |  |  |
| 983 | 16.7.1 | Deleted - Stage 2 | milestone | 0d | 2006-01-06 A | 2006-01-06 A | 100% | 2006-01-06 | 2006-01-06 | 0d |  | start no earlier than 2006-01-06 | S2 |  |  | IMSLocal | Rel-7 | SP-26 |  |  |  |  |  |
| 984 | 1.303.2 | Deleted - Stage 3 for IMS Local services | milestone | 0d? | 2006-01-06 A | 2006-01-06 A | 100% | 2006-01-06 | 2006-01-06 | 0d? |  | finish no earlier than 2006-01-06 | C1 |  |  | IMSLocal | Rel-7 | SP-25 |  | Lucent | Keith Drage (drage@lucent.com) |  |  |
| 985 | 1.304 | Deleted - IMS Phase 3 | milestone | 0d? | 2006-01-06 A | 2006-01-06 A | 100% | 2006-01-06 | 2006-01-06 | 0d? |  | start no earlier than 2006-01-06 | S2 |  |  |  | Rel-7 | SP-25 |  |  |  |  |  |
| 986 | 1.305 | Deleted - Improvements of Radio Interface | milestone | 0d? | 2004-09-15 A | 2004-09-15 A | 100% | 2004-09-15 | 2004-09-15 | 0d? |  | start no earlier than 2004-09-15 | RP |  |  | RInImp | Rel-7 | SP-24 |  |  | Rel-7 | Claude |  |
| 987 | 1.306 | Deleted: Generic User Profile Phase 2 | milestone | 0d | 2005-08-08 A | 2006-06-30 A | 100% | 2005-08-08 | 2006-06-30 | 0d |  |  | C4 |  |  |  | Rel-7 | SP-27 |  |  |  | Gaby |  |
| 988 | 30.4 | Deleted - Stage 3 - Common objects | milestone | 0d | 2005-08-08 A | 2006-06-30 A | 100% | 2005-08-08 | 2006-06-30 | 0d |  | finish no earlier than 2006-06-30 | C4 |  |  |  | Rel-7 | SP-27 | 24.241 |  |  | Gaby |  |
| 989 | 1.308 | Delete was duplicated- Study of Customised Alerting Tone (CAT) Requirements | milestone | 0d? | 2006-06-30 A | 2006-06-30 A | 100% | 2006-06-30 | 2006-06-30 | 0d? |  | start no earlier than 2006-06-30 | S1 |  |  | CAT | Rel-7 | SP-31 |  |  |  |  |  |
| 990 | 1.309 | Deleted - FS of enhanced support of Video Telephony | milestone | 0d? | 2006-06-30 A | 2006-06-30 A | 100% | 2006-06-30 | 2006-06-30 | 0d? |  | start no earlier than 2006-06-30 | GP |  |  | VIDGER | Rel-7 | SP-32 |  | Ericsson | stefan.g.eriksson@ericsson.com | Paolo |  |
| 991 | 1.310 | Deleted (moved to Rel8) - Study on Transferring of emergency call data – in-band modem solution | milestone | 0d? | 2007-06-22 A | 2007-06-22 A | 100% | 2007-06-22 | 2007-06-22 | 0d? |  | start no earlier than 2007-06-22 | S4 |  |  | eCALLIBMS | Rel-7 | SP-38 | 26.967 | Airbiquity | lhong@airbiquity.com | Paolo |  |
| 992 | 1.311 | Deleted - covered by UID 20053 - Study on Interference Cancellation for UTRA FDD UE |  | 1d? | 2007-03-28 A | 2007-03-28 A | 100% | 2007-03-28 | 2007-03-28 | 1d? |  | start no earlier than 2007-03-28 | R4 | 8h | 8h | RANFS-InterfCanc | Rel-7 | SP-38 |  |  |  |  |  |
| 993 | 1.312 | Deleted - Study of Personal Network and Personal Area Network | milestone | 0d? | 2006-10-20 A | 2006-10-20 A | 100% | 2006-10-20 | 2006-10-20 | 0d? |  | finish no earlier than 2006-10-20 | S1 |  |  | PNPAN | Rel-7 | SP-31 |  |  |  |  |  |
| 994 | 1.313 | Deleted - Study on IMS with real time services deployment |  | 316d? | 2004-06-28 A | 2005-09-12 A | 100% | 2004-06-28 | 2005-09-12 | 316d? |  |  | S1 | 2528h | 2528h | IRTSD | Rel-7 | SP-30 |  |  |  | Alain |  |
| 995 | 1.314 | Deleted - Study on Stage 2 (IMS services using CS bearers) |  | 316d? | 2004-06-28 A | 2005-09-12 A | 100% | 2004-06-28 | 2005-09-12 | 316d? |  | finish no earlier than 2005-09-12 | S2 | 2528h | 2528h | IRTSD-IMSCS | Rel-7 | SP-30 | 23.899 | Nortel | Mark Watson | Maurice |  |
| 996 | 1.315 | Deleted - Study on IMS enhancements and optimisations for real time communication. |  | 430d? | 2005-10-10 A | 2007-06-01 A | 100% | 2005-10-10 | 2007-06-01 | 430d? |  | finish no earlier than 2007-06-01 | S2 | 3440h | 3440h | IMS-RT | Rel-7 | SP-35 | 23.818 | Ericsson | stephen.terrill@ericsson.com | Maurice |  |
| 997 | 1.316 | Deleted - Study on Terminating Session handling |  | 255d? | 2006-01-09 A | 2006-12-29 A | 100% | 2006-01-09 | 2006-12-29 | 255d? |  | finish no earlier than 2006-12-29 | S2 | 2040h | 2040h | CSIterm | Rel-7 | SP-32 | 23.819 | Samsung | osok.song@samsung.com | Maurice |  |
| 998 | 1.317 | Deleted - Study on IRP usage scenarios |  | 330d? | 2005-09-02 A | 2006-12-07 A | 100% | 2005-09-02 | 2006-12-07 | 330d? |  | finish no earlier than 2006-12-07 | S5 | 2640h | 2640h | OAM-Study | Rel-7 | SP-32 | 32.8xy | Lucent |  | Adrian |  |
| 999 | 1.318 | Release 6 Features |  | 1d? | 2000-01-03 | 2000-01-03 |  | 2000-01-03 | 2000-01-03 | 1d? | 2659d |  | CP,GP, RP,SP,TP | 8h |  |  | Rel-6 |  |  |  |  |  |  |
| 1000 | 8 | **Rel-6 Improvements of Radio Interface** |  | 1393d? | 2000-08-14 A | 2005-12-14 A | 100% | 2000-08-14 | 2005-12-14 | 1393d? |  |  | RP | 38664h | 38664h | RInImp | Rel-6 |  |  |  |  | Cesar |  |
| 1001 | 1.319.1 | Improved support of IMS Realtime Services using HSDPA/EDCH |  | 197d? | 2005-03-15 A | 2005-12-14 A | 100% | 2005-03-15 | 2005-12-14 | 197d? |  | finish no earlier than 2005-12-14 | R2 | 1576h | 1576h | RInImp-IMSRealTime | Rel-6 |  |  | Cingular | don.zelmer@CINGULAR.COM | MCC_RAN |  |
| 1002 | 1.319.2 | Improving Receiver Performance Requirements for the FDD UE |  | 401d | 2002-03-08 A | 2003-09-19 A | 100% | 2002-03-08 | 2003-09-19 | 401d |  | start no earlier than 2002-03-08 | R4 | 3208h | 3208h | RInImp-UERecPerf | Rel-6 |  | 25.101 | Intel | shimon.moshavi@INTEL.COM |  | Active |

Notes:
- 983: DAB - Not yet required in SA2 as it exists in previous releases
- 986: Stage 2 description of Interim conclusion
- 987: Created at TSG#27 by A. Sultan because of the move to Rel-7 of "Common Objects".
- 988: No progress in CN4#26. This have to be moved to Rel-7. It was deleted from WID
- 989: Awaiting MCC SA3 input
- 990: FS CLOSED at G#28 (no input)
- 991: SP-38 stopped
- 992: Deleted. Same as FS on Further Improved Performance Requirements for UMTS/HSDPA UE (FDD)
- 993: Moved from FS section Feb 06
- 995: SP-30: S2 has no intention for TR completion
- 996: abandoned at 65%
- 997: SA#32 Jun 2006 Study abandoned => spin-off Implementation work UID_320029
- 1000: This is a generic feature without particular end date

| ID | WBS | Task | Duration | Start | Finish | Complete | Baseline start | Baseline finish | Baseline duration | Constraint | Resources | Work | Actual work | Text1 | Text6 | Text3 | Text4 | Text5 | Text8 | Text11 | Text10 |
| --- | --- | --- | --- | --- | --- | --- | --- | --- | --- | --- | --- | --- | --- | --- | --- | --- | --- | --- | --- | --- | --- |
| 1003 | 8.2 | **Base station classification** | 603d | 2000-08-14 A | 2002-12-04 A | 100% | 2000-08-14 | 2002-12-04 | 603d |  | R4 | 9648h | 9648h | RInImp-BSClass | Rel-6 |  |  |  |  |  |  |
| 1004 | 8.2.1 | FDD Base station classification | 603d | 2000-08-14 A | 2002-12-04 A | 100% | 2000-08-14 | 2002-12-04 | 603d | finish no earlier than 2002-12-04 | R4 | 4824h | 4824h | RInImp-BSClass-FDD | Rel-6 | 25.104, 25.141 | Nokia | A. Toskala |  |  |  |
| 1005 | 1.319.4 | UMTS-850 | 266d | 2002-12-06 A | 2003-12-12 A | 100% | 2002-12-06 | 2003-12-12 | 266d | finish no earlier than 2003-12-15 | R4 | 2128h | 2128h | RInImp-UMTS850 | Rel-6 | 25.101, 25.104, 25.133, 25.141, 25.307, 25.331, 25.942 | Cingular | don.zelmer@cingular.com | MCC_RAN | Active |  |
| 1006 | 1.319.5 | DS-CDMA introduction in the 800 MHz band | 196d | 2003-03-14 A | 2003-12-12 A | 100% | 2003-03-14 | 2003-12-12 | 196d | finish no earlier than 2003-12-15 | R4 | 1568h | 1568h | RInImp-UMTS800 | Rel-6 | 25.101, 25.104, 25.133, 25.141, 25.307, 25.331 | NTT DoCoMo | Takehiro Nakamura (takehiro@wsp.yrp.nttdocomo.co.jp) | MCC_RAN | Active |  |
| 1007 | 1.319.6 | UMTS 1.7/2.1 GHz | 261d | 2003-03-14 A | 2004-03-12 A | 100% | 2003-03-14 | 2004-03-12 | 261d | finish no earlier than 2004-03-15 | R4 | 2088h | 2088h | RInImp-UMTS1721 | Rel-6 | 25.101, 25.104, 25.133, 25.141, 25.307, 25.331 | Nokia | jussi.numminen@NOKIA.COM | MCC RAN | Active |  |
| 1008 | 1.319.7 | **Improved Receiver Performance Requirements for HSDPA** | 392d? | 2003-12-15 A | 2005-06-14 A | 100% | 2003-12-15 | 2005-06-14 | 392d? |  | R4 | 7304h | 7304h | RInImp-HSPerf | Rel-6 |  | Nokia | jussi.numminen@NOKIA.COM | MCC RAN |  |  |
| 1009 | 1.319.7.1 | Improved Minimum Performance Requirements for HSDPA UE categories 7 and 8 | 195d? | 2004-09-15 A | 2005-06-14 A | 100% | 2004-09-15 | 2005-06-14 | 195d? | finish no earlier than 2005-06-14 | R4 | 1560h | 1560h | RInImp-HSPerf-10code | Rel-6 | 25.101 | Nokia | jussi.numminen@nokia.com | MCC_RAN |  |  |
| 1010 | 1.319.7.2 | Performance Requirements of Receive Diversity for HSDPA | 326d | 2003-12-15 A | 2005-03-14 A | 100% | 2003-12-15 | 2005-03-14 | 326d | finish no earlier than 2005-03-14 | R4 | 2608h | 2608h | RInImp-HSPerf-RxDiv | Rel-6 | 25.101 | NTT DoCoMo | Takehiro Nakamura (takehiro@wsp.yrp.nttdocomo.co.jp) | MCC RAN |  |  |
| 1011 | 1.320 | **Rel-6 RAN Feasibility Studies** | 1196d? | 2000-08-14 A | 2005-03-14 A | 100% | 2000-08-14 | 2005-03-14 | 1196d? |  | RP | 43048h | 43048h |  | Rel-6 |  |  |  | Cesar |  |  |
| 1012 | 1.320.1 | FS of the improved access to UE measurement data for CRNC to support TDD RRM | 270d? | 2002-12-06 A | 2003-12-18 A | 100% | 2002-12-06 | 2003-12-18 | 270d? | finish no earlier than 2003-09-19 | R3 | 2160h | 2160h | RANimp-RRMopt-FSUEMsD | Rel-6 |  | Interdigital | jim.miller@interdigital.com |  |  | SP-24 |
| 1013 | 1.320.2 | FS on Radio link performance enhancements | 1067d | 2000-08-14 A | 2004-09-14 A | 100% | 2000-08-14 | 2004-09-14 | 1067d | finish no earlier than 2004-09-14 | R1 | 8536h | 8536h | RInImp-Rlperf | Rel-6 | 25.899 | Nokia | antti.toskala@nokia.com | MCC_RAN | Active |  |
| 1014 | 1.320.3 | FS on Improvement of inter-frequency and inter-system measurements for 1.28 Mcps TDD | 461d | 2001-12-14 A | 2003-09-19 A | 100% | 2001-12-14 | 2003-09-19 | 461d | start no earlier than 2001-12-14 | R1 | 3688h | 3688h | RInImp-IfIsMLCR | Rel-6 | 25.888 | Samsung | Li Xiao Qiang (xqli@samsung.co.kr) |  | Active |  |
| 1015 | 1.320.4 | FS for the analysis of OFDM for UTRAN enhancement | 526d | 2002-06-10 A | 2004-06-14 A | 100% | 2002-06-10 | 2004-06-14 | 526d | start no earlier than 2002-06-10 | R1 | 4208h | 4208h | RInImp-FSOFDM | Rel-6 | 25.892 | Nortel | Sarah Boumendil (boumendi@nortelnetworks.com) | MCC_RAN | Active |  |
| 1016 | 1.320.5 | FS on Uplink Enhancements for Dedicated Transport Channels | 396d | 2002-09-06 A | 2004-03-12 A | 100% | 2002-09-06 | 2004-03-12 | 396d | finish no earlier than 2004-03-12 | R1 | 3168h | 3168h | RInImp-FSUpDTrCh | Rel-6 | 25.896 | Nokia | Karri.Ranta-aho@nokia.com | MCC_RAN | Active |  |
| 1017 | 1.320.6 | FS on Analysis on Higher Chip Rates for UTRA TDD evolutions | 528d | 2002-09-06 A | 2004-09-14 A | 100% | 2002-09-06 | 2004-09-14 | 528d | finish no earlier than 2004-09-14 | R1 | 4224h | 4224h | RInImp-FSVHCRTDD | Rel-6 | 25.895 | IPWireless | mbeale@ipwireless.com | MCC_RAN | Active |  |
| 1018 | 1.320.7 | FS on Low Output Powers for general purpose FDD BSs | 128d | 2003-06-13 A | 2004-03-12 A | 100% | 2003-06-13 | 2004-03-12 | 128d | finish no earlier than 2004-03-12 | R3 | 1024h | 1024h | RInImp-FSLoPw | Rel-6 | 25.807 | Telefonica | Ana Burgos (burgos_a@tsm.es) | MCC_RAN | Active |  |
| 1019 | 1.320.8 | FS on Uplink enhancements for UTRA TDD | 462d | 2003-06-06 A | 2005-03-14 A | 100% | 2003-06-06 | 2005-03-14 | 462d | finish no earlier than 2005-03-14 | R1 | 3696h | 3696h | RInImp-FSUpEnhTDD | Rel-6 | 25.804 | Interdigital | Marian.Rudolf@InterDigital.com | MCC_RAN | Active |  |
| 1020 | 8.8 | FS on UE antenna efficiency test methods performance requirements (2) | 131d | 2002-03-08 A | 2002-09-06 A | 100% | 2002-03-08 | 2002-09-06 | 131d | finish no earlier than 2002-09-06 | R4 | 1048h | 1048h | RInImp-UEAnTM2 | Rel-6 |  | Allgon | Alf Ahlström |  |  |  |
| 1021 | 9.4 | Deleted - FS on the evolution of the UTRAN architecture | 592d | 2002-09-09 A | 2004-12-15 A | 100% | 2002-09-09 | 2004-12-15 | 592d | finish no earlier than 2004-12-15 | R3 | 4736h | 4736h | RANimp-FSEvo | Rel-6 |  | Nokia | Woonhee Hwang, Antti.Toskala@nokia.com | MCC_RAN |  |  |
| 1022 | 1.321 | **FDD Enhanced Uplink** | 393d | 2004-03-15 A | 2005-09-15 A | 100% | 2004-03-15 | 2005-09-15 | 393d |  | RP | 14128h | 14128h | EDCH | Rel-6 |  | Ericsson | Joakim Bergström | Cesar | Active |  |
| 1023 | 1.321.1 | FDD Enhanced Uplink - Stage 2 | 197d | 2004-03-15 A | 2004-12-14 A | 100% | 2004-03-15 | 2004-12-14 | 197d | finish no earlier than 2004-12-14 | R2 | 1576h | 1576h | EDCH-Stage2 | Rel-6 | 25.309 |  |  |  |  |  |
| 1024 | 1.321.2 | FDD Enhanced Uplink - Physical Layer | 261d | 2004-03-15 A | 2005-03-14 A | 100% | 2004-03-15 | 2005-03-14 | 261d | finish no earlier than 2005-03-14 | R1 | 2088h | 2088h | EDCH-Phys | Rel-6 | 25.211, 25.212, 25.213, 25.214, 25.215 | Nokia | Karri.Ranta-aho@nokia.com | MCC RAN | Active |  |
| 1025 | 1.321.3 | FDD Enhanced Uplink - Layer 2 and 3 Protocol Aspects | 261d | 2004-03-15 A | 2005-03-14 A | 100% | 2004-03-15 | 2005-03-14 | 261d | finish no earlier than 2005-03-14 | R2 | 2088h | 2088h | EDCH-L23 | Rel-6 | 25.301, 25.302, 25.306, 25.321, 25.331 | Ericsson | Joakim Bergström | MCC RAN | Active |  |
| 1026 | 1.321.4 | FDD Enhanced Uplink - UTRAN Iub/Iur Protocol Aspects | 261d | 2004-03-15 A | 2005-03-14 A | 100% | 2004-03-15 | 2005-03-14 | 261d | finish no earlier than 2005-03-14 | R3 | 2088h | 2088h | EDCH-IurIub | Rel-6 | 25.401, 25.420, 25.423, 25.430, 25.433 | Nortel | Saso Stojanovski | MCC RAN | Active |  |
| 1027 | 1.321.5 | FDD Enhanced Uplink - RF Radio Transmission/ Reception, System Performance Requirements and Conformance Testing | 393d | 2004-03-15 A | 2005-09-15 A | 100% | 2004-03-15 | 2005-09-15 | 393d | finish no earlier than 2005-09-15 | R4 | 3144h | 3144h | EDCH-RF | Rel-6 | 25.101, 25.104, 25.133, 25.141 | Ericsson | thomas.unshelm@ERICSSON.COM | MCC RAN | Active |  |

Notes:
- 1009: Approved at RP#25 as RP-040375
- 1013: Study finished at RP#25
- 1017: Study finished at RP#25
- 1020: The RInImp-UEAnTM FS was re-opened at TSG RP#15 upon request from WG4
- 1021: Study Closed, work will continue within the FS on evolved UTRA and UTRAN

| ID | WBS | Task | Type | Duration | Start | Finish | Complete | Baseline start | Baseline finish | Baseline duration | Constraint | Resources | Work | Actual work | Text1 | Text6 | Text8 | Text3 | Text4 | Text5 | Text11 | Text12 | Text10 |
| --- | --- | --- | --- | --- | --- | --- | --- | --- | --- | --- | --- | --- | --- | --- | --- | --- | --- | --- | --- | --- | --- | --- | --- |
| 1028 | 1.322 | **Rel-6 RAN improvements** |  | 656d? | 2002-09-09 A | 2005-03-14 A | 100% | 2002-09-09 | 2005-03-14 | 656d? |  | RP | 28312h | 28312h | RANimp | Rel-6 | Cesar |  |  |  |  |  |  |
| 1029 | 9.2 | **RAB support enhancement** |  | 522d? | 2003-03-14 A | 2005-03-14 A | 100% | 2003-03-14 | 2005-03-14 | 522d? |  | R2 | 9360h | 9360h | RANimp-RABSE | Rel-6 | MCC RAN | 25.862 | Nokia | juha.mikola@nokia.com |  |  |  |
| 1030 | 1.322.1.1 | Optimisation of downlink channelisation code utilisation |  | 262d | 2004-03-12 A | 2005-03-14 A | 100% | 2004-03-12 | 2005-03-14 | 262d | finish no earlier than 2005-03-14 | R1 | 2096h | 2096h | RANimp-RABSE-CodeOptFDD | Rel-6 | MCC RAN |  | Nortel | Sarah Boumendil ( (boumendi@nortelnetworks.com) | Active |  |  |
| 1031 | 1.322.1.2 | Optimisation of channelisation code utilisation for 3.84 Mcps TDD |  | 261d | 2004-03-15 A | 2005-03-14 A | 100% | 2004-03-15 | 2005-03-14 | 261d | finish no earlier than 2005-03-15 | R1 | 2088h | 2088h | RANimp-RABSE-CodOptTDD | Rel-6 | MCC RAN |  | IPWireless | Nicholas Anderson | Active |  |  |
| 1032 | 1.322.1.3 | HS-DPCCH ACK/NACK Enhancement |  | 65d? | 2004-09-15 A | 2004-12-14 A | 100% | 2004-09-15 | 2004-12-14 | 65d? | finish no earlier than 2004-12-15 | R1 | 520h | 520h | RANimp-RABSE-ACKNACK | Rel-6 | MCC_RAN | 25.212, 25.214, 24.331, 25.433 | Nokia | jussi.kahtava@nokia.com |  |  |  |
| 1033 | 1.322.1.4 | Deleted - Iu enhancements for IMS support in RAN |  | 320d? | 2003-03-14 A | 2004-06-03 A | 100% | 2003-03-14 | 2004-06-03 | 320d? | start no earlier than 2003-03-14 | R3 | 2560h | 2560h | RANimp-RABSE-IuEnhIMS | Rel-6 | MCC RAN |  | Nortel | Philippe.Godin@nortelnetworks.com |  |  |  |
| 1034 | 1.322.1.5 | Deleted - Improvement of RRM across RNS and RNS/BSS | milestone | 0d? | 2003-12-05 A | 2003-12-05 A | 100% | 2003-12-05 | 2003-12-05 | 0d? | finish no earlier than 2003-12-05 | R3 |  |  | RANimp-RRM1 | Rel-6 |  |  | Nokia | Antti Toskala |  | RP-23 |  |
| 1035 | 9.1 | Beamforming Enhancements |  | 66d | 2003-09-19 A | 2003-12-19 A | 100% | 2003-09-19 | 2003-12-19 | 66d | finish no earlier than 2004-03-12 | R1 | 528h | 528h | RANimp-BFE | Rel-6 | MCC_RAN | 24.215, 25.423, 25.425, 25.433, 25.435 | Nokia | jussi.kahtava@nokia.com |  |  |  |
| 1036 | 1.322.3 | **Rel6 RRM optimization for Iur and Iub** |  | 126d | 2003-09-19 A | 2004-03-12 A | 100% | 2003-09-19 | 2004-03-12 | 126d |  | R3 | 2016h | 2016h | RANimp-RRMopt | Rel-6 | MCC_RAN |  | Ericsson | Gert-Jan.van.Lieshout@eln.ericsson.se |  |  |  |
| 1037 | 1.322.3.1 | Improved access to UE measurement data for CRNC to support TDD RRM |  | 126d | 2003-09-19 A | 2004-03-12 A | 100% | 2003-09-19 | 2004-03-12 | 126d | finish no earlier than 2004-03-15 | R3 | 1008h | 1008h | RANimp-RRMopt-UEMsD | Rel-6 | MCC RAN | 25.423 | Interdigital | jim.miller@interdigital.com | Active | RP-22 |  |
| 1038 | 1.322.4 | **Remote Control of Electrical Tilting Antennas** |  | 395d? | 2003-03-14 A | 2004-09-16 A | 100% | 2003-03-14 | 2004-09-16 | 395d? |  | R3 | 7464h | 7464h | RANimp-TiltAnt | Rel-6 | MCC_RAN |  | Vodafone | Andreas.Hauser@vodafone.com |  |  |  |
| 1039 | 1.322.4.1 | Tilting Antenna - RAN aspects |  | 393d? | 2003-03-14 A | 2004-09-14 A | 100% | 2003-03-14 | 2004-09-14 | 393d? | finish no earlier than 2004-09-14 | R3 | 3144h | 3144h | RANimp-TiltAnt | Rel-6 | MCC_RAN | 25.460, 25.461, 25.462, 25.463 | Vodafone | Andreas.Hauser@vodafone.com |  |  |  |
| 1040 | 1.322.4.2 | OAM&P impacts |  | 145d | 2004-02-27 A | 2004-09-16 A | 100% | 2004-02-27 | 2004-09-16 | 145d | finish no earlier than 2004-09-16 | S5 | 1160h | 1160h | RANimp-TiltAnt-OAM | Rel-6 | Adrian | 32.804, 32.64x | Vodafone | Adrian.Neal@vodafone.com |  |  | SP-24 |
| 1041 | 1.322.5 | Network Assisted Cell Change (NACC) from UTRAN to GERAN - network-side aspects |  | 462d? | 2002-09-09 A | 2004-06-15 A | 100% | 2002-09-09 | 2004-06-15 | 462d? | finish no earlier than 2004-06-15 | R3 | 3696h | 3696h | RANimp-NACC | Rel-6 | MCC_RAN |  | Vodafone | Brendan.McWilliams@gb.vodafone.co.uk |  |  |  |
| 1042 | 12 | **Location Services enhancements 2** |  | 1024d? | 2001-01-15 A | 2004-12-16 A | 100% | 2001-01-15 | 2004-12-16 | 1024d? |  | S2 | 77352h | 77352h | LCS2 | Rel-6 | Sang-Ui | 23.271 |  |  |  |  |  |
| 1043 | 12.1 | **Improvement on Le interface** |  | 653d? | 2002-06-17 A | 2004-12-15 A | 100% | 2002-06-17 | 2004-12-15 | 653d? |  | S2 | 9872h | 9872h |  | Rel-6 |  |  |  |  |  |  |  |
| 1044 | 1.323.1.1 | Stage 2 |  | 331d? | 2002-06-17 A | 2003-09-22 A | 100% | 2002-06-17 | 2003-09-22 | 331d? | start no earlier than 2002-06-17 | S2 | 2648h | 2648h |  | Rel-6 |  |  |  |  |  |  |  |
| 1045 | 1.323.1.2 | Stage 3 - impacts MLP (Mobile Location Protocol) |  | 250d? | 2004-01-01 A | 2004-12-15 A | 100% | 2004-01-01 | 2004-12-15 | 250d? | finish no earlier than 2004-12-15 | OMA | 2000h | 2000h |  | Rel-6 |  |  |  | OMA-LIAISON@mail.openmobilealliance.org |  |  |  |
| 1046 | 12.2 | **Enhanced support for anonymity and user privacy** |  | 638d? | 2002-07-08 A | 2004-12-15 A | 100% | 2002-07-08 | 2004-12-15 | 638d? |  | S2 | 9144h | 9144h |  | Rel-6 |  |  |  |  |  |  |  |
| 1047 | 1.323.2.1 | Stage 2 |  | 255d? | 2002-07-08 A | 2003-06-27 A | 100% | 2002-07-08 | 2003-06-27 | 255d? | finish no earlier than 2003-06-27 | S2 | 2040h | 2040h |  | Rel-6 |  |  |  |  |  |  |  |
| 1048 | 1.323.2.2 | Stage 3 - impacts MLP and RLP |  | 250d? | 2004-01-01 A | 2004-12-15 A | 100% | 2004-01-01 | 2004-12-15 | 250d? | finish no earlier than 2004-12-15 | OMA | 2000h | 2000h |  | Rel-6 |  |  |  | OMA-LIAISON@mail.openmobilealliance.org |  |  |  |
| 1049 | 12.3 | **Enhanced inter-GMLC interface** |  | 648d? | 2002-06-24 A | 2004-12-15 A | 100% | 2002-06-24 | 2004-12-15 | 648d? |  | S2 | 9704h | 9704h |  | Rel-6 |  |  |  |  |  |  |  |
| 1050 | 1.323.3.1 | Stage 2 |  | 315d? | 2002-06-24 A | 2003-09-05 A | 100% | 2002-06-24 | 2003-09-05 | 315d? | finish no earlier than 2003-09-05 | S2 | 2520h | 2520h |  | Rel-6 |  |  |  |  |  |  |  |
| 1051 | 1.323.3.2 | Stage 3 - definition of RLP and PCP |  | 250d? | 2004-01-01 A | 2004-12-15 A | 100% | 2004-01-01 | 2004-12-15 | 250d? | finish no earlier than 2004-12-15 | OMA | 2000h | 2000h |  | Rel-6 |  |  |  | OMA-LIAISON@mail.openmobilealliance.org |  |  |  |

Notes:
- 1028: Generic feature
- 1029: This is a building block without particular end date
- 1031: WIDS modified in RP#26, RP-040551
- 1032: Approved at RP#25 as RP-040390
- 1033: Closed RP#24 due to the lack of progress
- 1034: abandoned RP-23
- 1039: Finished at RP#25
- 1040: SA#25 09/2004 completed
- 1045: Updated according to SP-040232
- 1048: Updated according to SP-040232
- 1051: Updated according to SP-040232

| ID | WBS | Task | Type | Duration | Start | Finish | Complete | Remaining | Baseline start | Baseline finish | Baseline duration | Total slack | Constraint | Resources | Work | Actual work | Text6 | Text5 | Text1 | Text8 | Text4 | Text12 |
| --- | --- | --- | --- | --- | --- | --- | --- | --- | --- | --- | --- | --- | --- | --- | --- | --- | --- | --- | --- | --- | --- | --- |
| 1052 | 12.4 | **Location Services support for IMS public identities** |  | 473d? | 2003-02-24 A | 2004-12-15 A | 100% |  | 2003-02-24 | 2004-12-15 | 473d? |  |  | S2 | 7704h | 7704h | Rel-6 |  |  |  |  |  |
| 1053 | 1.323.4.1 | Stage 2 |  | 240d? | 2003-02-24 A | 2004-01-23 A | 100% |  | 2003-02-24 | 2004-01-23 | 240d? |  | finish no earlier than 2004-01-23 | S2 | 1920h | 1920h | Rel-6 |  |  |  |  |  |
| 1054 | 1.323.4.2 | Stage 3 - impacts MLP, RLP and PCP |  | 250d? | 2004-01-01 A | 2004-12-15 A | 100% |  | 2004-01-01 | 2004-12-15 | 250d? |  | finish no earlier than 2004-12-15 | OMA | 2000h | 2000h | Rel-6 | OMA-LIAISON@mail.openmobilealliance.org |  |  |  |  |
| 1055 | 12.5 | **New area event for location service triggering reports** |  | 663d? | 2002-06-03 A | 2004-12-15 A | 100% |  | 2002-06-03 | 2004-12-15 | 663d? |  |  | S2 | 11416h | 11416h | Rel-6 |  |  |  |  |  |
| 1056 | 1.323.5.1 | Stage 2 |  | 280d? | 2002-06-03 A | 2003-06-27 A | 100% |  | 2002-06-03 | 2003-06-27 | 280d? |  | finish no earlier than 2003-06-27 | S2 | 2240h | 2240h | Rel-6 |  |  |  |  |  |
| 1057 | 1.323.5.2 | Stage 3 for UE-CN signalling |  | 234d? | 2003-10-09 A | 2004-08-31 A | 100% |  | 2003-10-09 | 2004-08-31 | 234d? |  | start no earlier than 2003-10-09 | N4 | 1872h | 1872h | Rel-6 |  |  |  |  |  |
| 1058 | 1.323.5.3 | Stage 3 - impacts MLP, RLP and PCP |  | 250d? | 2004-01-01 A | 2004-12-15 A | 100% |  | 2004-01-01 | 2004-12-15 | 250d? |  | finish no earlier than 2004-12-15 | OMA | 2000h | 2000h | Rel-6 | OMA-LIAISON@mail.openmobilealliance.org |  |  |  |  |
| 1059 | 12.7 | **UE positioning** |  | 957d? | 2001-01-15 A | 2004-09-14 A | 100% |  | 2001-01-15 | 2004-09-14 | 957d? |  |  | RP | 18480h | 18480h | Rel-6 |  | LCS2-UEpos | MCC_RAN |  |  |
| 1060 | 12.8 | Open SMLC-SRNC Interface within the UTRAN to support UTRAN Rel4 positioning methods |  | 700d? | 2001-01-15 A | 2003-09-19 A | 100% |  | 2001-01-15 | 2003-09-19 | 700d? |  | finish no earlier than 2003-09-19 | R2 | 5600h | 5600h | Rel-6 | Meik.Kottkamp@siemens.com | LCS-Rel4Pos |  | Siemens |  |
| 1061 | 1.323.6.2 | A-GPS minimum performance specification |  | 333d? | 2003-06-06 A | 2004-09-14 A | 100% |  | 2003-06-06 | 2004-09-14 | 333d? |  | finish no earlier than 2004-09-14 | R4 | 2664h | 2664h | Rel-6 | donglin.shen@attws.com | LCS-UEPos-AGPSPerf | MCC_RAN | AT&T Wireless |  |
| 1062 | 12.7.2 | FS on Enhancements to OTDOA Positioning using advanced blanking methods |  | 320d | 2002-07-01 A | 2003-09-19 A | 100% |  | 2002-07-01 | 2003-09-19 | 320d |  | finish no earlier than 2003-09-19 | R2 | 2560h | 2560h | Rel-6 | david.bartlett@cursor-system.com | LCS2-UEpos-FSBlank |  | Cambridge Positioning Systems |  |
| 1063 | 1.323.6.4 | Deleted - UE positioning enhancements - other methods | milestone | 0d? | 2003-09-26 A | 2003-09-26 A | 100% |  | 2003-09-26 | 2003-09-26 | 0d? |  | finish no earlier than 2003-09-26 | R2 |  |  | Rel-6 | Meik.Kottkamp@siemens.com | LCS2-UEpos-enh |  | Siemens | RP-24 |
| 1064 | 1.323.7 | LCS charging |  | 455d? | 2003-03-21 A | 2004-12-16 A | 100% |  | 2003-03-21 | 2004-12-16 | 455d? |  | start no earlier than 2003-03-21 | S5 | 3640h | 3640h | Rel-6 | alain.bibas@francetelecom.com | LCS2-CH | Adrian | France Telecom |  |
| 1065 | 14 | **Rel-6 Security enhancements** |  | 1018d? | 2001-01-03 A | 2004-11-26 | 75% | 250.03d? | 2001-01-03 | 2004-11-26 | 1018d? | 1380d |  | S3 | 28824h | 20775.7h | Rel-6 | Peter.Howard@vodafone.com | SEC1 | Maurice | Vodafone |  |
| 1066 | 14.1 | **Enhanced HE control of security (including positive authentication reporting)** |  | 712d | 2001-01-03 A | 2003-09-25 | 47% | 378d | 2001-01-03 | 2003-09-25 | 712d | 1686d |  | S3 | 14064h | 8016h | Rel-6 | Peter.Howard@vodafone.com |  |  | Vodafone |  |
| 1067 | 14.1.1 | Stage 2 |  | 378d | 2001-01-03 | 2002-06-14 |  |  | 2001-01-03 | 2002-06-14 | 378d | 2020d | finish no earlier than 2002-06-14 | S3 | 3024h |  | Rel-6 |  |  |  |  |  |
| 1068 | 14.1.3 | **Network domain security** |  | 334d | 2002-06-17 A | 2003-09-25 A | 100% |  | 2002-06-17 | 2003-09-25 | 334d |  |  | S3 | 5344h | 5344h | Rel-6 | Geir-myrdahl.koien@telenor.com | SEC1-NDS |  | Telenor |  |
| 1069 | 14.1.3.1 | IP network layer security (NDS/IP) |  | 334d | 2002-06-17 A | 2003-09-25 A | 100% |  | 2002-06-17 | 2003-09-25 | 334d |  | finish no earlier than 2003-09-25 | S3 | 2672h | 2672h | Rel-6 |  | SEC1-NDS-IP |  |  |  |
| 1070 | 1.324.2 | Network Domain Security; Authentication Framework (NDS/AF) |  | 521d? | 2002-02-15 A | 2004-02-13 A | 100% |  | 2002-02-15 | 2004-02-13 | 521d? |  | finish no earlier than 2004-02-13 | S3 | 4168h | 4168h | Rel-6 | tommi.viitanen@nokia.com | SEC1-NDS-AF |  | Nokia |  |
| 1071 | 1.324.3 | Key Management of group keys for Voice Group Call Services |  | 306d | 2003-09-26 A | 2004-11-26 A | 100% |  | 2003-09-26 | 2004-11-26 | 306d |  | finish no earlier than 2004-11-26 | S3 | 2448h | 2448h | Rel-6 | benno.tietz@vodafone.com | SECGKYV | Maurice | Vodafone |  |
| 1072 | 16 | **IMS Phase 2** |  | 1395d? | 2000-08-28 A | 2005-12-30 A | 100% |  | 2000-08-28 | 2005-12-30 | 1395d? |  |  | S1 | 126048h | 126048h | Rel-6 |  | IMS2 | Sang-Ui |  |  |
| 1073 | 1.325.1 | Enhancements to the Cx and Sh interfaces |  | 323d? | 2003-06-06 A | 2004-08-31 A | 100% |  | 2003-06-06 | 2004-08-31 | 323d? |  | finish no earlier than 2004-08-31 | N4 | 2584h | 2584h | Rel-6 |  | IMS2-CCR |  |  |  |
| 1074 | 16.12 | **IMS Group Management** |  | 715d? | 2002-03-14 A | 2004-12-08 A | 100% |  | 2002-03-14 | 2004-12-08 | 715d? |  |  | S1 | 12680h | 12680h | Rel-6 | juha.kalliokulju@nokia.com | IMSGM |  | Nokia |  |
| 1075 | 16.12.1 | Stage 1 - TS on IMS group management |  | 193d | 2002-03-14 A | 2002-12-09 A | 100% |  | 2002-03-14 | 2002-12-09 | 193d |  | finish no earlier than 2002-12-09 | S1 | 1544h | 1544h | Rel-6 | juha.kalliokulju@nokia.com |  |  | Nokia |  |
| 1076 | 1.325.2.2 | Stage 2 |  | 158d? | 2003-05-26 A | 2003-12-31 A | 100% |  | 2003-05-26 | 2003-12-31 | 158d? |  | finish no earlier than 2003-12-31 | S2 | 1264h | 1264h | Rel-6 |  |  |  |  |  |
| 1077 | 1.325.2.3 | Stage 3 for IMS Group management (e.g. chat) |  | 519d? | 2002-12-13 A | 2004-12-08 A | 100% |  | 2002-12-13 | 2004-12-08 | 519d? |  | finish no earlier than 2004-12-08 | N1 | 4152h | 4152h | Rel-6 | Keith Drage (drage@lucent.com) |  |  | Lucent |  |

Notes:
- 1054: Updated according to SP-040232
- 1057: 31/10/2003 work has started. Current stage 3 fullfills the requirements of stage 2. ......
- 1058: Updated according to SP-040232
- 1060: Text3: 25.305, 25.401, 25.450, 25.452, 25.453
- 1061: Finished at RP#25 / Text3: 25.171
- 1063: This is a building block without particular end date
- 1064: SA#26 12/2004 completed / Text3: 32.271
- 1065: Added BB UE authentication and rapporteur added.
- 1066: Added by SP-000575 without any dates. 18/10/00: Change of WI title, added hyperlink rapporteur new end date 03/01. New end date and correct Release to be decided S3#18
- 1067: New end date and correct Release to be decided S3#18
- 1068: WID approved for Rel-6 at SA#17. Completed 2004-12
- 1069: Should be complete after SA3#27. Completed 2004-12 / Text3: 33.210
- 1070: WID approved SA#19. Work started after FS approved SA#18
- 1071: Approved TSG#21. Completed 2004-12 / Text3: 42.068, 43.068, 44.068, 42.069, 43.069, 44.069, 31.102, 24.008, 48.008, 42.009, 43.020
- 1072: Not yet available: verbally approved at SA15, actual WID to be provided at SA16 by Lucent / Text3: 23.228
- 1073: Shared public user identities need to be solved. If email approval CR is accepted. Work 100% done....
- 1077: Depends on CN decision on CPCP in Rel-6. Complete, if unresolved IETF dependencies are dropped (-> LS to CN plenary)

| ID | WBS | Task | Type | Duration | Start | Finish | Complete | Baseline start | Baseline finish | Baseline duration | Constraint | Resources | Work | Actual work | Text6 | Text4 | Text5 | Text1 | Text3 | Text12 |
| --- | --- | --- | --- | --- | --- | --- | --- | --- | --- | --- | --- | --- | --- | --- | --- | --- | --- | --- | --- | --- |
| 1078 | 1.325.3 | **IMS Conferencing** |  | 548d? | 2002-11-04 A | 2004-12-08 A | 100% | 2002-11-04 | 2004-12-08 | 548d? |  | N1 | 10960h | 10960h | Rel-6 |  |  |  |  |  |
| 1079 | 1.325.3.1 | Stage 2 |  | 303d? | 2002-11-04 A | 2003-12-31 A | 100% | 2002-11-04 | 2003-12-31 | 303d? | finish no earlier than 2003-12-31 | S2 | 2424h | 2424h | Rel-6 |  |  |  |  |  |
| 1080 | 1.325.3.2 | Stage 3 |  | 519d? | 2002-12-13 A | 2004-12-08 A | 100% | 2002-12-13 | 2004-12-08 | 519d? | finish no earlier than 2004-12-08 | N1 | 4152h | 4152h | Rel-6 | Lucent | Keith Drage (drage@lucent.com) |  |  |  |
| 1081 | 16.11 | **IMS Messaging** |  | 992d? | 2002-03-14 A | 2005-12-30 A | 100% | 2002-03-14 | 2005-12-30 | 992d? |  | S1 | 23912h | 23912h | Rel-6 | Nokia | juha.kalliokulju@nokia.com | IMSM |  |  |
| 1082 | 16.11.1 | TR on support of messaging in the IMS |  | 193d | 2002-03-14 A | 2002-12-09 A | 100% | 2002-03-14 | 2002-12-09 | 193d | finish no earlier than 2002-12-09 | S1 | 1544h | 1544h | Rel-6 | Nokia | juha.kalliokulju@nokia.com | IMSM-TR |  |  |
| 1083 | 1.325.4.2 | Stage 1 22.340 |  | 23d? | 2002-11-11 A | 2002-12-11 A | 100% | 2002-11-11 | 2002-12-11 | 23d? | finish no earlier than 2002-12-11 | S1 | 184h | 184h | Rel-6 | Nokia | juha.kalliokulju@nokia.com | IMSM-TS | 22.340 |  |
| 1084 | 1.325.4.3 | CRs to 22.140 & 22.228 |  | 263d? | 2002-03-14 A | 2003-03-17 A | 100% | 2002-03-14 | 2003-03-17 | 263d? | finish no earlier than 2003-03-17 | S1 | 2104h | 2104h | Rel-6 | Nokia | juha.kalliokulju@nokia.com | IMSM-CR | 22.140,22.228 |  |
| 1085 | 16.11.3 | Stage 2 |  | 477d | 2002-11-04 A | 2004-08-31 A | 100% | 2002-11-04 | 2004-08-31 | 477d | finish no earlier than 2004-08-31 | S2 | 3816h | 3816h | Rel-6 |  |  |  |  |  |
| 1086 | 1.325.4.5 | Stage 3 for IMS Messaging |  | 519d? | 2002-12-13 A | 2004-12-08 A | 100% | 2002-12-13 | 2004-12-08 | 519d? | finish no earlier than 2004-12-08 | N1 | 4152h | 4152h | Rel-6 | Lucent | Keith Drage (drage@lucent.com) |  |  |  |
| 1087 | 1.325.4.6 | SIP/SIMPLE Instant messaging |  | 522d? | 2004-01-01 A | 2005-12-30 A | 100% | 2004-01-01 | 2005-12-30 | 522d? | finish no earlier than 2005-06-30 | OMA | 4176h | 4176h | Rel-6 |  | OMA-LIAISON@mail.openmobilealliance.org |  |  |  |
| 1088 | 1.325.5 | **Additional SIP Capabilities support not covered by Rel-5** |  | 680d? | 2002-11-11 A | 2005-06-17 A | 100% | 2002-11-11 | 2005-06-17 | 680d? |  | N1 | 13392h | 13392h | Rel-6 |  |  |  |  |  |
| 1089 | 1.325.5.1 | Stage 2 for add SIP cap (e.g. forking) |  | 335d? | 2002-11-11 A | 2004-02-20 A | 100% | 2002-11-11 | 2004-02-20 | 335d? | finish no earlier than 2004-02-20 | S2 | 2680h | 2680h | Rel-6 |  |  |  |  |  |
| 1090 | 1.325.5.2 | Stage 3 for Additional SIP Capabilities |  | 454d? | 2002-12-13 A | 2004-09-08 A | 100% | 2002-12-13 | 2004-09-08 | 454d? | finish no earlier than 2004-09-08 | N1 | 3632h | 3632h | Rel-6 | Lucent | Keith Drage (drage@lucent.com) |  |  |  |
| 1091 | 1.325.5.3 | Procedured associated with IMS-ALG |  | 205d? | 2004-09-06 A | 2005-06-17 A | 100% | 2004-09-06 | 2005-06-17 | 205d? | start no earlier than 2004-09-06 | N1 | 1640h | 1640h | Rel-6 |  |  |  |  |  |
| 1092 | 1.325.6 | Review additional SIP Capabilities against IMS |  | 454d? | 2002-12-13 A | 2004-09-08 A | 100% | 2002-12-13 | 2004-09-08 | 454d? | finish no earlier than 2004-09-08 | N1 | 3632h | 3632h | Rel-6 | Lucent | Keith Drage (drage@lucent.com) |  |  |  |
| 1093 | 16.5 | **Interworking between IMS and IP networks** |  | 1118d? | 2000-08-28 A | 2004-12-08 A | 100% | 2000-08-28 | 2004-12-08 | 1118d? |  | N3 | 31712h | 31712h | Rel-6 | BT | nigel.holland@bt.com | IMS-CCR-IWIP | 23.821, 29.061, 29.162 |  |
| 1094 | 16.5.1 | Interworking for 3GPP_SIP and IETF_SIP |  | 730d | 2000-08-28 A | 2003-06-13 A | 100% | 2000-08-28 | 2003-06-13 | 730d | finish no earlier than 2003-06-13 | N3 | 5840h | 5840h | Rel-6 | Siemens | Thomas Belling |  | New 29.962 |  |
| 1095 | 16.5.2 | Interworking for IPv6 to IPv4 |  | 1118d | 2000-08-28 A | 2004-12-08 A | 100% | 2000-08-28 | 2004-12-08 | 1118d | finish no earlier than 2004-12-08 | N3 | 8944h | 8944h | Rel-6 |  |  |  | 29.163 |  |
| 1096 | 1.325.7.3 | Interworking for IPv6 to IPv4 (SIP / SDP aspects) |  | 87d? | 2004-05-11 A | 2004-09-08 A | 100% | 2004-05-11 | 2004-09-08 | 87d? | finish no earlier than 2004-09-08 | N1 | 696h | 696h | Rel-6 |  |  |  |  |  |
| 1097 | 16.8.1 | stage 3 of interworking with non-IMS IP networks |  | 911d | 2001-03-14 A | 2004-09-08 A | 100% | 2001-03-14 | 2004-09-08 | 911d | finish no earlier than 2004-09-08 | N1 | 7288h | 7288h | Rel-6 |  |  |  |  |  |
| 1098 | 16.6.1 | Interworking between IMS and CS networks |  | 929d? | 2000-08-28 A | 2004-03-18 A | 100% | 2000-08-28 | 2004-03-18 | 929d? | finish no earlier than 2004-03-18 | N3 | 7432h | 7432h | Rel-6 | Vodafone | brendan.mcwilliams@vf.vodafone.co.uk | IMS-CCR-IWCS | 29.163, 29.061, 24.228, and new CN4 specification |  |
| 1099 | 16.10 | Mn interface (IM-MGW to MGCF) enhancements (CN4 Part) |  | 418d | 2001-08-07 A | 2004-09-01 A | 100% | 2001-08-07 | 2004-09-01 | 418d | finish no earlier than 2004-09-01 | N4 | 3344h | 3344h | Rel-6 |  |  | IMS-CCR-Mn |  |  |
| 1100 | 1.325.10 | Study of subscriber and operators relationship in IMS and related ISIM requirements for Rel 6” |  | 20d? | 2002-11-15 A | 2002-12-12 A | 100% | 2002-11-15 | 2002-12-12 | 20d? | finish no earlier than 2002-12-12 | S1 | 160h | 160h | Rel-6 | Nokia | juha.kalliokulju@nokia.com |  |  |  |
| 1101 | 1.325.11 | Lawful Interception in the 3GPP Rel-6 architecture |  | 269d? | 2002-12-09 A | 2003-12-18 A | 100% | 2002-12-09 | 2003-12-18 | 269d? | finish no earlier than 2003-12-18 | S3 | 2152h | 2152h | Rel-6 | Reg TP | Berthold.Wilhelm@REGTP.DE | SEC1-LI | 33.106, 33.107, 33.108 |  |
| 1102 | 1.325.12 | IMS Subscription and access scenarios |  | 130d? | 2002-12-16 A | 2003-06-13 A | 100% | 2002-12-16 | 2003-06-13 | 130d? | start no earlier than 2002-12-16 | S1 | 1040h | 1040h | Rel-6 |  |  |  | 22.800 |  |
| 1103 | 1.325.13 | IMS charging |  | 455d? | 2003-03-21 A | 2004-12-16 A | 100% | 2003-03-21 | 2004-12-16 | 455d? | finish no earlier than 2004-12-16 | S5 | 3640h | 3640h | Rel-6 |  |  | IMS2-CH | 32.260 |  |
| 1104 | 1.325.14 | IMS Management objects |  | 306d? | 2004-09-03 A | 2005-11-05 A | 100% | 2004-09-03 | 2005-11-05 | 306d? | finish no earlier than 2005-03-04 | N1 | 2448h | 2448h | Rel-6 |  |  |  | 24.167 |  |
| 1105 | 1.325.15 | Deleted - Stage 2 of IMS Phase 2 | milestone | 0d? | 2003-09-19 A | 2003-09-19 A | 100% | 2003-09-19 | 2003-09-19 | 0d? | finish no earlier than 2003-09-19 | S2 |  |  | Rel-6 |  |  |  |  | SP-24 |

Notes:
- 1080: Depends on CN decision on IETF dependencies in Rel-6. Higher figure if CPCP is dropped (-> LS to CN plenary)
- 1087: Updated according to SP-040232
- 1093: [DAB 14.02.02] - end date pushed back to March 2003
- 1094: [DAB - 20.08.03] - CN Part of TR Complete @ CN#20
- 1098: [DAB - 25.05.04] - CN3 consider this work to be complete
- 1099: TISPAN issue is open
- 1103: SA#26 12/2004 completed

| ID | WBS | Task | Type | Duration | Start | Finish | Complete | Baseline start | Baseline finish | Baseline duration | Constraint | Resources | Work | Actual work | Text1 | Text3 | Text4 | Text5 | Text6 | Text8 | Text10 |
| --- | --- | --- | --- | --- | --- | --- | --- | --- | --- | --- | --- | --- | --- | --- | --- | --- | --- | --- | --- | --- | --- |
| 1106 | 1.326 | **3GPP Enablers for services like Push to Talk over Cellular (PoC)** |  | 459d? | 2003-09-08 A | 2005-06-09 A | 100% | 2003-09-08 | 2005-06-09 | 459d? |  | S2 | 10696h | 10696h | PoC | 23.979 | Ericsson | Shabnam Sultana | Rel-6 | Sang-Ui |  |
| 1107 | 1.326.1 | Feasibility Study |  | 322d? | 2003-09-08 A | 2004-11-30 A | 100% | 2003-09-08 | 2004-11-30 | 322d? | finish no earlier than 2004-11-30 | S2 | 2576h | 2576h | PoC | 23.979 | Ericsson | Shabnam Sultana | Rel-6 |  | SP-24 |
| 1108 | 1.326.2 | Dependencies on OMA PoC |  | 303d? | 2004-01-01 A | 2005-02-28 A | 100% | 2004-01-01 | 2005-02-28 | 303d? | finish no earlier than 2004-12-30 | OMA | 2424h | 2424h | PoC |  |  | OMA-LIAISON@mail.openmobilealliance.org | Rel-6 |  | SP-24 |
| 1109 | 1.326.3 | Selection of one or more PoC codec(s) for PoC |  | 69d? | 2004-09-13 A | 2004-12-16 A | 100% | 2004-09-13 | 2004-12-16 | 69d? | start no earlier than 2004-09-13 | S4 | 552h | 552h | PoC | 26.235, 26.236 |  |  | Rel-6 | Paolo | SP-25 |
| 1110 | 1.326.4 | PoC charging |  | 184d? | 2004-09-27 A | 2005-06-09 A | 100% | 2004-09-27 | 2005-06-09 | 184d? | finish no earlier than 2005-06-09 | S5 | 1472h | 1472h | PoC-CH | 32.272 |  |  | Rel-6 |  |  |
| 1111 | 1.327 | Interworking aspects and migration scenarios for IPv4 based IMS Implementations (Study) |  | 210d? | 2003-09-08 A | 2004-06-25 A | 100% | 2003-09-08 | 2004-06-25 | 210d? | finish no earlier than 2004-06-25 | S2 | 1680h | 1680h | IPv4IMS | 23.881 | Siemens | Alexander Milinski | Rel-6 | Sang-Ui |  |
| 1112 | 16.3 | **Interoperability and Commonality between IMS using different "IP-connectivity Networks"** |  | 325d? | 2002-09-16 A | 2003-12-12 A | 100% | 2002-09-16 | 2003-12-12 | 325d? |  | S2 | 9176h | 9176h | IMSCOOP | 23.864 |  |  | Rel-6 | Sang-Ui |  |
| 1113 | 16.3.1 | Stage 2 for Interoperability |  | 272d | 2002-09-16 A | 2003-09-30 A | 100% | 2002-09-16 | 2003-09-30 | 272d | finish no earlier than 2003-09-30 | S2 | 2176h | 2176h |  | 23.864 | Nokia | Balazs Beternyi | Rel-6 |  |  |
| 1114 | 1.328.2 | Stage 2 for commonality |  | 265d? | 2002-09-16 A | 2003-09-19 A | 100% | 2002-09-16 | 2003-09-19 | 265d? | start no earlier than 2002-09-16 | S2 | 2120h | 2120h |  | 23.864 | Nokia | Balazs Beternyi | Rel-6 |  |  |
| 1115 | 16.3.2 | Stage 3 |  | 305d | 2002-10-14 A | 2003-12-12 A | 100% | 2002-10-14 | 2003-12-12 | 305d | finish no earlier than 2003-12-12 | N1 | 2440h | 2440h |  |  | Lucent | Keith Drage (drage@lucent.com) | Rel-6 |  |  |
| 1116 | 17 | **Support of Push Services** |  | 823d | 2001-01-03 A | 2004-02-27 A | 100% | 2001-01-03 | 2004-02-27 | 823d |  | S1 | 11390.6h | 11390.6h | PUSH | 23.976 | NTT Comware | Yoshinori Kitada | Rel-6 | Sang-Ui |  |
| 1117 | 17.1 | Stage 1 |  | 378d | 2001-01-03 A | 2002-06-14 A | 100% | 2001-01-03 | 2002-06-14 | 378d | finish no earlier than 2002-06-14 | S1 | 3024h | 3024h |  |  |  |  | Rel-6 |  |  |
| 1118 | 17.3 | TR 23.976 on Push Architecture |  | 340d | 2002-11-11 A | 2004-02-27 A | 100% | 2002-11-11 | 2004-02-27 | 340d | finish no earlier than 2004-02-27 | S2 | 2720h | 2720h |  | 23.976 | RIM | Nick Alfano | Rel-6 |  |  |
| 1119 | 18 | **Multimedia Messaging (MMS) enhancements** |  | 865d? | 2002-08-15 A | 2005-12-07 A | 100% | 2002-08-15 | 2005-12-07 | 865d? |  | T2 | 31936h | 31936h | MMS6 |  | Siemens | Josef.Laumen@SAL.SIEMENS.DE | Rel-6 | Friedhelm |  |
| 1120 | 18.1 | **Definition of service requirements** |  | 286d? | 2002-11-15 A | 2003-12-19 A | 100% | 2002-11-15 | 2003-12-19 | 286d? |  | S1 | 4576h | 4576h | MMS6-SR | 22.140 |  |  | Rel-6 |  |  |
| 1121 | 1.330.1.1 | Definition of service requirements charging |  | 286d? | 2002-11-15 A | 2003-12-19 A | 100% | 2002-11-15 | 2003-12-19 | 286d? | finish no earlier than 2003-12-20 | S1 | 2288h | 2288h |  | 22.140 | Siemens | Josef.Laumen@SAL.SIEMENS.DE | Rel-6 |  |  |
| 1122 | 18.2 | Technical realization |  | 591d | 2002-09-06 A | 2004-12-10 A | 100% | 2002-09-06 | 2004-12-10 | 591d | finish no earlier than 2004-12-10 | T2 | 4728h | 4728h |  | 23.140 | Siemens | Josef.Laumen@SAL.SIEMENS.DE | Rel-6 | Friedhelm |  |
| 1123 | 18.3 | OMA dependencies |  | 446d | 2003-08-15 A | 2005-04-29 A | 100% | 2003-08-15 | 2005-04-29 | 446d | finish no earlier than 2004-12-10 | OMA | 3568h | 3568h |  | OMA specs |  |  | Rel-6 | Friedhelm |  |
| 1124 | 18.4 | MMS formats and codecs |  | 865d | 2002-08-15 A | 2005-12-07 A | 100% | 2002-08-15 | 2005-12-07 | 865d | finish no earlier than 2005-12-07 | S4 | 6920h | 6920h | MMS6-Codec | 26.140, 26.936 | Nokia | roberto.castagno@nokia.com | Rel-6 | Paolo |  |
| 1125 | 1.330.5 | Handling of private addressing schemes in MMS |  | 263d | 2003-12-10 A | 2004-12-10 A | 100% | 2003-12-10 | 2004-12-10 | 263d | finish no earlier than 2004-12-10 | T2 | 2104h | 2104h |  | 23.140 | T-Mobile | Steffen.Habermann@T-MOBILE.DE | Rel-6 | Friedhelm |  |
| 1126 | 1.330.6 | MMS charging |  | 390d? | 2003-03-21 A | 2004-09-16 A | 100% | 2003-03-21 | 2004-09-16 | 390d? | start no earlier than 2003-03-21 | S5 | 3120h | 3120h | MMS6-CH | 32.270 |  |  | Rel-6 |  |  |
| 1127 | 1.330.7 | Deleted - FS Multiple MMS Relay/Server Architecture | milestone | 0d | 2004-12-10 A | 2004-12-10 A | 100% | 2004-12-10 | 2004-12-10 | 0d | finish no earlier than 2004-12-10 | T2 |  |  |  | probably Annex to 23.140 | Telefónica Móviles | Juan Gorospe (gorospe_j@tsm.es) | Rel-6 | Friedhelm |  |
| 1128 | 19 | **Rel-6 MExE enhancements** |  | 326d | 2002-03-08 A | 2003-06-06 A | 100% | 2002-03-08 | 2003-06-06 | 326d |  | T2 | 7328h | 7328h | MEXE6 |  |  |  | Rel-6 | Friedhelm |  |
| 1129 | 19.1 | MExE Rel-6 Improvements and Investigations |  | 264d | 2002-03-08 A | 2003-03-12 A | 100% | 2002-03-08 | 2003-03-12 | 264d | finish no earlier than 2003-03-12 | T2 | 2112h | 2112h | MEXE6-ENHANC | 22.057, 23.057 | TTPCom | Lars Brenk ( (lsb_ttpcom@HOTMAIL.COM) | Rel-6 |  |  |
| 1130 | 19.2 | MExE Run-Time Independent Framework Feasibility Study |  | 326d | 2002-03-08 A | 2003-06-06 A | 100% | 2002-03-08 | 2003-06-06 | 326d | finish no earlier than 2003-06-06 | T2 | 2608h | 2608h | MEXE6-RTIF | 22.857 | Intel | Aaron.Cohen@intel.com | Rel-6 |  |  |
| 1131 | 21 | Subscription Management |  | 650d | 2002-09-20 A | 2005-03-17 A | 100% | 2002-09-20 | 2005-03-17 | 650d | finish no earlier than 2005-03-17 | S5 | 5200h | 5200h | SuM | 32.140/1, 32.171/2/5, 32.803 | T-Mobile | istvan.aba@t-mobile.at | Rel-6 | Adrian |  |

Notes:
- 1108: Updated according to SP-040232
- 1109: Completed
- 1110: SA#28 06/2005 completed
- 1113: No contributions assumed that no more will be done in 3GPP hence work may need to be done in 3GPP2
- 1116: AS: Changed from FS to actual support of Push
- 1126: SA#25 09/2004 completed
- 1127: originally it was intended to create a FS TR but most likely the work will become an Annex of 23.140
- 1131: SA#27 03/2005 completed

| ID | WBS | Task | Duration | Start | Finish | Complete | Remaining | Baseline start | Baseline finish | Baseline duration | Total slack | Constraint | Resources | Work | Actual work | Text1 | Text4 | Text5 | Text6 | Text8 | Text3 |
| --- | --- | --- | --- | --- | --- | --- | --- | --- | --- | --- | --- | --- | --- | --- | --- | --- | --- | --- | --- | --- | --- |
| 1132 | 22 | **Presence Capability** | 1233d? | 2001-03-19 A | 2005-12-07 | 99% | 2.86d? | 2001-03-19 | 2005-12-07 | 1233d? | 1112d |  | S1 | 37112h | 35973.5h | PRESNC | Motorola | Mark Cataldo | Rel-6 | Michael |  |
| 1133 | 22.1 | Stage 1 | 610d | 2001-03-19 A | 2003-07-18 A | 100% |  | 2001-03-19 | 2003-07-18 | 610d |  | finish no earlier than 2003-07-18 | S1 | 4880h | 4880h |  |  |  | Rel-6 |  | 22.141 |
| 1134 | 22.2 | Stage 2 | 268d | 2001-09-12 A | 2002-09-20 A | 100% |  | 2001-09-12 | 2002-09-20 | 268d |  | finish no earlier than 2002-09-20 | S2 | 2144h | 2144h |  | Nokia | Balazs Beternyi | Rel-6 |  |  |
| 1135 | 22.3 | Stage 3 | 703d | 2002-04-01 A | 2004-12-08 A | 100% |  | 2002-04-01 | 2004-12-08 | 703d |  | finish no earlier than 2004-12-08 | N1 | 5624h | 5624h |  | Lucent | Keith Drage (drage@lucent.com) | Rel-6 |  |  |
| 1136 | 1.333.4 | Stage 3 (CN3 Part Pk interface) | 770d? | 2002-04-01 A | 2005-03-11 A | 100% |  | 2002-04-01 | 2005-03-11 | 770d? |  | finish no earlier than 2005-03-11 | N3 | 6160h | 6160h |  |  |  | Rel-6 |  |  |
| 1137 | 1.333.5 | Media Codecs and Formats for IMS Messaging and Presence | 650d? | 2003-06-12 A | 2005-12-07 A | 100% |  | 2003-06-12 | 2005-12-07 | 650d? |  | finish no earlier than 2005-12-07 | S4 | 5200h | 5200h | PRESNC-COFIMP | Nokia | harri.honko@nokia.com | Rel-6 | Paolo | 26.141, 26.936 |
| 1138 | 22.4 | Security issues | 79d | 2002-08-26 A | 2002-12-12 | 90% | 7.9d | 2002-08-26 | 2002-12-12 | 79d | 1891d | finish no earlier than 2002-12-12 | S3 | 632h | 568.8h |  |  |  | Rel-6 |  |  |
| 1139 | 1.333.7 | SIMPLE Presence | 326d? | 2004-01-01 A | 2005-03-31 A | 100% |  | 2004-01-01 | 2005-03-31 | 326d? |  | finish no earlier than 2004-12-30 | OMA | 2608h | 2608h |  |  | OMA-LIAISON@mail.openmobilealliance.org | Rel-6 |  |  |
| 1140 | 25 | **Enhanced A/Gb feasibility study** | 51d? | 2002-08-30 A | 2002-11-08 A | 100% |  | 2002-08-30 | 2002-11-08 | 51d? |  |  | GP | 3264h | 3264h | AGbEnFS | Vodafone | jose-luis.carrizo@vodafone.co.uk | Rel-6 | Paolo |  |
| 1141 | 25.1 | **Feasibility study on A/Gb enhancements** | 51d? | 2002-08-30 A | 2002-11-08 A | 100% |  | 2002-08-30 | 2002-11-08 | 51d? |  |  | G2 | 2856h | 2856h | AGbEnFS-FS |  |  | Rel-6 |  |  |
| 1142 | 25.1.1 | Requirements for the support of conversational services | 51d | 2002-08-30 A | 2002-11-08 A | 100% |  | 2002-08-30 | 2002-11-08 | 51d |  | finish no earlier than 2002-11-08 | GP | 408h | 408h |  |  |  | Rel-6 |  |  |
| 1143 | 1.334.1.2 | Identification of the different building blocks for the provision of conversational services on the existing A/Gb protocol stack | 51d? | 2002-08-30 A | 2002-11-08 A | 100% |  | 2002-08-30 | 2002-11-08 | 51d? |  | finish no earlier than 2002-11-08 | GP | 408h | 408h |  |  |  | Rel-6 |  |  |
| 1144 | 1.334.1.3 | Outline of impact and feasibility of these building blocks and their different solutions | 51d? | 2002-08-30 A | 2002-11-08 A | 100% |  | 2002-08-30 | 2002-11-08 | 51d? |  | finish no earlier than 2002-11-08 | GP | 408h | 408h |  |  |  | Rel-6 |  |  |
| 1145 | 25.1.4 | Impact on 3GPP architecture and requirement to co-ordinatge with other TSGs (CN, SA) | 51d | 2002-08-30 A | 2002-11-08 A | 100% |  | 2002-08-30 | 2002-11-08 | 51d |  | finish no earlier than 2002-11-08 | GP | 408h | 408h |  |  |  | Rel-6 |  |  |
| 1146 | 25.1.5 | Standardisation effort | 51d | 2002-08-30 A | 2002-11-08 A | 100% |  | 2002-08-30 | 2002-11-08 | 51d |  | finish no earlier than 2002-11-08 | GP | 408h | 408h |  |  |  | Rel-6 |  |  |
| 1147 | 25.1.6 | Dependency to other features | 51d | 2002-08-30 A | 2002-11-08 A | 100% |  | 2002-08-30 | 2002-11-08 | 51d |  | finish no earlier than 2002-11-08 | GP | 408h | 408h |  |  |  | Rel-6 |  |  |
| 1148 | 26 | **Flexible Layer One for GERAN** | 1170d | 2000-01-03 A | 2004-06-25 A | 100% |  | 2000-01-03 | 2004-06-25 | 1170d |  |  | GP | 71535h | 71535h | FLOGER | Nokia | benoist.sebire@nokia.com | Rel-6 | Paolo |  |
| 1149 | 26.1 | **Realisation of a Flexible Layer One** | 1125d | 2000-01-03 A | 2004-04-23 A | 100% |  | 2000-01-03 | 2004-04-23 | 1125d |  |  | GP | 42808h | 42808h | FLOGER-Real | Nokia | benoist.sebire@nokia.com | Rel-6 |  |  |
| 1150 | 26.1.1 | Technical Report | 471d | 2002-04-19 A | 2004-02-06 A | 100% |  | 2002-04-19 | 2004-02-06 | 471d |  | finish no earlier than 2004-02-06 | GP | 3768h | 3768h |  |  |  | Rel-6 |  |  |
| 1151 | 26.1.2 | Architecture in 45.001 and 43.051 | 526d | 2002-04-19 A | 2004-04-23 A | 100% |  | 2002-04-19 | 2004-04-23 | 526d |  | finish no earlier than 2004-04-23 | G1 | 4208h | 4208h |  |  |  | Rel-6 |  |  |
| 1152 | 26.1.3 | Multiplexing in 45.002 | 526d | 2002-04-19 A | 2004-04-23 A | 100% |  | 2002-04-19 | 2004-04-23 | 526d |  | finish no earlier than 2004-04-23 | G1 | 4208h | 4208h |  |  |  | Rel-6 |  |  |
| 1153 | 26.1.4 | Channel Coding in 45.003 | 526d | 2002-04-19 A | 2004-04-23 A | 100% |  | 2002-04-19 | 2004-04-23 | 526d |  | finish no earlier than 2004-04-23 | G1 | 4208h | 4208h |  |  |  | Rel-6 |  |  |
| 1154 | 26.1.5 | Performance Requirements in 45.005 | 1125d | 2000-01-03 A | 2004-04-23 A | 100% |  | 2000-01-03 | 2004-04-23 | 1125d |  | finish no earlier than 2004-04-23 | G1 | 9000h | 9000h |  |  |  | Rel-6 |  |  |
| 1155 | 26.1.6 | Radio subsystem link control in 45.008 | 526d | 2002-04-19 A | 2004-04-23 A | 100% |  | 2002-04-19 | 2004-04-23 | 526d |  | finish no earlier than 2004-04-23 | G1 | 4208h | 4208h |  |  |  | Rel-6 |  |  |
| 1156 | 26.1.7 | Requirements in 44.004 | 526d | 2002-04-19 A | 2004-04-23 A | 100% |  | 2002-04-19 | 2004-04-23 | 526d |  | finish no earlier than 2004-04-23 | G2 | 4208h | 4208h |  |  |  | Rel-6 |  |  |

Notes:
- 1132: A Sultan merged "Presence Service Enhancements" (UID31028, PRES1) to this feature as no answer was provided on why Presence and Presence Encmts had same target completion date
- 1135: Dependency to 2 IETF drafts, no known work at the moment
- 1136: No Contributions so far - only requires a little work
- 1138: LSs handled in SA3. WID approved SA#17 Contribution at S3#25 & following e-mail discussion.
- 1139: Updated according to SP-040232
- 1140: Closed
- 1148: Nokia, Ericsson, Siemens, Telia
- 1149: Completed

| ID | WBS | Task | Type | Duration | Start | Finish | Complete | Baseline start | Baseline finish | Baseline duration | Constraint | Resources | Work | Actual work | Text1 | Text4 | Text5 | Text6 | Text3 | Text8 | Text12 |
| --- | --- | --- | --- | --- | --- | --- | --- | --- | --- | --- | --- | --- | --- | --- | --- | --- | --- | --- | --- | --- | --- |
| 1157 | 26.2 | **Signalling and protocol support for a Flexible Layer One** |  | 571d | 2002-04-19 A | 2004-06-25 A | 100% | 2002-04-19 | 2004-06-25 | 571d |  | G2 | 13704h | 13704h | FLOGER-SigPro | Nokia | benoist.sebire@nokia.com | Rel-6 |  |  |  |
| 1158 | 26.2.1 | Modifications to RLC/MAC in 44.060 and 44.160 |  | 571d | 2002-04-19 A | 2004-06-25 A | 100% | 2002-04-19 | 2004-06-25 | 571d | finish no earlier than 2004-06-25 | G2 | 4568h | 4568h |  |  |  | Rel-6 |  |  |  |
| 1159 | 26.2.2 | Modifications to RRC in 44.118 and 44.018 |  | 571d | 2002-04-19 A | 2004-06-25 A | 100% | 2002-04-19 | 2004-06-25 | 571d | finish no earlier than 2004-06-25 | G2 | 4568h | 4568h |  |  |  | Rel-6 |  |  |  |
| 1160 | 26.3 | **Security for a Flexible Layer One** |  | 356d | 2002-04-19 A | 2003-08-29 A | 100% | 2002-04-19 | 2003-08-29 | 356d |  | S3, G2 | 5663.03h | 5663.03h | FLOGER-SecFLO | Nokia | benoist.sebire@nokia.com | Rel-6 |  |  |  |
| 1161 | 26.3.1 | Ciphering in 44.160,44.118, 44.060 and 44.018 |  | 356d | 2002-04-19 A | 2003-08-29 A | 100% | 2002-04-19 | 2003-08-29 | 356d | finish no earlier than 2003-08-29 | S3, G2 | 2848h | 2848h |  |  |  | Rel-6 |  |  |  |
| 1162 | 26.4 | **Deleted at TSG#27 - GERAN MS Conformance test for the Flexible Layer One - DELETE** |  | 0d | 2004-02-06 A | 2004-02-06 A | 100% | 2004-02-06 | 2004-02-06 | 0d |  | G4; G5 |  |  | FLOGER-Msconf | Nokia | benoist.sebire@nokia.com | Rel-6 |  |  |  |
| 1163 | 26.4.1 | deleted at TSG #27 - MS Test in 51.010 | milestone | 0d | 2004-02-06 A | 2004-02-06 A | 100% | 2004-02-06 | 2004-02-06 | 0d | finish no earlier than 2004-02-06 | G4; G5 |  |  |  |  |  | Rel-6 |  |  |  |
| 1164 | 26.5 | **Deleted at TSG#27 - GERAN BTS Conformance test for the Flexible Layer One - DELETE** |  | 0d | 2004-02-06 A | 2004-02-06 A | 100% | 2004-02-06 | 2004-02-06 | 0d |  | G3 |  |  | FLOGER-BTSconf | Nokia | benoist.sebire@nokia.com | Rel-6 |  |  |  |
| 1165 | 26.5.1 | Deleted at TGS #27 - BTS Test in 51.021 - DELETE | milestone | 0d | 2004-02-06 A | 2004-02-06 A | 100% | 2004-02-06 | 2004-02-06 | 0d | finish no earlier than 2004-02-06 | G3 |  |  |  |  |  | Rel-6 |  |  |  |
| 1166 | 27 | Uplink TDOA feasibility study |  | 151d | 2001-11-30 A | 2002-06-28 A | 100% | 2001-11-30 | 2002-06-28 | 151d | finish no earlier than 2002-06-28 | GP | 1208h | 1208h | TDOAF | TruePosition | Bob Gross (rlgross@trueposition.com) | Rel-6 | 45.811 | Paolo |  |
| 1167 | 28 | **Multimedia Broadcast and Multicast Service** |  | 1781d? | 2001-05-11 A | 2008-03-07 A | 100% | 2001-05-11 | 2008-03-07 | 1781d? |  | S1 | 158281h | 158281h | MBMS |  |  | Rel-6 |  | Michael |  |
| 1168 | 28.1 | Stage 1 |  | 232d | 2001-05-11 A | 2002-04-01 A | 100% | 2001-05-11 | 2002-04-01 | 232d | finish no earlier than 2002-04-01 | S1 | 1856h | 1856h |  |  |  | Rel-6 | 22.146, 22.101 |  |  |
| 1169 | 28.2 | **Stage 2** |  | 648d | 2001-09-24 A | 2004-03-17 A | 100% | 2001-09-24 | 2004-03-17 | 648d |  | S2 | 10408h | 10408h |  |  |  | Rel-6 |  |  |  |
| 1170 | 28.2.1 | TR on Architectural Study |  | 240d | 2001-09-24 A | 2002-08-23 A | 100% | 2001-09-24 | 2002-08-23 | 240d | finish no earlier than 2002-08-23 | S2 | 1920h | 1920h |  |  |  | Rel-6 | 23.846 |  |  |
| 1171 | 28.2.2 | Stage 2 Specification Work |  | 413d | 2002-08-19 A | 2004-03-17 A | 100% | 2002-08-19 | 2004-03-17 | 413d | finish no earlier than 2004-03-17 | S2 | 3304h | 3304h |  |  |  | Rel-6 | 23.246 |  |  |
| 1172 | 28.3 | **Introduction of MBMS in RAN** |  | 967d? | 2002-01-01 A | 2005-09-15 A | 100% | 2002-01-01 | 2005-09-15 | 967d? |  | R2 | 15992h | 15992h | MBMS-RAN | Nokia | juho.pirskanen@nokia.com | Rel-6 | 25.346, 25.304, 25.321, 25.322, 25.323, 25.331 | MCC_RAN |  |
| 1173 | 1.337.3.1 | Introduction of MBMS in RAN (physical & upper layers, access network interfaces) |  | 771d? | 2002-01-01 A | 2004-12-14 A | 100% | 2002-01-01 | 2004-12-14 | 771d? | finish no earlier than 2004-12-14 | R2 | 6168h | 6168h | MBMS-RAN | Nokia | juho.pirskanen@nokia.com | Rel-6 | 25.346, 25.304, 25.321, 25.322, 25.323 | MCC_RAN |  |
| 1174 | 1.337.3.2 | UE Performance Requirements for MBMS |  | 261d? | 2004-09-15 A | 2005-09-15 A | 100% | 2004-09-15 | 2005-09-15 | 261d? | finish no earlier than 2005-09-15 | R4 | 2088h | 2088h | MBMS-RAN-RF | Ericsson | Torgny.Palenius@ericsson.com | Rel-6 | 25.101, 25.133 | MCC_RAN |  |
| 1175 | 28.4 | Support of the MBMS in CN protocols |  | 647d | 2002-06-18 A | 2004-12-08 A | 100% | 2002-06-18 | 2004-12-08 | 647d | finish no earlier than 2004-12-08 | N1 | 5176h | 5176h |  |  |  | Rel-6 |  |  |  |
| 1176 | 1.337.5 | Gmb interface for MBMS (CN3 part) |  | 334d | 2003-08-29 A | 2004-12-08 A | 100% | 2003-08-29 | 2004-12-08 | 334d | finish no earlier than 2004-12-08 | N3 | 2672h | 2672h |  |  |  | Rel-6 | 29.061 |  |  |
| 1177 | 28.5 | Security Aspects of MBMS |  | 710d | 2002-07-01 A | 2005-03-18 A | 100% | 2002-07-01 | 2005-03-18 | 710d | finish no earlier than 2005-03-18 | S3 | 5680h | 5680h | MBMS |  | adrian.escott@three.co.uk | Rel-6 |  |  |  |
| 1178 | 28.6 | **Support of MBMS in GERAN** |  | 892d? | 2001-08-30 A | 2005-01-28 A | 100% | 2001-08-30 | 2005-01-28 | 892d? |  | GP | 71040h | 71040h | MBMS-GERAN |  |  | Rel-6 |  |  |  |
| 1179 | 28.6.1 | Impact on the logical and physical channels |  | 631d | 2002-08-30 A | 2005-01-28 A | 100% | 2002-08-30 | 2005-01-28 | 631d | finish no earlier than 2005-01-28 | GP | 5048h | 5048h |  |  |  | Rel-6 |  |  |  |
| 1180 | 28.6.4 | Re-synchronisation at cell change |  | 631d | 2002-08-30 A | 2005-01-28 A | 100% | 2002-08-30 | 2005-01-28 | 631d | finish no earlier than 2005-01-28 | G2 | 5048h | 5048h |  |  |  | Rel-6 |  |  |  |
| 1181 | 1.337.7.3 | Simultaneous support of MBMS services |  | 631d? | 2002-08-30 A | 2005-01-28 A | 100% | 2002-08-30 | 2005-01-28 | 631d? | finish no earlier than 2005-01-28 | GP | 5048h | 5048h |  |  |  | Rel-6 |  |  |  |
| 1182 | 1.337.7.4 | Simultaneous support of MBMS and non-MBMS services |  | 892d? | 2001-08-30 A | 2005-01-28 A | 100% | 2001-08-30 | 2005-01-28 | 892d? | finish no earlier than 2005-01-28 | GP | 7136h | 7136h |  |  |  | Rel-6 |  |  |  |
| 1183 | 1.337.7.5 | Resynchronisation at cell change |  | 892d? | 2001-08-30 A | 2005-01-28 A | 100% | 2001-08-30 | 2005-01-28 | 892d? | finish no earlier than 2005-01-28 | GP | 7136h | 7136h |  |  |  | Rel-6 |  |  |  |
| 1184 | 28.6.5 | Decision making process between point-to-point or pont-to-multipoint configurations |  | 631d | 2002-08-30 A | 2005-01-28 A | 100% | 2002-08-30 | 2005-01-28 | 631d | finish no earlier than 2005-01-28 | GP | 5048h | 5048h |  |  |  | Rel-6 |  |  |  |
| 1185 | 28.6.6 | MBMS channel allocations procedures to multiple MSs |  | 631d | 2002-08-30 A | 2005-01-28 A | 100% | 2002-08-30 | 2005-01-28 | 631d | finish no earlier than 2005-01-28 | GP | 5048h | 5048h |  |  |  | Rel-6 |  |  |  |
| 1186 | 28.6.7 | Changes to the Gb interface |  | 631d | 2002-08-30 A | 2005-01-28 A | 100% | 2002-08-30 | 2005-01-28 | 631d | finish no earlier than 2005-01-28 | GP | 5048h | 5048h |  |  |  | Rel-6 |  |  |  |
| 1187 | 28.6.8 | GERAN specific changes to the Iu-ps interface |  | 631d | 2002-08-30 A | 2005-01-28 A | 100% | 2002-08-30 | 2005-01-28 | 631d | finish no earlier than 2005-01-28 | GP | 5048h | 5048h |  |  |  | Rel-6 |  |  |  |
| 1188 | 28.6.9 | Interaction between MBMS and Iu-flex |  | 631d | 2002-08-30 A | 2005-01-28 A | 100% | 2002-08-30 | 2005-01-28 | 631d | finish no earlier than 2005-01-28 | GP | 5048h | 5048h |  |  |  | Rel-6 |  |  |  |
| 1189 | 28.6.10 | Security aspects |  | 631d | 2002-08-30 A | 2005-01-28 A | 100% | 2002-08-30 | 2005-01-28 | 631d | finish no earlier than 2005-01-28 | GP | 5048h | 5048h |  |  |  | Rel-6 |  |  |  |
| 1190 | 1.337.7.12 | MS conformance tests- G3 |  | 786d? | 2002-01-25 A | 2005-01-28 A | 100% | 2002-01-25 | 2005-01-28 | 786d? | finish no earlier than 2005-01-28 | G3 | 6288h | 6288h |  |  |  | Rel-6 |  |  |  |
| 1191 | 1.337.7.13 | Deleted - MS conformance tests - G5 | milestone | 0d? | 2003-06-27 A | 2003-06-27 A | 100% | 2003-06-27 | 2003-06-27 | 0d? | start no earlier than 2003-06-27 | G5 |  |  |  |  |  | Rel-6 |  |  | GP-19 |

Notes:
- 1157: Completed
- 1160: Started
- 1162: DELETE
- 1163: DELETE
- 1164: DELETE
- 1165: DELETE
- 1167: Title renamed at SA#13
- 1168: This may or may not be a separate stage 1. In the meantime, CRs are proposed for 22.101
- 1173: Was "Introduction of MBMS in RAN" before RP#25. Created w/o WIDS after RAN approved the WT for RF aspects.Take WIDS from the parent BB
- 1174: Approved at RP#25 as RP-040370
- 1177: WID approved SA#17. 2004-12: Expected completion March 2005
- 1178: Completed
- 1190: Under evaluation

| ID | WBS | Task | Type | Duration | Start | Finish | Complete | Baseline start | Baseline finish | Baseline duration | Constraint | Deadline | Resources | Work | Actual work | Text6 | Text8 | Text1 | Text4 | Text5 | Text10 | Text12 |
| --- | --- | --- | --- | --- | --- | --- | --- | --- | --- | --- | --- | --- | --- | --- | --- | --- | --- | --- | --- | --- | --- | --- |
| 1192 | 28.1 | **MBMS User Services** |  | 743d? | 2003-05-13 A | 2006-03-16 A | 100% | 2003-05-13 | 2006-03-16 | 743d? |  |  | S1 | 13576h | 13576h | Rel-6 | Michael |  |  |  |  |  |
| 1193 | 28.1 | MBMS User Services Stage 1 |  | 233d | 2003-05-13 A | 2004-04-01 A | 100% | 2003-05-13 | 2004-04-01 | 233d | start no earlier than 2003-05-13 |  | S1 | 1864h | 1864h | Rel-6 | Michael |  |  |  |  |  |
| 1194 | 1.337.8.2 | Definition of MBMS user services, media codecs, formats and transport/application protocols using MBMS |  | 721d? | 2003-06-12 A | 2006-03-16 A | 100% | 2003-06-12 | 2006-03-16 | 721d? | finish no earlier than 2006-03-16 |  | S4 | 5768h | 5768h | Rel-6 | Paolo | MBMS-TSMBMS | Nokia | igor.curcio@nokia.com |  |  |
| 1195 | 1.337.9 | MBMS charging |  | 108d? | 2005-01-11 A | 2005-06-09 A | 100% | 2005-01-11 | 2005-06-09 | 108d? | start no earlier than 2005-01-11 |  | S5 | 864h | 864h | Rel-6 |  | MBMS-CH |  |  |  |  |
| 1196 | 1.337.10 | **MBMS UE Conformance Testing** |  | 521d? | 2006-03-10 A | 2008-03-07 A | 100% | 2006-03-10 | 2008-03-07 | 521d? |  |  | R5 | 17047.2h | 17047.2h | Rel-6 | Stoyan Baev | MBMS-UEConTest |  |  |  |  |
| 1197 | 16.5.1 | RF/RRM Conformance Test Aspects – MBMS (FDD) |  | 461d | 2006-06-02 A | 2008-03-07 A | 100% | 2006-06-02 | 2008-03-07 | 461d | finish no earlier than 2008-03-07 | 2006-06-02 | R5 | 3688h | 3688h | Rel-6 | Stoyan Baev | MBMS-RAN-RF_Test | Ericsson | leif.mattisson@ericsson.com | Fri 11/03/05 |  |
| 1198 | 1.337.10.2 | Conformance Test Aspects - MBMS for 3.84 Mcps and 7.68 Mcps TDD |  | 318d? | 2006-09-20 A | 2007-12-07 A | 100% | 2006-09-20 | 2007-12-07 | 318d? | finish no earlier than 2007-12-07 |  | R5 | 2544h | 2544h | Rel-6 | Stoyan Baev | MBMS-UEConTest_TDH | IPWireless | Timothy Speight (tspeight@ipwireless.com) |  |  |
| 1199 | 1.337.10.3 | Signalling Conformance Test Aspects – MBMS for LCR TDD |  | 318d? | 2006-09-20 A | 2007-12-07 A | 100% | 2006-09-20 | 2007-12-07 | 318d? | finish no earlier than 2007-12-07 |  | R5 | 2544h | 2544h | Rel-6 | Stoyan Baev | MBMS-UEConTest_SIGTDL | DATANG | zhaojian@datangmobile.cn |  |  |
| 1200 | 1.337.10.4 | Conformance Test Aspects – MBMS |  | 396d? | 2006-03-10 A | 2007-09-14 A | 100% | 2006-03-10 | 2007-09-14 | 396d? | finish no earlier than 2007-09-14 |  | R5 | 3168h | 3168h | Rel-6 | Stoyan Baev | MBMS_Test | Qualcomm | Shubhang Vora (svora@qualcomm.com) |  |  |
| 1201 | 16.5.1 | Conformance Test Aspects - 1.28Mcps TDD MBMS RF/RRM |  | 136d | 2007-06-01 A | 2007-12-07 A | 100% | 2007-06-01 | 2007-12-07 | 136d | finish no earlier than 2007-12-07 | 2006-06-02 | R5 | 1088h | 1088h | Rel-6 | Stoyan Baev | MBMS-UEConTest_RFTDL | Datang Mobile | chenxiaozhong@datangmobile.cn | Fri 11/03/05 |  |
| 1202 | 29 | **Speech Recognition and Speech Enabled Services** |  | 1105d? | 2001-10-08 A | 2005-12-30 A | 100% | 2001-10-08 | 2005-12-30 | 1105d? |  |  | S1 | 20176h | 20176h | Rel-6 | Michael | SRSES |  |  |  |  |
| 1203 | 29.1 | Speech Enabled Services Based on Distributed Speech Recognition (DSR) |  | 115d | 2001-10-08 A | 2002-03-15 A | 100% | 2001-10-08 | 2002-03-15 | 115d | finish no earlier than 2002-03-15 |  | S1 | 920h | 920h | Rel-6 |  | DSR | Qualcomm | Dwilliams@qualcomm.com |  |  |
| 1204 | 29.2 | TR on Architectural impacts |  | 212d | 2003-05-12 A | 2004-03-02 A | 100% | 2003-05-12 | 2004-03-02 | 212d | finish no earlier than 2004-03-02 |  | S2 | 1696h | 1696h | Rel-6 |  |  |  |  |  |  |
| 1205 | 1.338.3 | Codec Work to Support Speech Recognition Framework for Automated Voice Services |  | 568d? | 2002-10-15 A | 2004-12-16 A | 100% | 2002-10-15 | 2004-12-16 | 568d? | finish no earlier than 2004-12-16 |  | S4 | 4544h | 4544h | Rel-6 | Paolo | SRSES-Codec | Motorola | David Pearce (bdp003@motorola.com) |  |  |
| 1206 | 1.338.4 | Multimodal support |  | 522d? | 2004-01-01 A | 2005-12-30 A | 100% | 2004-01-01 | 2005-12-30 | 522d? | finish no earlier than 2005-06-30 |  | OMA | 4176h | 4176h | Rel-6 |  |  |  | OMA-LIAISON@mail.openmobilealliance.org | SP-24 |  |
| 1207 | 1.338.5 | Deleted - SES codec negotiation at SDP | milestone | 0d? | 2003-06-04 A | 2003-06-04 A | 100% | 2003-06-04 | 2003-06-04 | 0d? | start no earlier than 2003-06-04 |  | N1 |  |  | Rel-6 |  |  |  |  |  | NP-23 |
| 1208 | 30 | **Generic User Profile Rel-6** |  | 889d | 2001-10-08 A | 2005-03-03 A | 100% | 2001-10-08 | 2005-03-03 | 889d |  |  | S1 | 24295.8h | 24295.8h | Rel-6 | Michael | GUP |  |  |  |  |
| 1209 | 30.1 | Stage 1 - Requirements |  | 430d | 2001-10-08 A | 2003-05-30 A | 100% | 2001-10-08 | 2003-05-30 | 430d | finish no earlier than 2002-12-09 |  | S1 | 3440h | 3440h | Rel-6 |  |  | T-Mobile | kurt.bischinger@t-mobile.at |  |  |
| 1210 | 30.3 | Stage 2 - Architecture |  | 355d | 2002-01-28 A | 2003-06-06 A | 100% | 2002-01-28 | 2003-06-06 | 355d | finish no earlier than 2003-06-06 |  | S2 | 2840h | 2840h | Rel-6 |  |  | Nokia | harri.o.koskinen@nokia.com |  |  |
| 1211 | 30.2 | Stage 2 - Data Description Method |  | 586d | 2002-12-05 A | 2005-03-03 A | 100% | 2002-12-05 | 2005-03-03 | 586d | finish no earlier than 2005-03-03 |  | N4 | 4688h | 4688h | Rel-6 | Friedhelm |  | T-Mobile | kurt.bischinger@t-mobile.at |  |  |
| 1212 | 30.5 | Stage 3 - Network |  | 468.98d | 2003-05-19 A | 2005-03-03 A | 100% | 2003-05-19 | 2005-03-03 | 468.98d | finish no earlier than 2005-03-03 |  | N4 | 3751.83h | 3751.83h | Rel-6 |  |  |  |  |  |  |
| 1213 | 30.6 | Security Aspects |  | 308d | 2002-07-16 A | 2003-09-18 A | 100% | 2002-07-16 | 2003-09-18 | 308d | finish no earlier than 2003-09-18 |  | S3 | 2464h | 2464h | Rel-6 |  |  | Lucent | Owen, Bradley (bvowen@lucent.com) |  |  |
| 1214 | 31 | **Digital Rights Management** |  | 690d? | 2001-10-08 A | 2004-05-28 A | 100% | 2001-10-08 | 2004-05-28 | 690d? |  |  | S1 | 10152h | 10152h | Rel-6 | Michael | DRM |  |  |  |  |
| 1215 | 31.1 | Requirements |  | 179d | 2001-10-08 A | 2002-06-13 A | 100% | 2001-10-08 | 2002-06-13 | 179d | finish no earlier than 2002-06-13 |  | S1 | 1432h | 1432h | Rel-6 |  |  | Openwave | nicholas.wood@openwave.com |  |  |
| 1216 | 1.340.2 | Stage 2 |  | 107d? | 2004-01-01 A | 2004-05-28 A | 100% | 2004-01-01 | 2004-05-28 | 107d? | finish no earlier than 2004-05-28 |  | OMA | 856h | 856h | Rel-6 |  |  |  | OMA-LIAISON@mail.openmobilealliance.org | SP-24 |  |
| 1217 | 1.340.3 | Stage 3 |  | 107d? | 2004-01-01 A | 2004-05-28 A | 100% | 2004-01-01 | 2004-05-28 | 107d? | finish no earlier than 2004-05-28 |  | OMA | 856h | 856h | Rel-6 |  |  |  | OMA-LIAISON@mail.openmobilealliance.org | SP-24 |  |
| 1218 | 31.3 | Security |  | 186d | 2002-06-17 A | 2003-03-03 A | 100% | 2002-06-17 | 2003-03-03 | 186d | finish no earlier than 2003-03-03 |  | OMA | 1488h | 1488h | Rel-6 |  |  |  |  |  |  |
| 1219 | 1.340.5 | Deleted - Monitoring of Stages 2 and 3 progress (actual work to be done by OMA) | milestone | 0d? | 2003-03-21 A | 2003-03-21 A | 100% | 2003-03-21 | 2003-03-21 | 0d? | start no earlier than 2002-08-19 |  | S1 |  |  | Rel-6 |  |  |  |  |  |  |

Notes:
- 1192: Text3: 22.246
- 1193: Text3: 22.246
- 1194: TR26.946 tbc by March 06 / Text3: 26.346, 26.936, 26.946
- 1195: SA#28 06/2005 completed / Text3: 32.273
- 1196: BB place holder for a number of RAN5 Tasks. Moved in from the Stoyan/Testing WP / Text3: 34.108, 34.109, 34.121-1, 34.121-2, 34.122, 34.123-1, 34.123-2, 34.123-3
- 1197: TS 34.109 is under RAN2; RAN5 need to identify possible new requirements on UE test loop functionality to enable testing / Text3: 34.108, 34.109, 34.121-1, 34.121-2
- 1198: Text3: 34.108, 34.122, 34.123-1, 34.123-2, 34.123-3
- 1199: Text3: 34.108, 34.123-1, 34.123-2, 34.123-3
- 1200: Text3: 34.108, 34.123-1, 34.123-2, 34.123-3
- 1201: Text3: 34.108, 34.109, 34.122
- 1203: Text3: 22.941, 23.207, 22.243
- 1204: Text3: 23.877
- 1205: Completed / Text3: 26.235, 26.236, 26.243, 26.177, 26.943
- 1207: Abandoned NP-23
- 1209: Text3: 22.240, 22.228
- 1210: Text3: 23.240
- 1211: TR approved in CN#26 / Text3: 23.241
- 1212: 17 May no activity in CN4............ / Text3: 29.240
- 1213: WID approved SA#17. SA WG3 progress slow, depends on progress in other groups. / Text3: 33.102, 33.203, 33.210
- 1214: Foreseen start and completion dates introduced by MCC (no indication at all on the WID)
- 1218: SA3 acknowledge role in WI at SA3#20. Active contribution S3#24, S3#25. S3 WID approved SA#17
- 1219: Replaced by UID 60005 and 60006

| ID | WBS | Task | Duration | Start | Finish | Complete | Baseline start | Baseline finish | Baseline duration | Constraint | Resources | Work | Actual work | Text1 | Text4 | Text5 | Text6 | Text8 | Text3 | Text10 | Text11 |
| --- | --- | --- | --- | --- | --- | --- | --- | --- | --- | --- | --- | --- | --- | --- | --- | --- | --- | --- | --- | --- | --- |
| 1220 | 32 | **WLAN-UMTS Interworking Rel-6** | 1494d? | 2000-01-03 A | 2005-09-22 A | 100% | 2000-01-03 | 2005-09-22 | 1494d? |  | S1 | 48464h | 48464h | WLAN | Telenor | frederic.paint@telenor.com | Rel-6 | Michael |  |  |  |
| 1221 | 32.1 | Technical Report | 900d? | 2000-01-03 A | 2003-06-13 A | 100% | 2000-01-03 | 2003-06-13 | 900d? | finish no earlier than 2003-06-13 | S1 | 7200h | 7200h | WLAN-TR | Telenor | frederic.paint@telenor.com | Rel-6 |  | 22.934, 22.101, 22.105 |  |  |
| 1222 | 1.341.2 | **Stage 1** | 375d? | 2003-01-06 A | 2004-06-11 A | 100% | 2003-01-06 | 2004-06-11 | 375d? |  | S1 | 3920h | 3920h | WLAN-TS | Telenor | frederic.paint@telenor.com | Rel-6 |  | 22.234 | SP-24 |  |
| 1223 | 1.341.2.1 | Global stage 1 | 375d? | 2003-01-06 A | 2004-06-11 A | 100% | 2003-01-06 | 2004-06-11 | 375d? | finish no earlier than 2004-06-11 | S1 | 3000h | 3000h | WLAN-TS | Telenor | frederic.paint@telenor.com | Rel-6 |  | 22.234 | SP-24 |  |
| 1224 | 32.2 | Architecture Definition for scenarii 2 and 3 | 571d | 2002-03-25 A | 2004-05-31 A | 100% | 2002-03-25 | 2004-05-31 | 571d | finish no earlier than 2004-05-31 | S2 | 4568h | 4568h |  |  |  | Rel-6 |  | 23.234 |  |  |
| 1225 | 32.3 | Security | 125d | 2002-09-30 A | 2003-03-21 A | 100% | 2002-09-30 | 2003-03-21 | 125d | finish no earlier than 2003-03-21 | S3 | 1000h | 1000h |  | Ericsson | luis.lopez-soria@ece.ericsson.se | Rel-6 |  | 21.133, 33.106, 33.107, 33.108, 33.200, 33.203, 33.210 |  |  |
| 1226 | 1.341.5 | Stage 3 - CN4 aspects | 334d? | 2003-05-23 A | 2004-09-01 A | 100% | 2003-05-23 | 2004-09-01 | 334d? | finish no earlier than 2004-09-01 | N4 | 2672h | 2672h | WLAN-IW | Nokia | raquel.rodriguez@nokia.com | Rel-6 |  | 29.234, 29.061 |  |  |
| 1227 | 1.341.6 | Stage 3 - CN3 aspects (Wi Interface for Scenario 3) | 355d? | 2003-05-23 A | 2004-09-30 A | 100% | 2003-05-23 | 2004-09-30 | 355d? | start no earlier than 2003-05-23 | N3 | 2840h | 2840h | WLAN |  |  | Rel-6 |  | 29.161 | SP-24 |  |
| 1228 | 1.341.7 | Stage 3 for scenario 2 | 339d? | 2003-05-23 A | 2004-09-08 A | 100% | 2003-05-23 | 2004-09-08 | 339d? | finish no earlier than 2004-09-08 | N1 | 2712h | 2712h |  |  |  | Rel-6 |  |  |  |  |
| 1229 | 1.341.8 | Stage 3 for scenario 3 | 404d? | 2003-05-23 A | 2004-12-08 A | 100% | 2003-05-23 | 2004-12-08 | 404d? | finish no earlier than 2004-12-08 | N1 | 3232h | 3232h |  |  |  | Rel-6 |  |  | SP-24 |  |
| 1230 | 1.341.9 | WLAN charging | 655d? | 2003-03-21 A | 2005-09-22 A | 100% | 2003-03-21 | 2005-09-22 | 655d? | finish no earlier than 2005-09-22 | S5 | 5240h | 5240h | WLAN-CH | Nokia | benni.alexander@nokia.com | Rel-6 | Adrian | 32.252 |  |  |
| 1231 | 1.341.10 | USIM enhancements for WLAN Interworking | 391d? | 2003-09-05 A | 2005-03-04 A | 100% | 2003-09-05 | 2005-03-04 | 391d? | finish no earlier than 2005-03-04 | T3 | 3128h | 3128h |  | Axalto | Jabellan@axalto.com | Rel-6 |  |  |  |  |
| 1232 | 33 | **Priority Service** | 347d? | 2002-05-30 A | 2003-09-26 A | 100% | 2002-05-30 | 2003-09-26 | 347d? |  | S1 | 6464h | 6464h | NTShar |  |  | Rel-6 | Michael |  |  |  |
| 1233 | 33.1 | Feasibility Study | 1d | 2002-06-14 A | 2002-06-14 A | 100% | 2002-06-14 | 2002-06-14 | 1d | finish no earlier than 2002-06-14 | S1 | 8h | 8h | PRIOR-FS | Telcordia | Biplab K. Pramanik (bpramani@telcordia.com) | Rel-6 | Michael | 22.950 |  |  |
| 1234 | 33.2 | Stage 1 - Requirements | 340d | 2002-05-30 A | 2003-09-17 A | 100% | 2002-05-30 | 2003-09-17 | 340d | finish no earlier than 2003-09-17 | S1 | 2720h | 2720h | PRIOR-SR | Telcordia | James J. Garrahan (bpramani@telcordia.com) | Rel-6 | Michael |  |  |  |
| 1235 | 1.342.3 | Priority service implementation guide | 131d? | 2003-03-28 A | 2003-09-26 A | 100% | 2003-03-28 | 2003-09-26 | 131d? | finish no earlier than 2003-09-26 | S1 | 1048h | 1048h |  | Telcordia | Biplab K. Pramanik (bpramani@telcordia.com) | Rel-6 |  | 22.952 |  |  |
| 1236 | 34 | **Network Sharing** | 498d? | 2003-01-20 A | 2004-12-15 A | 100% | 2003-01-20 | 2004-12-15 | 498d? |  | S1 | 16608h | 16608h | NTShar |  |  | Rel-6 | Michael |  |  |  |
| 1237 | 34.1 | Technical Report | 240d? | 2003-01-20 A | 2003-12-19 A | 100% | 2003-01-20 | 2003-12-19 | 240d? |  | S1 | 1920h | 1920h | NTShar-TR |  |  | Rel-6 | Michael | 22.951 |  |  |
| 1238 | 1.343.2 | Stage 1 - CRs to implement Network Sharing | 240d? | 2003-01-20 A | 2003-12-19 A | 100% | 2003-01-20 | 2003-12-19 | 240d? | finish no earlier than 2003-12-19 | S1 | 1920h | 1920h | NTShar-CR |  |  | Rel-6 |  | 22.011, 22.101, 22.115, 22.129 |  |  |
| 1239 | 1.343.3 | Stage 2 | 372d? | 2003-02-27 A | 2004-07-30 A | 100% | 2003-02-27 | 2004-07-30 | 372d? | finish no earlier than 2004-07-30 | S2 | 2976h | 2976h |  |  |  | Rel-6 |  | 23.251 |  |  |
| 1240 | 1.343.4 | Network sharing - stage 3 | 404d? | 2003-05-23 A | 2004-12-08 A | 100% | 2003-05-23 | 2004-12-08 | 404d? | finish no earlier than 2004-12-08 | N1 | 3232h | 3232h |  |  |  | Rel-6 |  |  |  |  |
| 1241 | 1.343.5 | Enhancement of the support of network sharing in the UTRAN | 324d | 2003-09-19 A | 2004-12-15 A | 100% | 2003-09-19 | 2004-12-15 | 324d | finish no earlier than 2004-12-15 | R2 | 2592h | 2592h | NTShar-UTRANEnh | TeliaSonera | Anders.Dahlen@TeliaSonera.com | Rel-6 | MCC_RAN | 25.401, 25.413, 25.331, 25.304 |  | Active |
| 1242 | 35 | **QoS Improvements** | 628d? | 2002-07-15 A | 2004-12-08 A | 100% | 2002-07-15 | 2004-12-08 | 628d? |  | S2 | 13128h | 13128h | QoS1 | Nokia |  | Rel-6 | Sang-Ui |  |  |  |
| 1243 | 35.1 | FS on Dynamic Policy control enhancements for end-to-end QoS | 465d | 2002-07-15 A | 2004-04-23 A | 100% | 2002-07-15 | 2004-04-23 | 465d | finish no earlier than 2004-04-23 | S2 | 3720h | 3720h | QoS1 |  | Claire Mousset, Nortel | Rel-6 |  | 23.917 |  |  |
| 1244 | 1.344.2 | Definition of the Gq interface | 214d? | 2003-07-01 A | 2004-04-23 A | 100% | 2003-07-01 | 2004-04-23 | 214d? | finish no earlier than 2004-04-23 | S2 | 1712h | 1712h |  |  | Janne Rinne | Rel-6 |  | 23.221 |  |  |
| 1245 | 1.344.3 | Gq interface specification for Dynamic Policy control enhancements – Stage 3 | 334d | 2003-08-29 A | 2004-12-08 A | 100% | 2003-08-29 | 2004-12-08 | 334d | finish no earlier than 2004-12-08 | N3 | 2672h | 2672h |  | Nokia | Anna.Sillanpaai@nokia.com | Rel-6 |  | 24,228, 29.207, 29.208 |  |  |

Notes:
- 1225: Active contribution S3#24, S3#25. WID approved SA#17
- 1226: WID approved at CN#19...............
- 1230: SA#28: delayed 09/2005. WT also under SA5 BB 35017 Charging Management for Bearer level
- 1245: [DAB - 25.05.04] - Delayed to Sept - possibly Dec 2004

| ID | WBS | Task | Type | Duration | Start | Finish | Complete | Baseline start | Baseline finish | Baseline duration | Constraint | Resources | Work | Actual work | Text1 | Text4 | Text5 | Text6 | Text8 | Text10 | Text12 |
| --- | --- | --- | --- | --- | --- | --- | --- | --- | --- | --- | --- | --- | --- | --- | --- | --- | --- | --- | --- | --- | --- |
| 1246 | 36 | **Subscriber certificates** |  | 728d? | 2002-02-25 A | 2004-12-08 A | 100% | 2002-02-25 | 2004-12-08 | 728d? |  | S3 | 12888h | 12888h | SEC1-SC | Nokia | valtteri.niemi@nokia.com | Rel-6 | Maurice |  |  |
| 1247 | 36.1 | Stage 1 |  | 144d | 2002-02-25 A | 2002-09-12 A | 100% | 2002-02-25 | 2002-09-12 | 144d | finish no earlier than 2002-09-12 | S3 | 1152h | 1152h |  |  |  | Rel-6 |  |  |  |
| 1248 | 36.2 | Architecture review |  | 24d | 2002-10-14 A | 2002-11-14 A | 100% | 2002-10-14 | 2002-11-14 | 24d | finish no earlier than 2002-11-14 | S2 | 192h | 192h |  |  |  | Rel-6 |  |  |  |
| 1249 | 1.345.3 | Stage 3 |  | 313d? | 2003-09-19 A | 2004-11-30 A | 100% | 2003-09-19 | 2004-11-30 | 313d? | finish no earlier than 2004-11-30 | N4 | 2504h | 2504h | SEC1-SC | Nokia | Lauri Laitinen | Rel-6 | Kimmo |  |  |
| 1250 | 1.345.4 | Stage 3 Ua & Ub interfaces |  | 288d? | 2003-11-03 A | 2004-12-08 A | 100% | 2003-11-03 | 2004-12-08 | 288d? | finish no earlier than 2004-12-08 | N1 | 2304h | 2304h |  |  |  | Rel-6 |  |  |  |
| 1251 | 1.345.5 | OMA dependencies on Subscriber certificates |  | 114d? | 2004-01-01 A | 2004-06-08 A | 100% | 2004-01-01 | 2004-06-08 | 114d? | finish no earlier than 2004-06-08 | OMA | 912h | 912h |  |  | OMA-LIAISON@mail.openmobilealliance.org | Rel-6 |  | SP-24 |  |
| 1252 | 1.346 | **Rel-6 OSA enhancements** |  | 616d? | 2002-10-31 A | 2005-03-10 A | 100% | 2002-10-31 | 2005-03-10 | 616d? |  | N5 | 22576h | 22576h | OSA3 | Alcatel | Chelo.Abarca@alcatel.fr | Rel-6 | Adrian |  |  |
| 1253 | 1.346.1 | Scope of the Open Service Access Release 6 |  | 66d? | 2003-03-28 A | 2003-06-27 A | 100% | 2003-03-28 | 2003-06-27 | 66d? | finish no earlier than 2003-06-27 | S1 | 528h | 528h |  |  |  | Rel-6 |  |  |  |
| 1254 | 1.346.2 | OSA Stage 2 |  | 150d? | 2004-08-13 A | 2005-03-10 A | 100% | 2004-08-13 | 2005-03-10 | 150d? | finish no earlier than 2005-03-10 | N5 | 1200h | 1200h |  |  |  | Rel-6 |  |  |  |
| 1255 | 1.346.3 | Multi Media Messaging function |  | 487d? | 2002-10-31 A | 2004-09-10 A | 100% | 2002-10-31 | 2004-09-10 | 487d? | finish no earlier than 2004-09-10 | N5 | 3896h | 3896h |  |  |  | Rel-6 |  |  |  |
| 1256 | 1.346.4 | Policy management extensions |  | 292d? | 2002-10-31 A | 2003-12-12 A | 100% | 2002-10-31 | 2003-12-12 | 292d? | finish no earlier than 2003-12-12 | N5 | 2336h | 2336h |  |  |  | Rel-6 |  |  |  |
| 1257 | 1.346.5 | TS on Presence and Availability Management (from the PRESNC WI) |  | 367d? | 2002-10-31 A | 2004-03-26 A | 100% | 2002-10-31 | 2004-03-26 | 367d? | finish no earlier than 2004-03-26 | N5 | 2936h | 2936h |  |  |  | Rel-6 |  |  |  |
| 1258 | 1.346.6 | OSA interfaces at different levels of abstractions (Parlay X, Web services) |  | 305d? | 2003-07-14 A | 2004-09-10 A | 100% | 2003-07-14 | 2004-09-10 | 305d? | finish no earlier than 2004-09-10 | N5 | 2440h | 2440h |  |  |  | Rel-6 |  |  |  |
| 1259 | 1.346.7 | Introduction of migration support mechanism |  | 290d? | 2002-10-31 A | 2003-12-10 A | 100% | 2002-10-31 | 2003-12-10 | 290d? | finish no earlier than 2003-12-12 | N5 | 2320h | 2320h |  |  |  | Rel-6 |  |  |  |
| 1260 | 1.346.8 | Framework Function for Federation |  | 225d? | 2003-02-03 A | 2003-12-12 A | 100% | 2003-02-03 | 2003-12-12 | 225d? | finish no earlier than 2003-12-12 | N5 | 1800h | 1800h |  |  |  | Rel-6 |  |  |  |
| 1261 | 1.346.9 | OMA potential overlaps with 3GPP OSA Stage 3 (Web services) |  | 196d? | 2003-12-18 A | 2004-09-16 A | 100% | 2003-12-18 | 2004-09-16 | 196d? | start no earlier than 2003-12-18 | OMA | 1568h | 1568h |  |  |  | Rel-6 |  | SP-24 |  |
| 1262 | 1.346.10 | Deleted - TR on Presence and Availability Management (from the PRESNC WI) | milestone | 0d? | 2004-09-17 A | 2004-09-17 A | 100% | 2004-09-17 | 2004-09-17 | 0d? | start no earlier than 2004-09-17 | N5 |  |  |  |  |  | Rel-6 |  |  | NP-24 |
| 1263 | 39 | **Addition of frequency bands to GSM (TAPS)** |  | 676d | 2002-06-28 A | 2005-01-28 A | 100% | 2002-06-28 | 2005-01-28 | 676d |  | GP | 16640h | 16640h | TAPS | Nokia | Torben Themsen | Rel-6 | Paolo |  |  |
| 1264 | 39.1 | **Addition of frequency bands to GSM – Changes to core specs** |  | 26d | 2002-11-15 A | 2002-12-20 A | 100% | 2002-11-15 | 2002-12-20 | 26d |  | G1 | 416h | 416h | TAPS-Specs | Nokia | Torben Themsen | Rel-6 |  |  |  |
| 1265 | 39.1.1 | Changes to core specs |  | 26d | 2002-11-15 A | 2002-12-20 A | 100% | 2002-11-15 | 2002-12-20 | 26d | finish no earlier than 2002-12-20 | G1 | 208h | 208h |  |  |  | Rel-6 |  |  |  |
| 1266 | 39.2 | **Deleted at TSG #27 - Addition of frequency bands to GSM – Changes for conformance tests** |  | 676d | 2002-06-28 A | 2005-01-28 A | 100% | 2002-06-28 | 2005-01-28 | 676d |  | G4 | 10816h | 10816h | TAPS-Conf | Nokia | Torben Themsen | Rel-6 |  |  |  |
| 1267 | 39.2.1 | Deleted at TSG #27 - 51.010-1 Add testing |  | 676d | 2002-06-28 A | 2005-01-28 A | 100% | 2002-06-28 | 2005-01-28 | 676d | finish no earlier than 2005-01-28 | G4 | 5408h | 5408h |  |  |  | Rel-6 |  |  |  |
| 1268 | 40 | **Seamless support of streaming services in A/Gb mode** |  | 1425d? | 2000-01-03 A | 2005-06-17 A | 100% | 2000-01-03 | 2005-06-17 | 1425d? |  | GP | 53088h | 53088h | SSStrea | Vodafone | José Luis Carrizo Martínez | Rel-6 | Paolo |  |  |
| 1269 | 40.1 | **Identification of requirements for streaming** |  | 46d? | 2003-06-27 A | 2003-08-29 A | 100% | 2003-06-27 | 2003-08-29 | 46d? |  | G1 | 736h | 736h |  |  |  | Rel-6 |  |  |  |
| 1270 | 1.348.1.1 | Requirements |  | 46d? | 2003-06-27 A | 2003-08-29 A | 100% | 2003-06-27 | 2003-08-29 | 46d? | finish no earlier than 2003-08-29 | G1 | 368h | 368h |  |  |  | Rel-6 |  |  |  |

Notes:
- 1246: Approved at SA#14. This may require BBs from CN1, CN4, SA5 and T3 / Text3: 33.102
- 1247: Contribution received S3#24, S3#25
- 1249: Finished in CN4#26
- 1251: Updated according to SP-040420
- 1252: CN#25: Updated WID NP-040351 replaces NP-040144. / Text3: 22.127, 23.198, 29.198, 29.199, 29.998
- 1254: Inherited by CN5 from SA2 at TSG#25 Sep 2004. SA2's 23.127 (OSA/VHE Stage 2) replaced from Rel-6 onwards by a new CN5 TS 23.198 (Stage 2 OSA-only). / Text3: 23.198 OSA Stage 2-ONLY replaces 23.127 (OSA/VHE) from Rel-6 onwards
- 1255: Text3: 29.198-15
- 1256: Text3: 29.198, 29.998
- 1257: N5#26: Split WI into TS & TR. / Text3: 29.198-14
- 1258: Text3: 29.199
- 1259: Text3: 29.198, 29.998
- 1260: Text3: 29.198, 29.998
- 1261: TSG#25 Approved CN5 29.199 Parlay X Web services. Ongoing 3GPP/OMA co-ordination to avoid OMA producing conflicting/OVERLAPING specs (NP-040283/SP-040493).
- 1262: N5#26:TR Completion 09/04; consistent with CN1 delayed Rel-6 completion.
- 1264: Ready
- 1266: DELETE
- 1267: DELETE
- 1269: Started

| ID | WBS | Task | Duration | Start | Finish | Complete | Baseline start | Baseline finish | Baseline duration | Constraint | Resources | Work | Actual work | Text6 | Text3 | Text4 | Text5 | Text8 | Text1 |
| --- | --- | --- | --- | --- | --- | --- | --- | --- | --- | --- | --- | --- | --- | --- | --- | --- | --- | --- | --- |
| 1271 | 40.2 | **Performance study of cell change mechanisms** | 955d? | 2000-01-03 A | 2003-08-29 A | 100% | 2000-01-03 | 2003-08-29 | 955d? |  | G1 | 30560h | 30560h | Rel-6 |  |  |  |  |  |
| 1272 | 1.348.2.1 | Performance of NACC | 955d? | 2000-01-03 A | 2003-08-29 A | 100% | 2000-01-03 | 2003-08-29 | 955d? | finish no earlier than 2003-08-29 | G1 | 7640h | 7640h | Rel-6 |  |  |  |  |  |
| 1273 | 1.348.2.2 | Performance of cell change in DTM for the PS domain | 955d? | 2000-01-03 A | 2003-08-29 A | 100% | 2000-01-03 | 2003-08-29 | 955d? | finish no earlier than 2003-08-29 | G1 | 7640h | 7640h | Rel-6 |  |  |  |  |  |
| 1274 | 1.348.2.3 | Handover | 955d? | 2000-01-03 A | 2003-08-29 A | 100% | 2000-01-03 | 2003-08-29 | 955d? | finish no earlier than 2003-08-29 | G1 | 7640h | 7640h | Rel-6 |  |  |  |  |  |
| 1275 | 40.3 | **Reduction of service interruption times and packet loss during mobility procedures** | 516d? | 2003-06-27 A | 2005-06-17 A | 100% | 2003-06-27 | 2005-06-17 | 516d? |  | G2 | 10800h | 10800h | Rel-6 |  |  |  |  |  |
| 1276 | 1.348.3.1 | Optimisations of existing mechanisms/procedures | 106d? | 2003-06-27 A | 2003-11-21 A | 100% | 2003-06-27 | 2003-11-21 | 106d? | finish no earlier than 2003-11-21 | G2 | 848h | 848h | Rel-6 |  |  |  |  |  |
| 1277 | 1.348.3.2 | Inter-system NACC | 106d? | 2003-06-27 A | 2003-11-21 A | 100% | 2003-06-27 | 2003-11-21 | 106d? | finish no earlier than 2003-11-21 | G2 | 848h | 848h | Rel-6 |  |  |  |  |  |
| 1278 | 1.348.3.3 | PS Handover (within GERAN and between GERAN and UTRAN) | 516d? | 2003-06-27 A | 2005-06-17 A | 100% | 2003-06-27 | 2005-06-17 | 516d? | finish no earlier than 2003-11-21 | G2 | 4128h | 4128h | Rel-6 |  |  |  |  |  |
| 1279 | 1.348.3.4 | Dependency to other features | 106d? | 2003-06-27 A | 2003-11-21 A | 100% | 2003-06-27 | 2003-11-21 | 106d? | finish no earlier than 2003-11-21 | G2 | 848h | 848h | Rel-6 |  |  |  |  |  |
| 1280 | 40.5 | **MS conformance testing** | 31d? | 2003-12-19 A | 2004-01-30 A | 100% | 2003-12-19 | 2004-01-30 | 31d? |  | G3 | 248h | 248h | Rel-6 |  |  |  |  |  |
| 1281 | 1.348.4.1 | MS conformance tests | 31d? | 2003-12-19 A | 2004-01-30 A | 100% | 2003-12-19 | 2004-01-30 | 31d? | finish no earlier than 2004-01-30 | G4,G5 | 248h | 248h | Rel-6 |  |  |  |  |  |
| 1282 | 1.348.5 | GERAN A/Gb mode security enhancements | 612d? | 2002-09-26 A | 2005-01-28 A | 100% | 2002-09-26 | 2005-01-28 | 612d? | finish no earlier than 2005-01-28 | S3 | 4896h | 4896h | Rel-6 | 33.102 | Vodafone | peter.howard@vodafone.com | Maurice |  |
| 1283 | 41 | Performance characterisation of default codecs for PS conversational multimedia application | 455d | 2002-09-13 A | 2004-06-10 A | 100% | 2002-09-13 | 2004-06-10 | 455d | finish no earlier than 2004-06-10 | S4 | 3640h | 3640h | Rel-6 | 26.935 | Nokia | pasi.s.ojala@nokia.com | Paolo | CODCAR |
| 1284 | 43 | Study on Privacy Capability | 83d | 2003-11-10 A | 2004-03-03 A | 100% | 2003-11-10 | 2004-03-03 | 83d | start no earlier than 2003-11-10 | S1 | 664h | 664h | Rel-6 | 21.949 | Lucent | Liz Daniel | Michael | PrivCap |
| 1285 | 44 | **OAM&P Rel-6** | 652d? | 2002-09-12 A | 2005-03-11 A | 100% | 2002-09-12 | 2005-03-11 | 652d? |  | S5 | 30819.5h | 30819.5h | Rel-6 | 32-series | Motorola | Michael.Truss@MOTOROLA.COM | Adrian | OAM |
| 1286 | 44.1 | Principles, high level Requirements and Architecture | 526d | 2002-09-12 A | 2004-09-16 A | 100% | 2002-09-12 | 2004-09-16 | 526d | finish no earlier than 2004-09-16 | S5 | 4208h | 4208h | Rel-6 | 32.101, 32.102 | Motorola | Michael.Truss@MOTOROLA.COM |  | OAM-AR |
| 1287 | 44.2 | Performance Management | 591d | 2002-09-12 A | 2004-12-16 A | 100% | 2002-09-12 | 2004-12-16 | 591d | finish no earlier than 2004-12-16 | S5 | 4728h | 4728h | Rel-6 | 32.401/3, 52.402, 32.411/2/3, 32.432/5/6 | Nortel | toche@NORTELNETWORKS.COM |  | OAM-PM |
| 1288 | 44.4 | Network Infrastructure Management | 591d | 2002-09-12 A | 2004-12-16 A | 100% | 2002-09-12 | 2004-12-16 | 591d | finish no earlier than 2004-12-16 | S5 | 4728h | 4728h | Rel-6 | 32.15x, 32.3/6/7xy | Ericsson | Thomas.Tovinger@emw.ericsson.se |  | OAM-NIM |
| 1289 | 44.5 | **Trace Management Rel-6** | 646d? | 2002-09-20 A | 2005-03-11 A | 100% | 2002-09-20 | 2005-03-11 | 646d? |  | S5 | 12061.9h | 12061.9h | Rel-6 | 32.42x, 52.008 | Nokia | kari.t.ronka@nokia.com |  | OAM-Trace |
| 1290 | 1.351.4.1 | Subscriber and UE trace management | 585d | 2002-09-20 A | 2004-12-16 A | 100% | 2002-09-20 | 2004-12-16 | 585d | finish no earlier than 2004-12-16 | S5 | 4680h | 4680h | Rel-6 | 32.421/2/3, 52.008 | Nokia | kari.t.ronka@nokia.com |  | OAM-Trace |
| 1291 | 1.351.4.2 | Subscriber and equipment trace in UTRAN | 268d? | 2003-06-06 A | 2004-06-15 A | 100% | 2003-06-06 | 2004-06-15 | 268d? | finish no earlier than 2004-06-15 | R3 | 2144h | 2144h | Rel-6 | 25.413, 25.420, 25.423 | Nortel | Yann Sehedi (sehedic@nortelnetworks.com) | MCC_RAN | OAM-Trace-RAN |
| 1292 | 1.351.4.3 | Trace Management, Stage3 | 193.74d? | 2004-06-09 A | 2005-03-11 A | 100% | 2004-06-09 | 2005-03-11 | 193.74d? | finish no earlier than 2005-03-11 | N4 | 1549.92h | 1549.92h | Rel-6 | 23.205, 29.232, 29.060, 29.002, 29.228 | Nokia | seppo.kauntola@nokia.com |  | OAM-Trace |
| 1293 | 1.352 | **Charging Management** | 666d? | 2002-11-21 A | 2005-06-09 A | 100% | 2002-11-21 | 2005-06-09 | 666d? |  | S5 | 55320h | 55320h | Rel-6 | 32.2xy | T-Mobile | karl-heinz.nenner@t-mobile.de | Adrian | CH |
| 1294 | 1.352.1 | Charging architecture and principles | 390d? | 2003-03-21 A | 2004-09-16 A | 100% | 2003-03-21 | 2004-09-16 | 390d? | start no earlier than 2003-03-21 | S5 | 3120h | 3120h | Rel-6 | 32.240 |  |  |  | CH |
| 1295 | 1.352.2 | Charging Data Record (CDR) file format and transfer | 260d? | 2003-03-21 A | 2004-03-18 A | 100% | 2003-03-21 | 2004-03-18 | 260d? | start no earlier than 2003-03-21 | S5 | 2080h | 2080h | Rel-6 | 32.297 |  |  |  | CH |
| 1296 | 1.352.3 | CDR parameter description | 580d? | 2003-03-21 A | 2005-06-09 A | 100% | 2003-03-21 | 2005-06-09 | 580d? | finish no earlier than 2005-06-09 | S5 | 4640h | 4640h | Rel-6 | 32.298 |  |  |  | CH |
| 1297 | 1.352.4 | Diameter charging applications | 390d? | 2003-03-21 A | 2004-09-16 A | 100% | 2003-03-21 | 2004-09-16 | 390d? | start no earlier than 2003-03-21 | S5 | 3120h | 3120h | Rel-6 | 32.299 |  |  |  | CH |
| 1298 | 1.352.5 | Online Charging System (OCS) architecture study | 130d? | 2003-03-21 A | 2003-09-18 A | 100% | 2003-03-21 | 2003-09-18 | 130d? | start no earlier than 2003-03-21 | S5 | 1040h | 1040h | Rel-6 | 32.815 |  |  |  | CH |
| 1299 | 1.352.6 | OCS: Applications and interfaces | 455d? | 2003-03-21 A | 2004-12-16 A | 100% | 2003-03-21 | 2004-12-16 | 455d? | start no earlier than 2003-03-21 | S5 | 3640h | 3640h | Rel-6 | 32.296 |  |  |  | CH |

Notes:
- 1271: Started
- 1275: Completed at GERP#17
- 1280: Closed, no work needed
- 1281: Closed, no work needed
- 1282: Possible changes to 33.102 or new specification needed.
- 1285: SA#26: Updated WID SP-040766 was SP-020445. Completion delayed 12/04->03/05 due to OAM-Trace in CN1/4.
- 1286: SA#25 09/2004 completed
- 1287: SA#26 12/2004 completed
- 1288: SA#26 12/2004 completed
- 1289: SA#26 12/2004 SA5 completed 12/04. Signalling Based Trace Activation for IMS (SIP) moved to Rel-7. Reason: CN1 cannot complete 24.229 trace without IETF dependency => estimate 05/2005.
- 1290: SA#26 12/2004 completed
- 1293: SA#28 Target 09/2005 for WLAN Charging 32.252
- 1294: SA#25 09/2004 completed
- 1295: SA#23 03/2004 completed
- 1296: SA#28 06/2005 completed
- 1297: SA#25 09/2004 completed
- 1298: SA#21 09/2003 completed
- 1299: SA#26 12/2004 completed

| ID | WBS | Task | Duration | Start | Finish | Complete | Baseline start | Baseline finish | Baseline duration | Constraint | Resources | Work | Actual work | Text1 | Text4 | Text5 | Text6 | Text10 | Text8 |
| --- | --- | --- | --- | --- | --- | --- | --- | --- | --- | --- | --- | --- | --- | --- | --- | --- | --- | --- | --- |
| 1300 | 1.352.7 | **Charging Management for Bearer level** | 390d? | 2003-03-21 A | 2004-09-16 A | 100% | 2003-03-21 | 2004-09-16 | 390d? |  | S5 | 11440h | 11440h | CH-BC | Nokia | Benni ALEXANDER | Rel-6 |  |  |
| 1301 | 1.352.7.1 | CS domain charging | 260d? | 2003-03-21 A | 2004-03-18 A | 100% | 2003-03-21 | 2004-03-18 | 260d? | start no earlier than 2003-03-21 | S5 | 2080h | 2080h | CH |  |  | Rel-6 |  |  |
| 1302 | 1.352.7.2 | PS domain charging | 390d? | 2003-03-21 A | 2004-09-16 A | 100% | 2003-03-21 | 2004-09-16 | 390d? | start no earlier than 2003-03-21 | S5 | 3120h | 3120h | CH |  |  | Rel-6 |  |  |
| 1303 | 1.352.7.3 | CDR transfer | 390d? | 2003-03-21 A | 2004-09-16 A | 100% | 2003-03-21 | 2004-09-16 | 390d? | start no earlier than 2003-03-21 | S5 | 3120h | 3120h | CH |  |  | Rel-6 |  |  |
| 1304 | 1.352.8 | Charging Management for the IMS | 455d? | 2003-03-21 A | 2004-12-16 A | 100% | 2003-03-21 | 2004-12-16 | 455d? | finish no earlier than 2004-12-16 | S5 | 3640h | 3640h | IMS2-CH | Ericsson | Patrik TEPPO | Rel-6 |  |  |
| 1305 | 1.352.9 | Charging Management for the Service domain | 580d? | 2003-03-21 A | 2005-06-09 A | 100% | 2003-03-21 | 2005-06-09 | 580d? | finish no earlier than 2005-06-09 | S5 | 4640h | 4640h | CH | Siemens | Gerald GÖRMER | Rel-6 |  |  |
| 1306 | 1.352.10 | **Overall architectural aspects of IP flow based bearer level charging** | 602d? | 2002-11-21 A | 2005-03-11 A | 100% | 2002-11-21 | 2005-03-11 | 602d? |  | S2 | 12632h | 12632h | CH-FBC |  |  | Rel-6 |  |  |
| 1307 | 1.352.10.1 | Overall definition of FBC architecture | 334d? | 2002-11-21 A | 2004-03-02 A | 100% | 2002-11-21 | 2004-03-02 | 334d? | start no earlier than 2002-11-21 | S2 | 2672h | 2672h |  |  |  | Rel-6 | SP-24 |  |
| 1308 | 1.352.10.2 | Study on providing policy control with FBC | 130d? | 2004-02-02 A | 2004-07-30 A | 100% | 2004-02-02 | 2004-07-30 | 130d? | start no earlier than 2004-02-01 | S2 | 1040h | 1040h |  |  |  | Rel-6 | SP-24 |  |
| 1309 | 1.352.10.3 | Gx interface for flow based charging | 223d? | 2004-02-02 A | 2004-12-08 A | 100% | 2004-02-02 | 2004-12-08 | 223d? | start no earlier than 2004-02-01 | N3 | 1784h | 1784h | CH-FBC | Nokia | juha.a.rasanen@nokia.com | Rel-6 | SP-25 |  |
| 1310 | 1.352.10.4 | Rx interface for flow based charging | 290d? | 2004-02-02 A | 2005-03-11 A | 100% | 2004-02-02 | 2005-03-11 | 290d? | finish no earlier than 2005-03-11 | N3 | 2320h | 2320h | CH-FBC | Nortel | Javier Gonzalez Gallego (ggfj@nortelnetworks.com) | Rel-6 | SP-25 |  |
| 1311 | 13 | **Rel-6 UICC/USIM enhancements and interworking** | 1164d? | 2000-09-25 A | 2005-03-10 A | 100% | 2000-09-25 | 2005-03-10 | 1164d? |  | T3 | 43088h | 43088h | USAT1 |  |  | Rel-6 |  | Claus |
| 1312 | 13.1 | **UICC API** | 777d | 2002-03-20 A | 2005-03-10 A | 100% | 2002-03-20 | 2005-03-10 | 777d |  | T3 | 15024h | 15024h | USAT1-API |  |  | Rel-6 |  |  |
| 1313 | 13.1.1 | Java API Test specification | 59d | 2002-03-20 A | 2002-06-10 A | 100% | 2002-03-20 | 2002-06-10 | 59d | finish no earlier than 2002-09-20 | T3 | 472h | 472h |  | Microelectrónica Española | Mario Pérez | Rel-6 |  |  |
| 1314 | 1.353.1.2 | 2G/3G Java Card™ API based applet interworking | 255d | 2003-03-17 A | 2004-03-05 A | 100% | 2003-03-17 | 2004-03-05 | 255d | finish no earlier than 2004-02-19 | T3 | 2040h | 2040h | USAT1-API | Oberthur Card Systems | Stéphane Andrau | Rel-6 |  |  |
| 1315 | 1.353.1.3 | (U)SIM API for Java Card Testing Work Item | 519d | 2003-03-17 A | 2005-03-10 A | 100% | 2003-03-17 | 2005-03-10 | 519d | finish no earlier than 2005-03-10 | T3 | 4152h | 4152h |  | Axalto | Christophe Begassat (cbegassat@axalto.com) | Rel-6 |  | Friedhelm |
| 1316 | 13.1.2 | Deleted - Java API Test specification (TS 43.019 Rel-5) | 268d | 2002-05-30 A | 2003-06-09 A | 100% | 2002-05-30 | 2003-06-09 | 268d | finish no earlier than 2003-09-17 | T3 | 2144h | 2144h |  | Microelectrónica Española | Mario Pérez | Rel-6 |  |  |
| 1317 | 1.353.2 | **Rel-6 USIM toolkit enhancements** | 1160d? | 2000-09-25 A | 2005-03-04 A | 100% | 2000-09-25 | 2005-03-04 | 1160d? |  | T3 | 21848h | 21848h |  |  |  | Rel-6 |  | Claus |
| 1318 | 1.353.2.1 | **C SIM API** | 525d | 2000-09-25 A | 2002-09-27 A | 100% | 2000-09-25 | 2002-09-27 | 525d |  | T3 | 9960h | 9960h | USAT1-API-MULTOS |  |  | Rel-6 |  |  |
| 1319 | 1.353.2.1.1 | Specification | 525d | 2000-09-25 A | 2002-09-27 A | 100% | 2000-09-25 | 2002-09-27 | 525d | finish no earlier than 2002-09-27 | T3 | 4200h | 4200h |  | Aspects Software | Neil Livingston | Rel-6 |  |  |
| 1320 | 1.353.2.1.2 | Test specification | 195d | 2001-01-01 A | 2001-09-28 A | 100% | 2001-01-01 | 2001-09-28 | 195d | finish no earlier than 2001-09-28 | T3 | 1560h | 1560h |  | Aspects Software | Neil Livingston | Rel-6 |  |  |
| 1321 | 1.353.2.2 | USIM application toolkit Conformance Test Specification for Mobile Equipments | 326d? | 2003-12-05 A | 2005-03-04 A | 100% | 2003-12-05 | 2005-03-04 | 326d? | start no earlier than 2003-12-05 | T3 | 2608h | 2608h |  | Gemplus | Eric.laffont@gemplus.com | Rel-6 |  |  |
| 1322 | 1.354 | **Packet Switched Streaming Services Rel-6** | 798d? | 2002-11-18 A | 2005-12-07 A | 100% | 2002-11-18 | 2005-12-07 | 798d? |  | S4 | 11579.4h | 11579.4h | PSSrel6 | Ericsson | olle.franceschi@ericsson.com | Rel-6 |  | Paolo |
| 1323 | 1.354.1 | Stage 1 | 86d? | 2002-11-18 A | 2003-03-17 A | 100% | 2002-11-18 | 2003-03-17 | 86d? | finish no earlier than 2003-03-17 | S1 | 688h | 688h |  |  |  | Rel-6 |  |  |
| 1324 | 1.354.2 | Stage 3 | 779d? | 2002-12-13 A | 2005-12-07 A | 100% | 2002-12-13 | 2005-12-07 | 779d? | finish no earlier than 2005-12-07 | S4 | 6232h | 6232h | PSSrel6-Stage3 | Ericsson | olle.franceschi@ericsson.com | Rel-6 |  | Paolo |
| 1325 | 1.355 | AMR-WB extension for high audio quality | 779d | 2002-12-13 A | 2005-12-07 A | 100% | 2002-12-13 | 2005-12-07 | 779d | finish no earlier than 2005-12-07 | S4 | 6232h | 6232h | AMRWB+ | Nokia | janne.m.vainio@nokia.com | Rel-6 |  | Paolo |
| 1326 | 1.356 | Codec Enhancements for Packet Switched Conversational Multimedia Applications | 198d? | 2004-03-16 A | 2004-12-16 A | 100% | 2004-03-16 | 2004-12-16 | 198d? | finish no earlier than 2004-12-16 | S4 | 1584h | 1584h | CEPSCM | Nokia | miska.hannuksela@nokia.com | Rel-6 |  | Paolo |
| 1327 | 1.357 | 3G-324M Improvements | 198d? | 2004-03-16 A | 2004-12-16 A | 100% | 2004-03-16 | 2004-12-16 | 198d? | finish no earlier than 2004-12-16 | S4 | 1584h | 1584h | 3G-324MI | Ericsson | bo.burman@ericsson.com | Rel-6 |  | Paolo |
| 1328 | 1.358 | Single Antenna Receiver Interference Cancellation (SAIC) | 420.92d? | 2002-11-15 A | 2004-08-27 A | 100% | 2002-11-15 | 2004-08-27 | 420.92d? | finish no earlier than 2004-08-27 | GP; G1 | 6734.73h | 6734.73h | SAIC | Cingular | Marc Grant | Rel-6 |  | Paolo |

Notes:
- 1300: SA#28 Target 09/2005 for WLAN Charging 32.252
- 1301: SA#23 03/2004 completed / Text3: 32.250
- 1302: SA#25 09/2004 completed / Text3: 32.251
- 1303: SA#25 09/2004 completed / Text3: 32.295
- 1304: SA#26 12/2004 completed / Text3: 32.260
- 1305: SA#26: Updated WID SP-040778 was SP-030050. Target completion 06/2005. Consisting of MMS-CH, LCS-CH, WLAN-CH, POC-CH, MBMS-CH / Text3: 32.252, 32.270/1/2
- 1306: Text3: 23.125
- 1309: Text3: 29.210
- 1310: Text3: 29.209
- 1312: 8/3/2001: test spec is based on R99 core spec, so deleted from Workplan
- 1315: Text3: 31.213
- 1316: MOVED to Rel-5 WP
- 1321: Text3: 31.124
- 1323: 2nd resp SA4 / Text3: 22.233
- 1324: TR tbc by Sept. 05 / Text3: 26.233, 26.234, 26.244, 26.245, 26.246, 26.401, 26.402, 26.403, 26.404, 26.405, 26.406, 26.410, 26.411, 26.412, 26.273, 26.290, 26.304, 26.412, 26.274, 26.936
- 1325: TR tbc by Sept. 05 / Text3: 26.290, 26.304, 26.273, 26.274, 26.412, 26.936
- 1326: Completed / Text3: 26.235, 26.236
- 1327: Completed / Text3: 26.111, 26.911

| ID | WBS | Task | Type | Duration | Start | Finish | Complete | Baseline start | Baseline finish | Baseline duration | Constraint | Resources | Work | Actual work | Text1 | Text4 | Text5 | Text6 | Text8 | Text3 |
| --- | --- | --- | --- | --- | --- | --- | --- | --- | --- | --- | --- | --- | --- | --- | --- | --- | --- | --- | --- | --- |
| 1329 | 1.359 | **Enhancement of dialled service for CAMEL** |  | 199d | 2003-03-28 A | 2003-12-31 A | 100% | 2003-03-28 | 2003-12-31 | 199d |  | S1 | 3184h | 3184h | EDCAMEL | Samsung | Craig Bishop | Rel-6 | Andrijana |  |
| 1330 | 1.359.1 | Stages 2 and 3 |  | 199d | 2003-03-28 A | 2003-12-31 A | 100% | 2003-03-28 | 2003-12-31 | 199d | finish no earlier than 2003-09-19 | N4 | 1592h | 1592h |  |  |  | Rel-6 |  |  |
| 1331 | 1.360 | Bandwidth and resource savings in CS networks |  | 273d? | 2003-06-01 A | 2004-06-16 A | 100% | 2003-06-01 | 2004-06-16 | 273d? | finish no earlier than 2004-06-16 | S2 | 2184h | 2184h | BARS |  |  | Rel-6 | Sang-Ui | 23.977 |
| 1332 | 1.361 | FS on (U)SIM Security Reuse by Peripheral Devices on Local Interfaces |  | 127d? | 2003-07-03 A | 2003-12-26 A | 100% | 2003-07-03 | 2003-12-26 | 127d? | finish no earlier than 2003-12-26 | S3 | 1016h | 1016h |  | Toshiba | Raziq Yaqub (ryaqub@tari.toshiba.com) | Rel-6 | Maurice |  |
| 1333 | 1.362 | **Multiple TBF in A/Gb mode** |  | 736d? | 2002-04-05 A | 2005-01-28 A | 100% | 2002-04-05 | 2005-01-28 | 736d? |  | GP; G2 | 35200h | 35200h | MULTBF | Ericsson | gunnar.mildh@era.ericsson.se | Rel-6 | Paolo |  |
| 1334 | 1.362.1 | **Multiple TBF in A/Gb mode** |  | 366d? | 2002-04-05 A | 2003-08-29 A | 100% | 2002-04-05 | 2003-08-29 | 366d? |  | GP; G2 | 23424h | 23424h | MULTBF-Agbmode | Ericsson | gunnar.mildh@era.ericsson.se | Rel-6 |  |  |
| 1335 | 1.362.1.1 | Multiple TBF Concept paper |  | 366d? | 2002-04-05 A | 2003-08-29 A | 100% | 2002-04-05 | 2003-08-29 | 366d? | finish no earlier than 2003-08-29 | GP; G2 | 5856h | 5856h |  |  |  | Rel-6 |  |  |
| 1336 | 1.362.1.2 | Multiple TBF Stage 2 (43.064) CRs |  | 366d? | 2002-04-05 A | 2003-08-29 A | 100% | 2002-04-05 | 2003-08-29 | 366d? | finish no earlier than 2003-08-29 | GP; G2 | 5856h | 5856h |  |  |  | Rel-6 |  |  |
| 1337 | 1.362.1.3 | Multiple TBF Stage 3 (44.060) CRs |  | 366d? | 2002-04-05 A | 2003-08-29 A | 100% | 2002-04-05 | 2003-08-29 | 366d? | finish no earlier than 2003-08-29 | GP; G2 | 5856h | 5856h |  |  |  | Rel-6 |  |  |
| 1338 | 1.362.2 | Deleted at TGS # 27 - Multiple TBF in A/Gb mode – MS testing | milestone | 0d? | 2005-01-28 A | 2005-01-28 A | 100% | 2005-01-28 | 2005-01-28 | 0d? | start no earlier than 2005-01-28 | G3 |  |  | MULTBF-Testing | Ericsson | gunnar.mildh@era.ericsson.se | Rel-6 | Paolo |  |
| 1339 | 1.363 | **Alignment between the test-regimes for GERAN capable MS** |  | 526d? | 2003-08-29 A | 2005-09-02 A | 100% | 2003-08-29 | 2005-09-02 | 526d? |  | G3 | 8416h | 8416h | ALTERE | Ericsson | Toubassi | Rel-6 | Stoyan |  |
| 1340 | 1.363.1 | Determine the controversial test cases in the different test regimes and align them with 3GPP GERAN test specifications. Such test cases to be added to TS 51.010. |  | 526d? | 2003-08-29 A | 2005-09-02 A | 100% | 2003-08-29 | 2005-09-02 | 526d? | finish no earlier than 2005-09-02 | G3 | 4208h | 4208h | ALTERE-TC |  |  | Rel-6 |  |  |
| 1341 | 1.364 | Addition of U-TDOA in the CS domain |  | 111d? | 2003-11-21 A | 2004-04-23 A | 100% | 2003-11-21 | 2004-04-23 | 111d? | finish no earlier than 2004-04-23 | GP | 888h | 888h | UTDOACS | TruePosition | Bob Gross, Rhys Robinson (rlgross@trueposition.com) | Rel-6 | Paolo |  |
| 1342 | 1.365 | Addition of U-TDOA in the PS domain |  | 361d? | 2003-06-27 A | 2004-11-12 A | 100% | 2003-06-27 | 2004-11-12 | 361d? | finish no earlier than 2004-11-12 | GP | 2888h | 2888h | UTDOAPS | TruePosition | Bob Gross, Rhys Robinson (rlgross@trueposition.com) | Rel-6 | Paolo |  |
| 1343 | 1.366 | **Downlink Advanced Receiver Performance** |  | 466d? | 2003-11-21 A | 2005-09-02 A | 100% | 2003-11-21 | 2005-09-02 | 466d? |  | GP | 19160h | 19160h | DARP | Nokia | tommy.bysted@nokia.com | Rel-6 | Paolo |  |
| 1344 | 1.366.1 | DARP test scenarios |  | 201d? | 2003-11-21 A | 2004-08-27 A | 100% | 2003-11-21 | 2004-08-27 | 201d? | finish no earlier than 2004-08-27 | GP | 1608h | 1608h | DARP-TS | Nokia | tommy.bysted@nokia.com | Rel-6 | Paolo |  |
| 1345 | 1.366.2 | **DARP for GMSK modulated voice services** |  | 201d? | 2004-02-06 A | 2004-11-12 A | 100% | 2004-02-06 | 2004-11-12 | 201d? |  | GP | 4824h | 4824h | DARP-GMSK | Nokia | tommy.bysted@nokia.com | Rel-6 | Paolo |  |
| 1346 | 1.366.2.1 | Performance requirements in 45.005 |  | 201d? | 2004-02-06 A | 2004-11-12 A | 100% | 2004-02-06 | 2004-11-12 | 201d? | finish no earlier than 2004-11-12 | GP | 1608h | 1608h | DARP-GMSK-Perf |  |  | Rel-6 |  |  |
| 1347 | 1.366.2.2 | Radio subsystem link control in 45.008 |  | 201d? | 2004-02-06 A | 2004-11-12 A | 100% | 2004-02-06 | 2004-11-12 | 201d? | finish no earlier than 2004-11-12 | GP | 1608h | 1608h | DARP-GMSK-LC |  |  | Rel-6 |  |  |
| 1348 | 1.366.3 | **DARP for GPRS and EGPRS MCS1-MCS4** |  | 201d? | 2004-02-06 A | 2004-11-12 A | 100% | 2004-02-06 | 2004-11-12 | 201d? |  | GP | 4824h | 4824h | DARP-GPRSE | Nokia | tommy.bysted@nokia.com | Rel-6 | Paolo |  |
| 1349 | 1.366.3.1 | Performance requirements in 45.005 |  | 201d? | 2004-02-06 A | 2004-11-12 A | 100% | 2004-02-06 | 2004-11-12 | 201d? | finish no earlier than 2004-11-12 | GP | 1608h | 1608h | DARP-GPRSE-Perf |  |  | Rel-6 |  |  |
| 1350 | 1.366.3.2 | Radio subsystem link control in 45.008 |  | 201d? | 2004-02-06 A | 2004-11-12 A | 100% | 2004-02-06 | 2004-11-12 | 201d? | finish no earlier than 2004-11-12 | GP | 1608h | 1608h | DARP-GPRSE-LC |  |  | Rel-6 |  |  |
| 1351 | 1.366.4 | DARP Capability signalling |  | 256d? | 2003-11-21 A | 2004-11-12 A | 100% | 2003-11-21 | 2004-11-12 | 256d? | finish no earlier than 2004-11-12 | GP | 2048h | 2048h | DARP-CAPSIG | Nokia | tommy.bysted@nokia.com | Rel-6 | Paolo |  |
| 1352 | 1.366.5 | GERAN MS Conformance test for DARP |  | 266d? | 2004-08-27 A | 2005-09-02 A | 100% | 2004-08-27 | 2005-09-02 | 266d? | finish no earlier than 2005-06-24 | G3 | 2128h | 2128h | ARP-ConfTest | Nokia | tommy.bysted@nokia.com | Rel-6 | Michael |  |

Notes:
- 1332: Approved TSG#20
- 1338: DELETE
- 1340: Completed
- 1341: Completed, except for potential LMU performance specs
- 1352: Started

| ID | WBS | Task | Type | Duration | Start | Finish | Complete | Remaining | Baseline start | Baseline finish | Baseline duration | Total slack | Constraint | Resources | Work | Actual work | Text1 | Text4 | Text5 | Text6 | Text8 | Text3 | Text10 |
| --- | --- | --- | --- | --- | --- | --- | --- | --- | --- | --- | --- | --- | --- | --- | --- | --- | --- | --- | --- | --- | --- | --- | --- |
| 1353 | 1.367 | **Reduction of PS service interruption in Dual Transfer Mode** |  | 416d? | 2003-11-21 A | 2005-06-24 | 59% | 172.62d? | 2003-11-21 | 2005-06-24 | 416d? | 1230d |  | G2 | 8360h | 2968.18h | PSintDTM | Siemens | toby.proctor@roke.co.uk | Rel-6 | Gert |  |  |
| 1354 | 1.367.1 | Use case and requirement definition |  | 111d? | 2003-11-21 A | 2004-04-23 A | 100% |  | 2003-11-21 | 2004-04-23 | 111d? |  | finish no earlier than 2004-04-23 | G2 | 888h | 888h | PSintDTM-Req | Siemens | toby.proctor@roke.co.uk | Rel-6 | Gert |  |  |
| 1355 | 1.367.2 | Performance Study of Current Procedures |  | 111d? | 2003-11-21 A | 2004-04-23 A | 100% |  | 2003-11-21 | 2004-04-23 | 111d? |  | start no earlier than 2003-11-21 | G2 | 888h | 888h | PSintDTM-Perf | Siemens | toby.proctor@roke.co.uk | Rel-6 | Gert |  |  |
| 1356 | 1.367.3 | Reduction of service interruption times and packet loss during Dual Transfer Mode and mobility procedures |  | 146d? | 2004-04-23 A | 2004-11-12 A | 100% |  | 2004-04-23 | 2004-11-12 | 146d? |  | finish no earlier than 2004-11-12 | G2 | 1168h | 1168h | PSintDTM-Reduct | Siemens | toby.proctor@roke.co.uk | Rel-6 | Gert |  |  |
| 1357 | 1.367.4 | MS Conformance testing |  | 261d? | 2004-06-25 | 2005-06-24 |  |  | 2004-06-25 | 2005-06-24 | 261d? | 1230d | finish no earlier than 2005-06-24 | G3 | 2088h |  | PSintDTM-ConfMS |  |  | Rel-6 | Stoyan |  |  |
| 1358 | 1.367.5 | Deleted - BTS Conformance testing | milestone | 0d? | 2005-06-24 A | 2005-06-24 A | 100% |  | 2005-06-24 | 2005-06-24 | 0d? |  | finish no earlier than 2005-06-24 | G3 |  |  | PSintDTM-ConfBTS |  |  | Rel-6 | Paolo |  |  |
| 1359 | 1.368 | CAMEL prepay interworking with SCUDIF |  | 206d | 2003-12-08 A | 2004-10-05 A | 100% |  | 2003-12-08 | 2004-10-05 | 206d |  |  | N4 | 1648h | 1648h | SCCAMEL |  |  | Rel-6 | Kimmo |  |  |
| 1360 | 1.369 | **Circuit Switched Video and Voice Service Improvements** |  | 430d? | 2004-01-12 A | 2005-09-02 A | 100% |  | 2004-01-12 | 2005-09-02 | 430d? |  |  | S1 | 6536h | 6536h | CS_VSS | Vodafone | John Watson | Rel-6 | Michael | 23.801 |  |
| 1361 | 1.369.1 | Stage 1 - Requirements |  | 199d | 2004-01-12 A | 2004-10-14 A | 100% |  | 2004-01-12 | 2004-10-14 | 199d |  | finish no earlier than 2004-10-14 | S1 | 1592h | 1592h | CS_VSS | Vodafone | John Watson | Rel-6 | Michael |  |  |
| 1362 | 1.369.2 | Stage 2 Study on architecture alternatives |  | 155d? | 2004-01-12 A | 2004-08-13 A | 100% |  | 2004-01-12 | 2004-08-13 | 155d? |  | finish no earlier than 2004-08-13 | S2 | 1240h | 1240h | CS_VSS |  |  | Rel-6 |  |  | SP-24 |
| 1363 | 1.369.3 | Stage 2 description on Redial |  | 164d? | 2004-05-03 A | 2004-12-16 A | 100% |  | 2004-05-03 | 2004-12-16 | 164d? |  | finish no earlier than 2004-12-16 | S2 | 1312h | 1312h | CS_VSS |  |  | Rel-6 |  | 23.903 | SP-24 |
| 1364 | 1.369.4 | Switching between voice and video call - Redial solution |  | 120d? | 2005-01-03 A | 2005-06-17 A | 100% |  | 2005-01-03 | 2005-06-17 | 120d? |  | start no earlier than 2005-01-03 | C1 | 960h | 960h | CS_VSS |  |  | Rel-6 |  |  |  |
| 1365 | 1.369.5 | Deleted - GERAN2 Part | milestone | 0d | 2005-09-02 A | 2005-09-02 A | 100% |  | 2005-09-02 | 2005-09-02 | 0d |  | start no earlier than 2005-09-02 | G2 |  |  | CS_VSS |  |  | Rel-6 | Gert |  |  |
| 1366 | 1.369.6 | Deleted - CN3 Part | milestone | 0d? | 2004-10-14 A | 2004-10-14 A | 100% |  | 2004-10-14 | 2004-10-14 | 0d? |  | start no earlier than 2004-10-14 | N3 |  |  | CS_VSS |  |  | Rel-6 |  |  |  |
| 1367 | 1.370 | Network Domain Security; MAP application layer security (NDS/MAPsec) |  | 127d? | 2004-07-06 A | 2004-12-29 | 20% | 101.6d? | 2004-07-06 | 2004-12-29 | 127d? | 1357d | finish no earlier than 2003-12-26 | S3 | 1016h | 203.2h | MAPSEC | Vodafone | Peter.Howard@vodafone.com | Rel-6 | Maurice |  |  |
| 1368 | 1.371 | FS on Security for early IMS |  | 127d? | 2004-10-01 A | 2005-03-28 A | 100% |  | 2004-10-01 | 2005-03-28 | 127d? |  | finish no earlier than 2003-12-26 | S3 | 1016h | 1016h | SEC-IMS | Vodafone | Peter.Howard@vodafone.com | Rel-6 | Maurice |  |  |
| 1369 | 1.372 | Reorganisation of CS Data Specifications |  | 14d? | 2004-11-19 A | 2004-12-08 A | 100% |  | 2004-11-19 | 2004-12-08 | 14d? |  | finish no earlier than 2004-12-24 | N3 | 112h | 112h | CS Data | Siemens | thomas.belling@siemens.com | Rel-6 | Seung Don |  |  |
| 1370 | 1.373 | **Generic Access to A/Gb Interface (GAAI)** |  | 411d? | 2004-06-25 A | 2006-01-20 | 95% | 20.49d? | 2004-06-25 | 2006-01-20 | 411d? | 1080d |  | GP | 9160h | 8703.25h | GAAI | Motorola |  | Rel-6 | Paolo |  |  |
| 1371 | 1.373.1 | FS on GAAI |  | 46d? | 2004-06-25 A | 2004-08-27 A | 100% |  | 2004-06-25 | 2004-08-27 | 46d? |  | finish no earlier than 2004-08-27 | GP | 368h | 368h | GAAG | Motorola |  | Rel-6 | Paolo | 43.901 |  |
| 1372 | 1.373.2 | GAAI – Stage 2 |  | 161d? | 2004-08-27 A | 2005-04-08 A | 100% |  | 2004-08-27 | 2005-04-08 | 161d? |  | finish no earlier than 2005-04-08 | GP | 1288h | 1288h | GAAI-Stage2 | Ericsson | jari.vikberg@ericsson.com | Rel-6 | Paolo | 43.318 |  |
| 1373 | 1.373.3 | GAAI – Stage 3 |  | 161d? | 2004-08-27 A | 2005-04-08 A | 100% |  | 2004-08-27 | 2005-04-08 | 161d? |  | finish no earlier than 2005-04-08 | GP | 1288h | 1288h | GAAI-Stage3 |  |  | Rel-6 | Gert | 44.318 |  |
| 1374 | 1.373.4 | MS Conformance Test for GAAI |  | 366d? | 2004-08-27 A | 2006-01-20 | 90% | 36.6d? | 2004-08-27 | 2006-01-20 | 366d? | 1080d | finish no earlier than 2006-01-20 | GP | 2928h | 2635.2h | GAAI-CT |  |  | Rel-6 | Stoyan |  |  |
| 1375 | 1.374 | **Support of PS Handover for GERAN A/Gb mode** |  | 473d? | 2003-11-03 A | 2005-08-24 A | 100% |  | 2003-11-03 | 2005-08-24 | 473d? |  |  | GP-G2 | 15136h | 15136h | SPSHAGB | Ericsson | gunnar.hedby@ericsson.com | Rel-6 | Paolo |  |  |
| 1376 | 1.374.1 | Stage 2 |  | 473d? | 2003-11-03 A | 2005-08-24 A | 100% |  | 2003-11-03 | 2005-08-24 | 473d? |  | finish no earlier than 2005-09-02 | GP-G2 | 3784h | 3784h | SPSHAGB-Stage2 | Ericsson | gunnar.hedby@ericsson.com | Rel-6 | Paolo | 43.129 |  |
| 1377 | 1.374.2 | PS handover |  | 473d? | 2003-11-03 A | 2005-08-24 A | 100% |  | 2003-11-03 | 2005-08-24 | 473d? |  | finish no earlier than 2005-09-02 | GP-G2 | 3784h | 3784h | SPSHAGB-PSHO | Ericsson | gunnar.hedby@ericsson.com | Rel-6 | Paolo |  |  |
| 1378 | 1.374.3 | Definition of radio resource management functionality |  | 473d? | 2003-11-03 A | 2005-08-24 A | 100% |  | 2003-11-03 | 2005-08-24 | 473d? |  | finish no earlier than 2005-09-02 | GP-G2 | 3784h | 3784h | SPSHAGB-RRM | Ericsson | gunnar.hedby@ericsson.com | Rel-6 | Paolo |  |  |

Notes:
- 1357: On-going
- 1367: Approved TSG#24
- 1368: Approved TSG#24. TR 33.978 Approved at TSG SA #27
- 1369: Created at TSG#27 as 100 % complete
- 1371: Feasibility Study
- 1372: Completed
- 1373: Completed
- 1374: Started
- 1375: Replaces SCSAGB- Originally Started Nov 2003 as GP-030443
- 1376: Replaces SCSAGB-Stage2
- 1377: Replaces SCSAGB-PSH
- 1378: Replaces SCSAGB-RRM

| ID | WBS | Task | Type | Duration | Start | Finish | Complete | Remaining | Baseline start | Baseline finish | Baseline duration | Total slack | Constraint | Resources | Work | Actual work | Text1 | Text6 | Text3 | Text8 | Text4 | Text5 | Text12 | Text11 |
| --- | --- | --- | --- | --- | --- | --- | --- | --- | --- | --- | --- | --- | --- | --- | --- | --- | --- | --- | --- | --- | --- | --- | --- | --- |
| 1379 | 1.375 | **small Technical Enhancements and Improvements for Rel-6** |  | 503d? | 2006-06-02 A | 2008-05-06 A | 100% |  | 2006-06-02 | 2008-05-06 | 503d? |  |  | Generic | 8048h | 8048h | TEI6 | Rel-6 |  |  |  |  |  |  |
| 1380 | 1.375.1 | Small Technical Enhancements and Improvements for Rel-6 Conformance Testing |  | 503d? | 2006-06-02 A | 2008-05-06 A | 100% |  | 2006-06-02 | 2008-05-06 | 503d? |  | start no earlier than 2006-06-02 | R5 | 4024h | 4024h | TEI6_Test | Rel-6 | 34.108,34.121-1/2,34.122,34.123-1/2/3 | Stoyan Baev |  |  |  |  |
| 1381 | 1.376 | Deleted - Study of Feature Interactions Requirements | milestone | 0d? | 2004-10-01 A | 2004-10-01 A | 100% |  | 2004-10-01 | 2004-10-01 | 0d? |  | finish no earlier than 2004-10-01 | S1 |  |  | FINTER | Rel-6 |  |  |  |  |  |  |
| 1382 | 1.377 | Deleted (moved to Rel7) - Enhancements of VGCS in public networks for communication of public authority officials | milestone | 0d? | 2005-08-24 A | 2005-08-24 A | 100% |  | 2005-08-24 | 2005-08-24 | 0d? |  | start no earlier than 2005-08-24 | GP-G2 |  |  | EVGCS | Rel-6 | 44.018, 44.068, 48.008 | Gert | Siemens | kenneth.isaacs@roke.co.uk |  |  |
| 1383 | 1.378 | **Deleted - Support of Conversational Services in A/Gb mode via the PS domain** |  | 64d? | 2003-11-21 A | 2004-02-19 A | 100% |  | 2003-11-21 | 2004-02-19 | 64d? |  |  | GP |  |  | SCSAGB | Rel-6 |  | Paolo | Ericsson | David Bladsjö (david.bladsjo@ericsson.com) |  |  |
| 1384 | 1.378.1 | Delete - Creation of a TR | milestone | 0d? | 2003-11-21 A | 2003-11-21 A | 100% |  | 2003-11-21 | 2003-11-21 | 0d? |  | start no earlier than 2003-11-21 | GP |  |  | SCSAGB-TR | Rel-6 |  |  | Ericsson | David Bladsjö (david.bladsjo@ericsson.com) |  |  |
| 1385 | 1.378.2 | Delete - Stage 2 | milestone | 0d? | 2003-11-21 A | 2003-11-21 A | 100% |  | 2003-11-21 | 2003-11-21 | 0d? |  | finish no earlier than 2003-11-21 | GP |  |  | SCSAGB-Stage2 | Rel-6 |  |  | Ericsson | David Bladsjö (david.bladsjo@ericsson.com) |  |  |
| 1386 | 1.378.3 | Delete - Radio Channel Support | milestone | 0d? | 2003-11-21 A | 2003-11-21 A | 100% |  | 2003-11-21 | 2003-11-21 | 0d? |  | finish no earlier than 2003-11-21 | GP |  |  | SCSAGB-RCS | Rel-6 |  |  | Ericsson | David Bladsjö (david.bladsjo@ericsson.com) |  |  |
| 1387 | 1.378.4 | Delete - Definition of radio resource management functionality | milestone | 0d? | 2003-11-21 A | 2003-11-21 A | 100% |  | 2003-11-21 | 2003-11-21 | 0d? |  | finish no earlier than 2003-11-21 | GP; G2 |  |  | SCSAGB-RRM | Rel-6 |  |  | Ericsson | David Bladsjö (david.bladsjo@ericsson.com) |  |  |
| 1388 | 1.378.5 | Delete, replaced by 50561 - PS Handover | milestone | 0d | 2003-11-21 A | 2004-02-19 A | 100% |  | 2003-11-21 | 2004-02-19 | 0d |  | start no earlier than 2003-11-21 | GP; GP, N1 |  |  | SCSAGB-PSH | Rel-6 |  |  | Ericsson | David Bladsjö (david.bladsjo@ericsson.com) |  |  |
| 1389 | 1.378.6 | Delete - Modifications to FLO | milestone | 0d? | 2003-11-21 A | 2003-11-21 A | 100% |  | 2003-11-21 | 2003-11-21 | 0d? |  | finish no earlier than 2003-11-21 | GP; G2 |  |  | SCSAGB-FLO | Rel-6 |  |  | Ericsson | David Bladsjö (david.bladsjo@ericsson.com) | RP-29 |  |
| 1390 | 1.379 | Deleted - Rel-6 Evolutions of the transport in the UTRAN | milestone | 0d | 2003-12-31 A | 2003-12-31 A | 100% |  | 2003-12-31 | 2003-12-31 | 0d |  | start no earlier than 2003-12-31 | RP |  |  | ETRAN | Rel-6 |  | Cesar | Alcatel | francois.courau@alcatel.fr |  | Generic |
| 1391 | 1.380 | Release 5 Features |  | 1d? | 2000-01-03 | 2000-01-03 |  |  | 2000-01-03 | 2000-01-03 | 1d? | 2659d |  | CP,GP, RP,SP,TP | 8h |  |  | Rel-5 |  |  |  |  |  |  |
| 1392 | 75 | IP transport in the UTRAN |  | 445d | 2000-07-17 A | 2002-03-29 A | 100% |  | 2000-07-17 | 2002-03-29 | 445d |  | finish no earlier than 2002-03-29 | R3 | 3560h | 3560h | ETRAN-IPtrans | Rel-5 |  |  | Alcatel | Nicolas Drevon |  |  |
| 1393 | 76 | FS on Usage of SUA |  | 205d | 2001-03-12 A | 2001-12-21 A | 100% |  | 2001-03-12 | 2001-12-21 | 205d |  | finish no earlier than 2001-12-21 | N4 | 1640h | 1640h | SS7IP | Rel-5 |  |  |  |  |  |  |
| 1394 | 77 | **High Speed Downlink Packet Access** |  | 570d | 2001-04-02 A | 2003-06-06 A | 100% |  | 2001-04-02 | 2003-06-06 | 570d |  |  | R2 | 15272h | 15272h | HSDPA | Rel-5 |  | Cesar | Motorola | Ravi Kuchibhotla |  |  |
| 1395 | 77.1 | Physical Layer |  | 257d | 2001-04-05 A | 2002-03-29 A | 100% |  | 2001-04-05 | 2002-03-29 | 257d |  | finish no earlier than 2002-03-29 | R1 | 2056h | 2056h | HSDPA-Phys |  |  |  | Motorola | Amitava Ghosh |  |  |
| 1396 | 77.2 | Layer 2 and 3 aspects |  | 257d | 2001-04-05 A | 2002-03-29 A | 100% |  | 2001-04-05 | 2002-03-29 | 257d |  | finish no earlier than 2002-03-29 | R2 | 2056h | 2056h | HSDPA-L23 |  |  |  | Motorola | Ravi Kuchibhotla |  |  |
| 1397 | 77.3 | Iub/Iur protocol aspects |  | 260d | 2001-04-02 A | 2002-03-29 A | 100% |  | 2001-04-02 | 2002-03-29 | 260d |  | finish no earlier than 2002-03-29 | R3 | 2080h | 2080h | HSDPA-IubIur |  |  |  | Motorola | Mike Diesen |  |  |
| 1398 | 77.4 | RF Radio Transmission/ Reception, System Performance Requirements and Conformance Testing |  | 565d | 2001-04-09 A | 2003-06-06 A | 100% |  | 2001-04-09 | 2003-06-06 | 565d |  | finish no earlier than 2003-06-06 | R4 | 4520h | 4520h | HSDPA-RF |  |  |  | Motorola | Howard Benn |  |  |
| 1399 | 78 | **Rel-5 Improvements of Radio Interface** |  | 535d | 2000-08-14 A | 2002-08-30 | 89% | 56.7d | 2000-08-14 | 2002-08-30 | 535d | 1965d |  | RP | 30376h | 27009h | RInImp | NA |  | Tsukasa |  |  |  |  |
| 1400 | 78.1 | **Base station classification** |  | 480d | 2000-08-14 A | 2002-06-14 A | 100% |  | 2000-08-14 | 2002-06-14 | 480d |  |  | R4 | 9208h | 9208h | RInImp-BSClass | Rel-5 |  |  | Nokia | A. Toskala |  |  |
| 1401 | 78.1.1 | TDD Base station classification |  | 410d | 2000-08-14 A | 2002-03-08 A | 100% |  | 2000-08-14 | 2002-03-08 | 410d |  | finish no earlier than 2002-03-08 | R4 | 3280h | 3280h | RInImp-BSClass-TDD |  |  |  | Nokia | A. Toskala |  |  |
| 1402 | 78.1.2 | Base Station Classification for 1.28 Mcps TDD option |  | 261d | 2001-06-15 A | 2002-06-14 A | 100% |  | 2001-06-15 | 2002-06-14 | 261d |  | finish no earlier than 2002-06-14 | R4 | 2088h | 2088h | RInImp-BSClass-LCRTDD |  |  |  | Siemens | Meik.Kottkamp@siemens.com |  |  |
| 1403 | 78.2 | Enhancement on the DSCH hard split mode |  | 271d | 2001-03-16 A | 2002-03-29 A | 100% |  | 2001-03-16 | 2002-03-29 | 271d |  | finish no earlier than 2002-03-29 | R1 | 2168h | 2168h | RInImp-DSCHhsp | Rel-5 |  |  | Samsung | Jaeyoel KIM |  |  |
| 1404 | 78.3 | Hybrid ARQ II/III |  | 355d | 2000-08-21 A | 2001-12-28 A | 100% |  | 2000-08-21 | 2001-12-28 | 355d |  | finish no earlier than 2001-12-28 | R2 | 2840h | 2840h | RInImp-HARQ | Rel-5 |  |  | Siemens | A. Sitte |  |  |
| 1405 | 78.4 | FS on USTS |  | 355d | 2000-08-14 A | 2001-12-21 A | 100% |  | 2000-08-14 | 2001-12-21 | 355d |  | finish no earlier than 2001-12-21 | R1 | 2840h | 2840h | RInImp-USTS | Rel-5 |  |  | SK Telecom | D. Kim |  |  |
| 1406 | 78.5 | FS on UE antenna efficency test method performance requirements |  | 255d | 2000-09-25 A | 2001-09-14 A | 100% |  | 2000-09-25 | 2001-09-14 | 255d |  | finish no earlier than 2001-09-14 | R4 | 2040h | 2040h | RInImp-UEAnTM | Rel-5 |  |  | Allgon | O. Edvardsson |  |  |
| 1407 | 78.6 | FS on the re-introduction of the downlink SIR measurement |  | 200d | 2001-03-12 A | 2001-12-14 A | 100% |  | 2001-03-12 | 2001-12-14 | 200d |  | finish no earlier than 2001-12-14 | R4 | 1600h | 1600h | RInImp-SIR | Rel-5 |  | Cesar | Ericsson | Torgny.Palenius@ericsson.com |  |  |
| 1408 | 78.7 | FS on mitigating the effect of CPICH interference at the UE |  | 255d | 2001-03-19 A | 2002-03-08 A | 100% |  | 2001-03-19 | 2002-03-08 | 255d |  | finish no earlier than 2002-03-08 | R4 | 2040h | 2040h | RInImp-CPICH_Intf | Rel-5 |  | Cesar | Intel | shimon.moshavi@INTEL.COM |  |  |

Notes:
- 1379: "Joker" WI, to be used for a Rel 6 CR not related to any feature and with very limited impact on the system. Moved in from Stoyan/Testing WP
- 1380: "Joker" WI, to be used for small modifications applicable to Rel 4 conformance testing
- 1381: SP-23 - To be abandoned?
- 1382: Started
- 1385: Started
- 1386: Not started
- 1387: Not started
- 1388: Started
- 1389: Not started
- 1390: Generic feature
- 1393: update WID / 30.11.2001: To CN #14 for approval
- 1396: 30 November: Completion date shifted to March 2002
- 1404: Stopped at RP#14; work on this task was performed as part of High Speed Downlink Packet Access feature

| ID | WBS | Task | Type | Duration | Start | Finish | Predecessors | Complete | Remaining | Baseline start | Baseline finish | Baseline duration | Total slack | Free slack | Constraint | Resources | Work | Actual work | Text6 | Text1 | Text8 | Text4 | Text5 | Text3 |
| --- | --- | --- | --- | --- | --- | --- | --- | --- | --- | --- | --- | --- | --- | --- | --- | --- | --- | --- | --- | --- | --- | --- | --- | --- |
| 1409 | 78.8 | **Conformance Test Spec. improvements in Radio Interface** |  | 140d | 2002-02-18 | 2002-08-30 |  |  |  | 2002-02-18 | 2002-08-30 | 140d | 1965d |  |  | T1 | 3360h |  |  |  |  |  |  |  |
| 1410 | 78.8.1 | Testing improvement of inter-frequency and inter-system measurement |  | 140d | 2002-02-18 | 2002-08-30 |  |  |  | 2002-02-18 | 2002-08-30 | 140d | 1965d |  | finish no earlier than 2002-08-30 | T1 | 1120h |  | Rel-5 |  |  |  |  |  |
| 1411 | 78.8.2 | Testing Hybrid ARQ II/III |  | 140d | 2002-02-18 | 2002-08-30 |  |  |  | 2002-02-18 | 2002-08-30 | 140d | 1965d |  | finish no earlier than 2002-08-30 | T1 | 1120h |  | Rel-5 |  |  |  |  |  |
| 1412 | 79 | **Rel-5 RAN improvements** |  | 772d? | 2001-03-16 A | 2004-03-01 |  | 87% | 100.69d? | 2001-03-16 | 2004-03-01 | 772d? | 1574d |  |  | RP | 39984h | 28864h | NA | RANimp | Cesar |  |  |  |
| 1413 | 79.1 | **RRM optimization for Iur and Iub** |  | 318d | 2001-03-16 A | 2002-06-04 A |  | 100% |  | 2001-03-16 | 2002-06-04 | 318d |  |  |  | R3 | 8904h | 8904h | Rel-5 | RANimp-RRMopt |  | Ericsson | Gert-Jan.van.Lieshout@eln.ericsson.se |  |
| 1414 | 79.1.1 | Iur common transport channel efficiency optimisation |  | 271d | 2001-03-16 A | 2002-03-29 A |  | 100% |  | 2001-03-16 | 2002-03-29 | 271d |  |  | finish no earlier than 2002-03-29 | R3 | 2168h | 2168h |  | RANimp-RRMopt-ctc |  | Ericsson | Shahrokh Amirijoo |  |
| 1415 | 79.1.2 | Iur neighbouring cell reporting efficiency optimisation |  | 271d | 2001-03-16 A | 2002-03-29 A |  | 100% |  | 2001-03-16 | 2002-03-29 | 271d |  |  | finish no earlier than 2002-03-29 | R3 | 2168h | 2168h |  | RANimp-RRMopt-ncr |  | Ericsson | Shahrokh Amirijoo |  |
| 1416 | 79.1.3 | FS Introduction of direct transport bearers between SRNC and Node-B |  | 253d | 2001-06-15 A | 2002-06-04 A |  | 100% |  | 2001-06-15 | 2002-06-04 | 253d |  |  | finish no earlier than 2002-06-28 | R3 | 2024h | 2024h |  | RAN-imp-RRMopt-DTB |  | Ericsson | Risto Sepponen |  |
| 1417 | 79.2 | RL Timing Adjustment |  | 271d | 2001-03-16 A | 2002-03-29 A |  | 100% |  | 2001-03-16 | 2002-03-29 | 271d |  |  | finish no earlier than 2002-03-29 | R3 | 2168h | 2168h | Rel-5 | RANimp-RLTA |  | Ericsson | Elena Voltolina |  |
| 1418 | 79.3 | Separation of resource reservation and radio link activation |  | 271d | 2001-03-16 A | 2002-03-29 A |  | 100% |  | 2001-03-16 | 2002-03-29 | 271d |  |  | finish no earlier than 2002-03-29 | R3 | 2168h | 2168h | Rel-5 | RANimp-SepRR |  | Ericsson | Gert-Jan.van.Lieshout@eln.ericsson.se |  |
| 1419 | 79.4 | FS SRNS Relocation Procedure Enhancement |  | 318d | 2001-06-15 A | 2002-09-03 A |  | 100% |  | 2001-06-15 | 2002-09-03 | 318d |  |  | finish no earlier than 2002-09-06 | R3 | 2544h | 2544h | Rel-5 | RANimp-SRNS |  | Nokia | Olivier Guyot |  |
| 1420 | 79.5 | FS Improvement of Radio Resource Management across RNS and RNS/PSS |  | 201d | 2001-03-16 A | 2001-12-21 A |  | 100% |  | 2001-03-16 | 2001-12-21 | 201d |  |  | finish no earlier than 2001-12-21 | R3 | 1608h | 1608h | Rel-5 | RANimp-ImpRRM |  | Nokia | Antti Toskala |  |
| 1421 | 79.6 | Re-arrangements of Iub transport bearers |  | 271d | 2001-03-16 A | 2002-03-29 A |  | 100% |  | 2001-03-16 | 2002-03-29 | 271d |  |  | finish no earlier than 2002-03-29 | R3 | 2168h | 2168h | Rel-5 | RANimp-TTPS |  | Nokia | Antti Toskala |  |
| 1422 | 79.7 | RAB support enhancement for Rel-5 |  | 325d | 2001-04-02 A | 2002-06-28 A |  | 100% |  | 2001-04-02 | 2002-06-28 | 325d |  |  | finish no earlier than 2002-06-28 | R2 | 2600h | 2600h | Rel-5 | RANimp-RABSE5 |  | Nokia | Juha Mikola |  |
| 1423 | 79.8 | Beamforming requirements for UE |  | 61d | 2001-09-21 A | 2001-12-14 A |  | 100% |  | 2001-09-21 | 2001-12-14 | 61d |  |  | finish no earlier than 2001-12-14 | R1 | 488h | 488h | Rel-5 | RANimp-BFR-UE |  | Nokia | Jussi Kähtävä |  |
| 1424 | 79.9 | Support of Site Selection Diversity Transmission in UTRAN |  | 123d | 2001-12-14 A | 2002-06-04 A |  | 100% |  | 2001-12-14 | 2002-06-04 | 123d |  |  | finish no earlier than 2002-06-04 | R1 | 984h | 984h | Rel-5 | RANimp-SSDT |  | NEC |  |  |
| 1425 | 79.10 | Node B Synchronisation for 1.28 Mcps TDD |  | 271d | 2001-03-16 A | 2002-03-29 A |  | 100% |  | 2001-03-16 | 2002-03-29 | 271d |  |  | finish no earlier than 2002-03-29 | R1 | 2168h | 2168h | Rel-5 | RANimp-NBSLCR |  | CATT | Jinling HU |  |
| 1426 | 79.11 | Start Testing | milestone | 0d | 2001-12-03 | 2001-12-03 |  |  |  | 2001-12-03 | 2001-12-03 | 0d | 1899d | 21d | start no earlier than 2001-12-03 | MLST |  |  |  |  |  |  |  |  |
| 1427 | 79.12 | **Conformance Test Aspects - RAN Improvements** |  | 565d? | 2002-01-01 | 2004-03-01 | 1426 |  |  | 2002-01-01 | 2004-03-01 | 565d? | 1574d |  |  | T1 | 8008h |  |  |  |  |  |  | 0% |
| 1428 | 79.12.1 | Testing Radio access bearer support enhancments |  | 175d | 2002-01-01 | 2002-09-02 |  |  |  | 2002-01-01 | 2002-09-02 | 175d | 1964d |  | finish no earlier than 2002-09-02 | T1 | 1400h |  |  |  |  |  |  |  |
| 1429 | 1.385.12.2 | General changes to TS34.121 and TS34.122 corresponding to release 5 |  | 261d? | 2003-03-03 | 2004-03-01 |  |  |  | 2003-03-03 | 2004-03-01 | 261d? | 1574d |  | finish no earlier than 2004-03-01 | T1 | 2088h |  | Rel-5 | RANimp-test |  |  |  | 34.108, 34.121, 34.122 |
| 1430 | 80 | UTRAN Sharing in Connected Mode |  | 197d | 2001-12-03 A | 2002-09-03 A |  | 100% |  | 2001-12-03 | 2002-09-03 | 197d |  |  | finish no earlier than 2002-09-06 | R3 | 1576h | 1576h | Rel-5 | NETSHARE |  | Ericsson | Martin Israelsson |  |
| 1431 | 81 | **Provisioning of IP-based multimedia services** |  | 1088d | 2000-01-03 A | 2004-03-03 |  | 92% | 90.44d | 2000-01-03 | 2004-03-03 | 1088d | 1572d |  |  | S1 | 184852h | 166937h | NA | IMS | MichaelC/Alain | Openwave | Mark Cataldo |  |
| 1432 | 81.1 | **Call control and roaming to support IMS in UMTS** |  | 640d | 2000-01-03 A | 2002-06-14 |  | 98% | 12.24d | 2000-01-03 | 2002-06-14 | 640d | 2020d |  |  | S2 | 82520h | 77103h | Rel-5 | IMS-CCR |  | Lucent | Liz Daniel |  |
| 1433 | 81.1.1 | Stage 1 |  | 215d | 2000-02-21 A | 2000-12-15 A |  | 100% |  | 2000-02-21 | 2000-12-15 | 215d |  |  | finish no earlier than 2000-09-21 | S1 | 1720h | 1720h |  |  |  | Motorola | Mark Cataldo (mcatald1@email.mot.com) | 22.228 |
| 1434 | 81.1.2 | Stage 2 (Architecture and Main flows) |  | 246d | 2000-04-14 A | 2001-03-23 A |  | 100% |  | 2000-04-14 | 2001-03-23 | 246d |  |  | finish no earlier than 2001-03-23 | S2 | 1968h | 1968h |  |  |  | Lucent | Liz Daniel | 23.228 |
| 1435 | 81.1.3 | Impact on MM/CC/SM |  | 400d | 2000-08-28 A | 2002-03-08 A |  | 100% |  | 2000-08-28 | 2002-03-08 | 400d |  |  | finish no earlier than 2002-03-08 | N1 | 3200h | 3200h |  | IMS-CCR-IWMM |  | Lucent | Keith Drage (drage@lucent.com) |  |

Notes:
- 1410: start/finish dates set / Not started due to lack of supporting companies
- 1411: start/finish dates set / Not started yet due to lack of supporting companies
- 1416: FS was closed and introduction of WI not agreed at RAN #16
- 1420: FS was closed and WI was introduced at RAN #14
- 1422: RFC 3095 context relocation
- 1424: RP-020356
- 1428: duration set to 6 months (was 0) / Task not started due to lack of supporting companies
- 1430: Formerly 'Shared Network support in connected mode', renamed at RAN #16.
- 1431: S1 WI proposed S1-000290 / TR22.976, WI Rapporteur, Mark Cataldo, Motorola
- 1433: Issues include e.g.: Roaming requirements, Requirements on supplementary services, Interworking requirements
- 1434: Issues include e.g.: Mobile IP, RAB selection principles, Optimized VoIP bearer mechanisms, SIP multimedia protocol
- 1435: Per 26/2-02: This is understood to be the PCO & TFT CRs which CN1 provides to TSGN #15 for approval. If this is correct understanding, then the task is 100 % complete.

| ID | WBS | Task | Duration | Start | Finish | Complete | Remaining | Baseline start | Baseline finish | Baseline duration | Total slack | Constraint | Resources | Work | Actual work | Text3 | Text4 | Text5 | Text1 | Text6 |
| --- | --- | --- | --- | --- | --- | --- | --- | --- | --- | --- | --- | --- | --- | --- | --- | --- | --- | --- | --- | --- |
| 1436 | 81.1.4 | **SIP Call Control protocol for the IMS** | 640d | 2000-01-03 A | 2002-06-14 | 98% | 13.73d | 2000-01-03 | 2002-06-14 | 640d | 2020d |  | N1 | 70800h | 65682h | 24.228, 24.229, 23.218 | Lucent | Keith Drage (drage@lucent.com) |  |  |
| 1437 | 81.1.4.1 | IMS signalling flows | 385d | 2000-10-02 A | 2002-03-22 A | 100% |  | 2000-10-02 | 2002-03-22 | 385d |  | finish no earlier than 2002-03-22 | N1 | 3080h | 3080h | 24.228 |  |  |  |  |
| 1438 | 81.1.4.2 | IMS stage 3 | 385d | 2000-10-02 A | 2002-03-22 A | 100% |  | 2000-10-02 | 2002-03-22 | 385d |  | finish no earlier than 2002-03-22 | N1 | 3080h | 3080h | 24.229 |  |  |  |  |
| 1439 | 81.1.4.3 | IMS Session Handling; stage 2 | 385d | 2000-10-02 A | 2002-03-22 A | 100% |  | 2000-10-02 | 2002-03-22 | 385d |  | finish no earlier than 2002-03-22 | N1 | 3080h | 3080h | 23.218 |  |  |  |  |
| 1440 | 81.1.4.4 | **Main IETF dependencies** | 635d | 2000-01-03 A | 2002-06-07 | 99% | 0d | 2000-01-03 | 2002-06-07 | 635d | 0d |  | NP | 45392h | 43712h |  |  |  |  |  |
| 1441 | 81.1.4.4.1 | IETF: RFC 3261 (Session Initiation Protocol) | 346d | 2000-11-24 A | 2002-03-22 A | 100% |  | 2000-11-24 | 2002-03-22 | 346d |  | finish no earlier than 2002-03-22 | N1 | 2768h | 2768h |  |  |  |  |  |
| 1442 | 81.1.4.4.2 | IETF: RFC 3262 (Reliability of provisional responses) | 346d | 2000-11-24 A | 2002-03-22 A | 100% |  | 2000-11-24 | 2002-03-22 | 346d |  | finish no earlier than 2002-03-22 | N1 | 2768h | 2768h |  |  |  |  |  |
| 1443 | 81.1.4.4.3 | IETF: RFC 3312 (Without COMET)(Integration of resource management and SIP) | 382d | 2000-11-24 A | 2002-05-13 A | 100% |  | 2000-11-24 | 2002-05-13 | 382d |  | finish no earlier than 2002-05-13 | N1 | 3056h | 3056h |  |  |  |  |  |
| 1444 | 81.1.4.4.4 | IETF: RFC 3323 (SIP extensions for caller identity and privacy) | 382d | 2000-11-24 A | 2002-05-13 A | 100% |  | 2000-11-24 | 2002-05-13 | 382d |  | finish no earlier than 2002-05-13 | N1 | 3056h | 3056h |  |  |  |  |  |
| 1445 | 81.1.4.4.5 | IETF: RFC 3313 (SIP extensions for media authorization) | 382d | 2000-11-24 A | 2002-05-13 A | 100% |  | 2000-11-24 | 2002-05-13 | 382d |  | finish no earlier than 2002-05-13 | N1 | 3056h | 3056h |  |  |  |  |  |
| 1446 | 81.1.4.4.6 | IETF: RFC 3265 (specific event notification) | 346d | 2000-11-24 A | 2002-03-22 A | 100% |  | 2000-11-24 | 2002-03-22 | 346d |  | finish no earlier than 2002-03-22 | N1 | 2768h | 2768h |  |  |  |  |  |
| 1447 | 81.1.4.4.7 | IETF: RFC editor Queue (refer method) | 401d | 2000-11-24 A | 2002-06-07 A | 100% |  | 2000-11-24 | 2002-06-07 | 401d |  | finish no earlier than 2002-06-07 | N1 | 3208h | 3208h |  |  |  |  |  |
| 1448 | 81.1.4.4.8 | IETF: RFC editor Queue (DHCP options for SIP servers) | 382d | 2000-11-24 A | 2002-05-13 A | 100% |  | 2000-11-24 | 2002-05-13 | 382d |  | finish no earlier than 2002-05-13 | N1 | 3056h | 3056h |  |  |  |  |  |
| 1449 | 81.1.4.4.10 | IETF: RFC 3267 (AMR and AMR WB RTP and SDP) | 346d | 2000-11-24 A | 2002-03-22 A | 100% |  | 2000-11-24 | 2002-03-22 | 346d |  | finish no earlier than 2002-03-22 | N1 | 2768h | 2768h |  |  |  |  |  |
| 1450 | 81.1.4.4.11 | IETF: RFC 3266 (IPv6 support within SDP) | 580d | 2000-01-03 A | 2002-03-22 A | 100% |  | 2000-01-03 | 2002-03-22 | 580d |  | finish no earlier than 2002-03-22 | N1 | 4640h | 4640h |  |  |  |  |  |
| 1451 | 81.1.4.4.12 | IETF: RFC 3311 (The Update method) | 382d | 2000-11-24 A | 2002-05-13 A | 100% |  | 2000-11-24 | 2002-05-13 | 382d |  | finish no earlier than 2002-05-13 | N1 | 3056h | 3056h |  |  |  |  |  |
| 1452 | 81.1.4.4.13 | IETF: RFC 3324 (Network Asserted Identity) | 382d | 2000-11-24 A | 2002-05-13 A | 100% |  | 2000-11-24 | 2002-05-13 | 382d |  | finish no earlier than 2002-05-13 | N1 | 3056h | 3056h |  |  |  |  |  |
| 1453 | 81.1.4.4.14 | IETF: RFC editor Queue (Various 3GPP Private Extensions) | 382d | 2000-11-24 A | 2002-05-13 A | 100% |  | 2000-11-24 | 2002-05-13 | 382d |  | finish no earlier than 2002-05-13 | N1 | 3056h | 3056h |  |  |  |  |  |
| 1454 | 81.1.4.5 | **Addressing** | 380d | 2000-10-09 A | 2002-03-22 A | 100% |  | 2000-10-09 | 2002-03-22 | 380d |  |  | S2 | 7744h | 7744h |  |  |  |  |  |
| 1455 | 81.1.4.5.1 | Architectural issues | 235d | 2000-10-09 A | 2001-08-31 A | 100% |  | 2000-10-09 | 2001-08-31 | 235d |  | finish no earlier than 2001-03-16 | S2 | 1880h | 1880h |  |  |  |  |  |
| 1456 | 81.1.4.5.2 | Impact on HSS | 353d | 2000-11-15 A | 2002-03-22 A | 100% |  | 2000-11-15 | 2002-03-22 | 353d |  | finish no earlier than 2002-03-22 | N4 | 2824h | 2824h |  |  |  |  |  |
| 1457 | 81.1.4.6 | **Service Examples (Work stopped)** | 304d | 2001-04-17 A | 2002-06-14 | 50% | 152d | 2001-04-17 | 2002-06-14 | 304d | 2020d |  | S1 | 4864h | 1502.4h | 22.928 | Motorola | Mark Cataldo (mcatald1@email.mot.com) | IMS-Sex |  |
| 1458 | 81.1.4.6.1 | IMS Framework Report (work stopped) | 304d | 2001-04-17 A | 2002-06-14 | 50% | 152d | 2001-04-17 | 2002-06-14 | 304d | 2020d | finish no earlier than 2002-06-14 | S1 | 2432h | 1216h | 22.941 | SBC | Randolph Wohlert (rwohlert@tri.sbc.com) | IMS-FrWk |  |
| 1459 | 81.2 | **Access Security for IMS** | 190d | 2001-10-08 A | 2002-06-28 A | 100% |  | 2001-10-08 | 2002-06-28 | 190d |  |  | S3 | 4120h | 4120h |  | Ericsson | krister.boman@emw.ericsson.se | IMS-ASEC | Rel-5 |
| 1460 | 81.2.2 | IMS impacts on UICC (ISIM application) | 185d | 2001-10-08 A | 2002-06-21 A | 100% |  | 2001-10-08 | 2002-06-21 | 185d |  | finish no earlier than 2002-06-21 | T3 | 1480h | 1480h |  | Vodafone | Jeremy Norris |  |  |
| 1461 | 81.2.3 | SIP extensions for Integrity protection | 140d | 2001-12-17 A | 2002-06-28 A | 100% |  | 2001-12-17 | 2002-06-28 | 140d |  | finish no earlier than 2002-06-28 | N1 | 1120h | 1120h |  |  |  |  |  |
| 1462 | 81.3 | Security Aspects of Requirement for Network Configuration Independence | 130d | 2001-07-02 A | 2001-12-28 A | 100% |  | 2001-07-02 | 2001-12-28 | 130d |  | finish no earlier than 2001-12-28 | S3 | 1040h | 1040h |  | AT&T Wireless | hugh.shieh@attws.com | SEC1-NCI | Rel-5 |
| 1463 | 81.4 | Lawful interception | 410d | 2000-09-04 A | 2002-03-29 A | 100% |  | 2000-09-04 | 2002-03-29 | 410d |  | finish no earlier than 2002-03-29 | S3 | 3280h | 3280h |  | Reg TP | berthold.wilhelm@regtp.de | IMS-LI | Rel-5 |
| 1464 | 81.5 | Charging and OAM&P for IMS | 383d | 2000-12-25 A | 2002-06-12 A | 100% |  | 2000-12-25 | 2002-06-12 | 383d |  | finish no earlier than 2002-06-12 | S5 | 3064h | 3064h | 32-series | VoiceStream, Motorola | Albert.Yuhan@voicestream.com; Michael.Truss@MOTOROLA.COM | IMS-OAM | Rel-5 |

Notes:
- 1436: TSGN_10 approved the change:CN1 - SA2 SIP joint meeting spotted one more place for improvement: work tasks with ID 1998 and 1278 are actually subtasks under of single CN1 WT. One WI has been approved for the CN1 WT with title "SIP Call Control protocol...
- 1437: TS 24.228...
- 1438: TS 24.229...
- 1439: TS 23.218...
- 1456: 17th May, KK: This is cover by 29.228 & 29228. Work complete.
- 1459: TS33.203 will be presented for info at SA#14 and is scheduled for approval at SA#15. Dependencies on IETF exist. Approved SA#15
- 1461: Per 26/2-02: CN1 is not aware of any requirements and is not doing anything on this task.
- 1462: Incorporated into IMS access security TS (33.203) which will be presented for info at SA#14 and is scheduled for approval at SA#15.Editors notes removed SA#16&17
- 1463: Rel-5 33.106 and 33.107 approved at SA#12.Revised WID including new Rel-5 specification (33.108) scheduled for approval at SA#14. 33.108 approved SA#16. CR at SA#17

| ID | WBS | Task | Duration | Start | Finish | Complete | Remaining | Baseline start | Baseline finish | Baseline duration | Total slack | Constraint | Resources | Work | Actual work | Text1 | Text3 | Text4 | Text5 | Text6 |
| --- | --- | --- | --- | --- | --- | --- | --- | --- | --- | --- | --- | --- | --- | --- | --- | --- | --- | --- | --- | --- |
| 1465 | 81.6 | **Multimedia codecs and protocols for conversational PS services** | 568d | 2000-07-26 A | 2002-09-27 A | 100% |  | 2000-07-26 | 2002-09-27 | 568d |  |  | S4 | 15640h | 15640h | IMS-CODEC | 26.235, 26.236 | Toshiba, Nokia | B. Aronson (Toshiba), pasi.s.ojala@nokia.com | Rel-5 |
| 1466 | 81.6.1 | Codecs | 427d | 2000-07-26 A | 2002-03-14 A | 100% |  | 2000-07-26 | 2002-03-14 | 427d |  | finish no earlier than 2001-03-21 | S4 | 3416h | 3416h |  | 26.235, 26.236 |  |  |  |
| 1467 | 81.6.2 | Transport protocols | 1d | 2002-03-12 A | 2002-03-12 A | 100% |  | 2002-03-12 | 2002-03-12 | 1d |  | finish no earlier than 2002-03-12 | S4 | 8h | 8h | IMS-CODEC | 26.236 | Nokia | P. Ojala | Rel-5 |
| 1468 | 81.6.4 | recommendation for QoS parameter values for various media types | 195d | 2001-12-31 A | 2002-09-27 A | 100% |  | 2001-12-31 | 2002-09-27 | 195d |  | finish no earlier than 2002-09-27 | S4 | 1560h | 1560h |  |  |  |  |  |
| 1469 | 81.6.5 | IETF: RFC 3310 (HTTP Digest Authentication using AKA) | 382d | 2000-11-24 A | 2002-05-13 A | 100% |  | 2000-11-24 | 2002-05-13 | 382d |  | finish no earlier than 2002-05-13 | N1 | 3056h | 3056h |  |  |  |  |  |
| 1470 | 81.6.6 | IETF: RFC 3329 (Security mechanism agreement for SIP connections) | 382d | 2000-11-24 A | 2002-05-13 A | 100% |  | 2000-11-24 | 2002-05-13 | 382d |  | finish no earlier than 2002-05-13 | N1 | 3056h | 3056h |  |  |  |  |  |
| 1471 | 81.7 | **SIP message compression** | 185d | 2001-09-24 A | 2002-06-07 A | 100% |  | 2001-09-24 | 2002-06-07 | 185d |  |  | S2 | 3128h | 3128h |  |  |  |  | Rel-5 |
| 1472 | 81.7.1 | Stage 2 | 25d | 2001-09-24 A | 2001-10-26 A | 100% |  | 2001-09-24 | 2001-10-26 | 25d |  | finish no earlier than 2001-10-26 | S2 | 200h | 200h |  |  |  |  |  |
| 1473 | 81.7.2 | Compression signalling | 181d | 2001-09-28 A | 2002-06-07 A | 100% |  | 2001-09-28 | 2002-06-07 | 181d |  | finish no earlier than 2002-06-07 | N1 | 1448h | 1448h |  |  |  |  |  |
| 1474 | 81.8 | **Stage 3 description of IMS interfaces** | 383d | 2001-03-14 A | 2002-08-30 | 99% | 4.93d | 2001-03-14 | 2002-08-30 | 383d | 1965d |  | NP | 29531.6h | 29151.4h |  |  |  |  | Rel-5 |
| 1475 | 81.8.1 | Cx interface (HSS to CSCF) | 135.95d | 2001-03-14 A | 2002-06-07 A | 100% |  | 2001-03-14 | 2002-06-07 | 135.95d |  | finish no earlier than 2002-06-07 | N4 | 1087.58h | 1087.58h |  |  |  |  |  |
| 1476 | 81.8.2 | Mp interface (MRFC - MRFP) enhancements | 258d | 2001-03-14 A | 2002-03-08 A | 100% |  | 2001-03-14 | 2002-03-08 | 258d |  | finish no earlier than 2002-06-07 | N4 | 2064h | 2064h |  |  |  |  |  |
| 1477 | 81.8.3 | Mw interface (CSCF to P-CSCF) | 323d | 2001-03-14 A | 2002-06-07 A | 100% |  | 2001-03-14 | 2002-06-07 | 323d |  | finish no earlier than 2002-06-07 | N1 | 2584h | 2584h |  |  |  |  |  |
| 1478 | 81.8.4 | Mr interface (CSCF to MRF) | 273d | 2001-03-14 A | 2002-03-29 A | 100% |  | 2001-03-14 | 2002-03-29 | 273d |  | finish no earlier than 2002-03-29 | N1 | 2184h | 2184h |  |  |  |  |  |
| 1479 | 81.8.5 | Dx interface (I-CSCF to SLF) | 323d | 2001-03-14 A | 2002-06-07 A | 100% |  | 2001-03-14 | 2002-06-07 | 323d |  | finish no earlier than 2002-06-07 | N4 | 2584h | 2584h |  |  |  |  |  |
| 1480 | 81.8.6 | Go interface (GGSN to PCF) | 323d | 2001-03-14 A | 2002-06-07 A | 100% |  | 2001-03-14 | 2002-06-07 | 323d |  | finish no earlier than 2002-06-07 | N3 | 2584h | 2584h |  |  |  |  |  |
| 1481 | 81.8.7 | ISC (IMS Service Control) Interface | 323d | 2001-03-14 A | 2002-06-07 A | 100% |  | 2001-03-14 | 2002-06-07 | 323d |  | finish no earlier than 2002-06-07 | N1 | 2584h | 2584h |  |  |  |  |  |
| 1482 | 81.8.8 | Sh interface (HSS to AS) | 82d | 2002-02-14 A | 2002-06-07 A | 100% |  | 2002-02-14 | 2002-06-07 | 82d |  | finish no earlier than 2002-06-07 | N4 | 656h | 656h |  |  |  |  |  |
| 1483 | 81.8.9 | Si interface (HSS to IM-SSF) | 162.5d | 2002-01-16 A | 2002-08-30 | 72% | 45d | 2002-01-16 | 2002-08-30 | 162.5d | 1965d | finish no earlier than 2002-06-07 | N4 | 1300h | 940h |  |  |  |  |  |
| 1484 | 81.8.10 | Gm interface (UE to CSCF) | 323d | 2001-03-14 A | 2002-06-07 A | 100% |  | 2001-03-14 | 2002-06-07 | 323d |  | finish no earlier than 2002-06-07 | N1 | 2584h | 2584h |  |  |  |  |  |
| 1485 | 81.8.11 | Mi interface (CSCF to BGCF) | 323d | 2001-03-14 A | 2002-06-07 A | 100% |  | 2001-03-14 | 2002-06-07 | 323d |  | finish no earlier than 2002-06-07 | N1 | 2584h | 2584h |  |  |  |  |  |
| 1486 | 81.8.12 | Mj interface (BGCF to MGCF) | 323d | 2001-03-14 A | 2002-06-07 A | 100% |  | 2001-03-14 | 2002-06-07 | 323d |  | finish no earlier than 2002-06-07 | N1 | 2584h | 2584h |  |  |  |  |  |
| 1487 | 81.8.13 | Mk interface (BGCF to BGCF) | 323d | 2001-03-14 A | 2002-06-07 A | 100% |  | 2001-03-14 | 2002-06-07 | 323d |  | finish no earlier than 2002-06-07 | N1 | 2584h | 2584h |  |  |  |  |  |
| 1488 | 81.9 | Support of VHE/OSA by entities and protocols of the IMS (e.g. CSCF) | 186d | 2001-09-21 A | 2002-06-07 A | 100% |  | 2001-09-21 | 2002-06-07 | 186d |  | finish no earlier than 2002-06-07 | N5 | 1488h | 1488h | IMS-ONOSA | 29.198, 29.998 | Ericsson | Ard.Jan.Moerdijk@eln.ericsson.se | Rel-5 |

Notes:
- 1475: DAB 12/12/01 to 75% / CN4 14/02/02 to 79% / 17th May work complete. 3GPP TSs 29.228 and 29.229 will be sent for proval in CN#16
- 1476: [DAB 08-03-02] - No work required in CN4
- 1479: CN4#11 30/11/01: No inputs received in CN4 / 14/02/02 Completed(introduced in 29.228)
- 1480: [DAB - 23/05/03] - 100 % complete
- 1482: CN4#11 30/11/01: No inputs received in CN4 / CN4#12bis 14/02/02: WID approved / 17th May 100% complete. 3GPP TS 29.329 will be sent for approval in CN#16
- 1483: SA16: Part of Rel5 only if completed in September 02

| ID | WBS | Task | Type | Duration | Start | Finish | Predecessors | Complete | Remaining | Baseline start | Baseline finish | Baseline duration | Total slack | Free slack | Constraint | Resources | Work | Actual work | Text1 | Text4 | Text5 | Text6 | Text3 | Text8 |
| --- | --- | --- | --- | --- | --- | --- | --- | --- | --- | --- | --- | --- | --- | --- | --- | --- | --- | --- | --- | --- | --- | --- | --- | --- |
| 1489 | 81.10 | **CAMEL control of IMS services** |  | 365d | 2001-04-16 A | 2002-09-06 |  | 91% | 34.05d | 2001-04-16 | 2002-09-06 | 365d | 1960d |  |  | N2 | 9952h | 9023.6h | IMS-CAMEL | Lucent | Angelica Remoquillo | Rel-5 |  |  |
| 1490 | 81.10.1 | Stage2 work 'general' |  | 365d | 2001-04-16 A | 2002-09-06 A |  | 100% |  | 2001-04-16 | 2002-09-06 | 365d |  |  | finish no earlier than 2002-09-06 | N2 | 2920h | 2920h |  |  |  |  |  |  |
| 1491 | 81.10.2 | Stage3 work 'CAP' |  | 175d | 2002-01-07 A | 2002-09-06 A |  | 100% |  | 2002-01-07 | 2002-09-06 | 175d |  |  | finish no earlier than 2002-09-06 | N2 | 1400h | 1400h |  |  |  |  |  |  |
| 1492 | 81.10.3 | Stage2 work 'Si interface' |  | 175d | 2002-01-07 A | 2002-09-06 A |  | 100% |  | 2002-01-07 | 2002-09-06 | 175d |  |  | finish no earlier than 2002-09-06 | N2 | 1400h | 1400h |  |  |  |  |  |  |
| 1493 | 81.10.4 | Stage3 work 'Si interface' |  | 82d | 2002-02-14 A | 2002-06-07 A |  | 100% |  | 2002-02-14 | 2002-06-07 | 82d |  |  | finish no earlier than 2002-06-07 | N4 | 656h | 656h |  |  |  |  |  |  |
| 1494 | 81.10.5 | SDM issues for CAMEL control of IMS |  | 82d | 2002-02-14 | 2002-06-07 |  |  |  | 2002-02-14 | 2002-06-07 | 82d | 2025d |  | finish no earlier than 2002-06-07 | N4 | 656h |  |  |  |  |  |  |  |
| 1495 | 81.11 | Pre-pay/real-time charging in IMS |  | 196d | 2001-06-15 A | 2002-03-15 |  | 60% | 78.4d | 2001-06-15 | 2002-03-15 | 196d | 2085d |  | finish no earlier than 2002-03-15 | S1 | 1568h | 940.8h |  |  |  | TBD |  |  |
| 1496 | 81.12 | **Charging** |  | 289d | 2001-08-06 A | 2002-09-12 A |  | 100% |  | 2001-08-06 | 2002-09-12 | 289d |  |  |  | S5 | 4624h | 4624h | OAM-CH | T-Mobile | karl-heinz.nenner@t-mobile.de | Rel-5 | 32.2xy |  |
| 1497 | 81.12.1 | Charging Implications of IMS architecture |  | 75d | 2001-08-06 A | 2001-11-16 A |  | 100% |  | 2001-08-06 | 2001-11-16 | 75d |  |  | finish no earlier than 2001-11-16 | S2 | 600h | 600h |  |  |  |  |  |  |
| 1498 | 81.12.2 | Charging management for IMS (off-line & on-line) |  | 214d | 2001-11-19 A | 2002-09-12 A | 1497 | 100% |  | 2001-11-19 | 2002-09-12 | 214d |  |  | finish no earlier than 2002-09-12 | S5 | 1712h | 1712h | OAM-CH |  |  | Rel-5 |  |  |
| 1499 | 81.13 | **Other IETF depencies** |  | 401d | 2000-11-24 A | 2002-06-07 |  | 70% | 120.3d | 2000-11-24 | 2002-06-07 | 401d | 2025d |  |  | NP | 9624h | 6736.8h |  |  |  | Rel-5 |  |  |
| 1500 | 81.13.1 | IETF: draft-ietf-aaa-diameter - should be CN4 |  | 401d | 2000-11-24 A | 2002-06-07 |  | 90% | 40.1d | 2000-11-24 | 2002-06-07 | 401d | 2025d |  | finish no earlier than 2002-06-07 | NP | 3208h | 2887.2h |  |  |  |  |  |  |
| 1501 | 81.13.2 | IETF: draft-johansson-aaa-diameter-mm-app - should be CN4 |  | 401d | 2000-11-24 A | 2002-06-07 |  | 50% | 200.5d | 2000-11-24 | 2002-06-07 | 401d | 2025d |  | finish no earlier than 2002-06-07 | NP | 3208h | 1604h |  |  |  |  |  |  |
| 1502 | 81.14 | Start Testing | milestone | 0d | 2002-03-18 | 2002-03-18 |  |  |  | 2002-03-18 | 2002-03-18 | 0d | 1880d | 0d | start no earlier than 2002-03-18 | MLST |  |  |  |  |  | Rel-5 |  |  |
| 1503 | 81.15 | Conformance Test Aspects - Provisioning of IMS |  | 205d | 2002-03-18 | 2002-12-27 | 1502 |  |  | 2002-03-18 | 2002-12-27 | 205d | 1880d |  | finish no earlier than 2002-12-27 | T1 | 1640h |  | IMS-TEST |  |  |  |  |  |
| 1504 | 81.16 | Testing of support for IMS - prose |  | 270d | 2002-09-18 | 2003-09-30 |  |  |  | 2002-09-18 | 2003-09-30 | 270d | 1683d |  | finish no earlier than 2003-09-30 | T1 | 2160h |  |  | Anritsu | dan.fox@eu.anritsu.com | Rel-5 | 34.108, 34.123 |  |
| 1505 | 81.17 | Testing of support for IMS - TTCN |  | 381d | 2002-09-18 | 2004-03-03 |  |  |  | 2002-09-18 | 2004-03-03 | 381d | 1572d |  | finish no earlier than 2004-03-03 | T1 | 3048h |  |  | Anritsu | dan.fox@eu.anritsu.com | Rel-5 | 34.108, 34.123 |  |
| 1506 | 82 | **Extended Transparent End-to-End PS Streaming Service** |  | 313d? | 2002-01-03 A | 2003-03-17 |  | 86% | 44.84d? | 2002-01-03 | 2003-03-17 | 313d? | 1824d |  |  | S4 | 6224h | 4687.32h | PSS-E | Ericsson | olle.franceschi@nrj.ericsson.se | Rel-5 | 26.233, 26.234 | Paolo |
| 1507 | 82.1 | **Stage 1** |  | 86d? | 2002-11-18 A | 2003-03-17 |  | 65% | 30.1d? | 2002-11-18 | 2003-03-17 | 86d? | 1824d |  |  | S1 | 1376h | 1015.2h |  | Vodafone | stephen.wolak@vodafone.com |  | 22.233 |  |
| 1508 | 1.388.1.1 | Interaction with other services |  | 86d? | 2002-11-18 A | 2003-03-17 |  | 65% | 30.1d? | 2002-11-18 | 2003-03-17 | 86d? | 1824d |  | finish no earlier than 2003-03-17 | S1 | 688h | 447.2h |  | Vodafone | stephen.wolak@vodafone.com |  | 22.233 |  |
| 1509 | 82.2 | Stage 2 (version Rel5 of TS 26.234) |  | 51d | 2002-01-03 A | 2002-03-14 A |  | 100% |  | 2002-01-03 | 2002-03-14 | 51d |  |  | finish no earlier than 2002-03-26 | S4 | 408h | 408h |  |  |  |  | 26.234 |  |
| 1510 | 82.3 | RTP usage model |  | 242d | 2002-01-03 A | 2002-12-06 |  | 90% | 24.2d | 2002-01-03 | 2002-12-06 | 242d | 1895d |  | finish no earlier than 2002-12-06 | S4 | 1936h | 1742.4h |  |  |  |  | 26.937 |  |
| 1511 | 83 | **Rel-5 OSA enhancements** |  | 639d | 2000-07-11 A | 2002-12-20 |  | 96% | 24.93d | 2000-07-11 | 2002-12-20 | 639d | 1885d |  |  | S1 | 62480h | 57172.1h | OSA1 | Siemens | Jörg Swetina | Rel-5 | 22.127, 23.127, 29.198-x, 29.998-x | Adrian |
| 1512 | 83.1 | General Stage 2 for Rel5 |  | 194d | 2001-09-11 A | 2002-06-07 |  | 47% | 103d | 2001-09-11 | 2002-06-07 | 194d | 2025d |  |  | S2 | 1232h | 408h |  |  |  | Rel-5 |  |  |

Notes:
- 1489: SA16: Part of Rel5 only if Si completed in September 02
- 1490: DAB 12.12.01 split into cn4 and cn2 parts
- 1491: DAB 12.12.01 split into cn4 and cn2 parts
- 1492: DAB 12.12.01 split into cn4 and cn2 parts
- 1493: [DAB 08-03-02] - UID 12004 is MASTER of UID 14998 / 17 May need to be recearch possible impact on 23.008 & 23.016, changes to 29.002 are done.
- 1494: [DAB 08-03-02] - No activity on this in CN4
- 1496: Changed Rapp email
- 1499: Was introduced at SA#13 by Ileana Leuca (exact position in the WP and related WG have to be defined)
- 1503: The task is a building block, individual work items are being considered but are constrained by lack of supporting companies
- 1507: 2nd resp SA4
- 1508: 2nd resp SA4
- 1509: 2nd resp SA2

| ID | WBS | Task | Duration | Start | Finish | Predecessors | Complete | Remaining | Baseline start | Baseline finish | Baseline duration | Total slack | Constraint | Resources | Work | Actual work | Text1 | Text6 | Text3 | Text4 | Text5 | Text8 |
| --- | --- | --- | --- | --- | --- | --- | --- | --- | --- | --- | --- | --- | --- | --- | --- | --- | --- | --- | --- | --- | --- | --- |
| 1513 | 83.2 | **OSA APIs for Multimedia Call Control** | 499d | 2000-07-11 A | 2002-06-07 A |  | 100% |  | 2000-07-11 | 2002-06-07 | 499d |  |  | S2 | 5960h | 5960h | OSA1-CSCF | Rel-5 |  |  |  |  |
| 1514 | 83.2.1 | Stage 1 | 438d | 2000-07-11 A | 2002-03-14 A |  | 100% |  | 2000-07-11 | 2002-03-14 | 438d |  | finish no earlier than 2002-03-14 | S1 | 3504h | 3504h |  |  | 22.127 | Siemens | Manfred.leitgeb@siemens.at | Michael |
| 1515 | 83.2.2 | (Multimedia) Call Control - Stages 2 and 3 | 194d | 2001-09-11 A | 2002-06-07 A |  | 100% |  | 2001-09-11 | 2002-06-07 | 194d |  | finish no earlier than 2002-06-07 | N5 | 1552h | 1552h |  |  | 29.198-04 |  |  |  |
| 1516 | 83.3 | Generic user interaction - Stage 3 | 194d | 2001-09-11 A | 2002-06-07 A |  | 100% |  | 2001-09-11 | 2002-06-07 | 194d |  | finish no earlier than 2002-06-07 | N5 | 1552h | 1552h |  | Rel-5 | 29.198-05 |  |  |  |
| 1517 | 83.4 | Charging - Stage 3 | 194d | 2001-09-11 A | 2002-06-07 A |  | 100% |  | 2001-09-11 | 2002-06-07 | 194d |  | finish no earlier than 2002-06-07 | N5 | 1552h | 1552h |  | Rel-5 | 29.198-12 |  |  |  |
| 1518 | 83.5 | Call Control Service Mapping; Multiparty Call Control SIP - Stage 3 | 194d | 2001-09-11 A | 2002-06-07 A |  | 100% |  | 2001-09-11 | 2002-06-07 | 194d |  | finish no earlier than 2002-06-07 | N5 | 1552h | 1552h |  | Rel-5 | 29.998-04-4 |  |  |  |
| 1519 | 83.6 | WSDL APIs for SOAP/HTTP - Stage 3 | 455d | 2000-09-11 A | 2002-06-07 A |  | 100% |  | 2000-09-11 | 2002-06-07 | 455d |  | finish no earlier than 2002-06-07 | N5 | 3640h | 3640h |  | Rel-5 | 29.198, 29.998 |  |  |  |
| 1520 | 83.7 | **OSA security** | 639d | 2000-07-11 A | 2002-12-20 |  | 93% | 44.46d | 2000-07-11 | 2002-12-20 | 639d | 1885d |  | S3 | 15000h | 13956.3h | OSA1-SEC | Rel-5 |  | BT | colin.blanchard@bt.com |  |
| 1521 | 83.7.1 | Stage 1 | 349d | 2000-07-11 A | 2001-11-09 A |  | 100% |  | 2000-07-11 | 2001-11-09 | 349d |  | finish no earlier than 2001-11-09 | S1 | 2792h | 2792h |  |  | 22.127 | Siemens | Manfred.leitgeb@siemens.at | Michael |
| 1522 | 83.7.2 | Stage 3 | 430d | 2000-10-23 A | 2002-06-14 |  | 80% | 86d | 2000-10-23 | 2002-06-14 | 430d | 2020d | finish no earlier than 2002-06-14 | S3 | 3440h | 2752h |  |  | ??? |  |  |  |
| 1523 | 83.7.3 | security related SCF(s) definition | 186d | 2001-09-21 A | 2002-06-07 A |  | 100% |  | 2001-09-21 | 2002-06-07 | 186d |  | finish no earlier than 2002-06-07 | N5 | 1488h | 1488h |  |  | 29.198, 29.998 | Ericsson | Ard.Jan.Moerdijk@eln.ericsson.se |  |
| 1524 | 83.7.4 | (possibly) changes required from supporting platforms, e.g. gsmSCF, HLR | 69d | 2000-09-11 A | 2000-12-14 A |  | 100% |  | 2000-09-11 | 2000-12-14 | 69d |  | finish no earlier than 2000-12-14 | S3 | 552h | 552h |  |  | ??? |  |  |  |
| 1525 | 1.389.7.5 | Security (moved from Rel-6) | 202d | 2002-03-14 A | 2002-12-20 A |  | 100% |  | 2002-03-14 | 2002-12-20 | 202d |  | finish no earlier than 2002-12-20 | S3 | 1616h | 1616h |  |  |  |  |  |  |
| 1526 | 83.8 | **Interactions OSA - e-commerce** | 499d | 2000-07-11 A | 2002-06-07 |  | 96% | 17.51d | 2000-07-11 | 2002-06-07 | 499d | 2025d |  | S2 | 6152h | 5976.8h | OSA1-ECOM | Rel-5 |  |  |  |  |
| 1527 | 83.8.1 | Stage 1 | 438d | 2000-07-11 A | 2002-03-14 |  | 95% | 21.9d | 2000-07-11 | 2002-03-14 | 438d | 2086d | finish no earlier than 2000-12-28 | S1 | 3504h | 3328.8h |  |  | 22.127 | Siemens | Jörg Swetina |  |
| 1528 | 83.8.2 | Stages 2 and 3 | 186d | 2001-09-21 A | 2002-06-07 A |  | 100% |  | 2001-09-21 | 2002-06-07 | 186d |  | finish no earlier than 2002-06-07 | N5 | 1488h | 1488h |  |  | 29.198, 29.998 | Ericsson | Ard.Jan.Moerdijk@eln.ericsson.se |  |
| 1529 | 83.9 | Policy Management - Stage 3 | 194d | 2001-09-11 A | 2002-06-07 A |  | 100% |  | 2001-09-11 | 2002-06-07 | 194d |  | finish no earlier than 2002-06-07 | N5 | 1552h | 1552h |  | Rel-5 | 29.198-13 |  |  |  |
| 1530 | 83.10 | Presence and Availability Management (PAM) - Stage 3 | 194d | 2001-09-11 A | 2002-06-07 A |  | 100% |  | 2001-09-11 | 2002-06-07 | 194d |  | finish no earlier than 2002-06-07 | N5 | 1552h | 1552h |  | Rel-5 | 29.198-14 |  |  |  |
| 1531 | 83.11 | **CHECK STATUS - LCS - OSA interfaces** | 455d | 2000-09-11 A | 2002-06-07 |  | 99% | 0d | 2000-09-11 | 2002-06-07 | 455d | 0d |  | S1 | 5656h | 2590.4h | OSA1-LCSI | Rel-5 |  | Siemens | Jörg Swetina |  |
| 1532 | 83.11.1 | Stage 1 | 65d | 2000-09-11 A | 2000-12-08 A |  | 100% |  | 2000-09-11 | 2000-12-08 | 65d |  | finish no earlier than 2000-12-08 | S1 | 520h | 520h |  |  | 22.127 | Siemens | Jörg Swetina |  |
| 1533 | 83.11.2 | Stage 2 | 1d | 2000-12-11 A | 2000-12-11 A | 1532 | 100% |  | 2000-12-11 | 2000-12-11 | 1d |  | finish no earlier than 2000-12-11 | S2 | 8h | 8h |  |  | 23.127 | Ericsson | Christophe GOURRAUD |  |
| 1534 | 83.11.3 | Stage 3 | 186d | 2001-09-21 A | 2002-06-07 A | 1533 | 100% |  | 2001-09-21 | 2002-06-07 | 186d |  | finish no earlier than 2002-06-07 | N5 | 1488h | 1488h |  |  | 29.198, 29.998 | Ericsson | Ard.Jan.Moerdijk@eln.ericsson.se |  |
| 1535 | 1.389.12 | Access to User Profile | 145d | 2001-06-01 A | 2001-12-20 A |  | 100% |  | 2001-06-01 | 2001-12-20 | 145d |  | finish no earlier than 2001-12-20 | S1 | 1160h | 1160h | OSA2-UP | Rel-5 |  |  |  |  |
| 1536 | 1.389.13 | **Retrieval of Terminal capabilities** | 634d | 2000-07-11 A | 2002-12-13 A |  | 100% |  | 2000-07-11 | 2002-12-13 | 634d |  |  | S2 | 10808h | 10808h | OSA2-TC | Rel-5 |  |  |  |  |
| 1537 | 1.389.13.1 | Stage 1 | 132d | 2000-07-11 A | 2001-01-10 A |  | 100% |  | 2000-07-11 | 2001-01-10 | 132d |  | finish no earlier than 2001-01-10 | S1 | 1056h | 1056h |  | Rel-5 | 22.127 | Siemens | Jörg Swetina |  |
| 1538 | 1.389.13.2 | Stages 2 and 3 | 321d | 2001-09-21 A | 2002-12-13 A | 1537 | 100% |  | 2001-09-21 | 2002-12-13 | 321d |  | finish no earlier than 2002-12-13 | N5 | 2568h | 2568h |  | Rel-5 | 29.198, 29.998 | Ericsson | Ard.Jan.Moerdijk@eln.ericsson.se |  |
| 1539 | 1.389.13.3 | Provisionning of the terminal capabilities | 445d | 2001-04-02 A | 2002-12-13 A |  | 100% |  | 2001-04-02 | 2002-12-13 | 445d |  | finish no earlier than 2002-12-13 | T2 | 3560h | 3560h |  | Rel-5 | 23.057 |  |  |  |

Notes:
- 1513: For Rel5 even if completed by March
- 1520: CR to correct security specifications in 29.198 scheduled for approval at CN#15
- 1522: ??
- 1525: Contribution at S3#25
- 1531: az: CN#13 - changed to Rel5
- 1533: az 24/05/01: Rel4 completion 90->100%.
- 1539: According to T2 SWG1 M. Cataldo this is automatically supported by the MExE support of UAProf therefore 100% complete

| ID | WBS | Task | Duration | Start | Finish | Predecessors | Complete | Remaining | Baseline start | Baseline finish | Baseline duration | Total slack | Constraint | Resources | Work | Actual work | Text1 | Text4 | Text5 | Text6 | Text8 | Text3 |
| --- | --- | --- | --- | --- | --- | --- | --- | --- | --- | --- | --- | --- | --- | --- | --- | --- | --- | --- | --- | --- | --- | --- |
| 1540 | 84 | **CAMEL phase 4** | 625d | 2000-04-17 A | 2002-09-06 |  | 99% | 0d | 2000-04-17 | 2002-09-06 | 625d | 0d |  | S1 | 41104h | 36244h | CAMEL4 | Nokia | keijo.palviainen@nokia.com | Rel-5 | Andrijana |  |
| 1541 | 84.1 | Service requirements | 565d | 2000-04-17 A | 2002-06-14 A |  | 100% |  | 2000-04-17 | 2002-06-14 | 565d |  | finish no earlier than 2002-06-14 | S1 | 4520h | 4520h |  |  |  |  |  |  |
| 1542 | 84.2 | Call Party Handling | 500d | 2000-07-10 A | 2002-06-07 A |  | 100% |  | 2000-07-10 | 2002-06-07 | 500d |  | finish no earlier than 2002-06-07 | N2 | 4000h | 4000h | CAMEL4-CPH |  |  |  |  |  |
| 1543 | 84.3 | Mid call procedure for MO and MT calls | 495d | 2000-07-17 A | 2002-06-07 A |  | 100% |  | 2000-07-17 | 2002-06-07 | 495d |  | finish no earlier than 2002-06-07 | N2 | 3960h | 3960h | CAMEL4-MCP |  |  |  |  |  |
| 1544 | 84.4 | Interactions with Optimal Routing | 430d | 2000-07-17 A | 2002-03-08 A |  | 100% |  | 2000-07-17 | 2002-03-08 | 430d |  | finish no earlier than 2002-03-08 | N2 | 3440h | 3440h | CAMEL4-IOR |  |  |  |  |  |
| 1545 | 84.5 | Inclusion of flexible tone injection | 430d | 2000-07-17 A | 2002-03-08 A |  | 100% |  | 2000-07-17 | 2002-03-08 | 430d |  | finish no earlier than 2002-03-08 | N2 | 3440h | 3440h | CAMEL4-IFTI |  |  |  |  |  |
| 1546 | 84.6 | CSE control over MT SMS | 430d | 2000-07-17 A | 2002-03-08 A |  | 100% |  | 2000-07-17 | 2002-03-08 | 430d |  | finish no earlier than 2002-03-08 | N2 | 3440h | 3440h | CAMEL4-CCSMS |  |  |  |  |  |
| 1547 | 84.7 | Notification of GPRS mobility management to CSE | 331d | 2001-03-02 A | 2002-06-07 A |  | 100% |  | 2001-03-02 | 2002-06-07 | 331d |  | finish no earlier than 2002-06-07 | N2 | 2648h | 2648h | CAMEL4-NMM |  |  |  |  |  |
| 1548 | 84.8 | Provision of location information of called subscriber | 266d | 2001-03-02 A | 2002-03-08 A |  | 100% |  | 2001-03-02 | 2002-03-08 | 266d |  | finish no earlier than 2002-03-08 | N2 | 2128h | 2128h | CAMEL4-LOCB |  |  |  |  |  |
| 1549 | 84.9 | Inclusion of ODB data in the CSE_HLR interface | 175d | 2001-07-09 A | 2002-03-08 A |  | 100% |  | 2001-07-09 | 2002-03-08 | 175d |  | finish no earlier than 2002-03-08 | N2 | 1400h | 1400h | CAMEL4-ODB |  |  |  |  |  |
| 1550 | 84.10 | Location information during an ongoing call (Handover DP) | 280d | 2001-05-14 A | 2002-06-07 A |  | 100% |  | 2001-05-14 | 2002-06-07 | 280d |  | finish no earlier than 2002-06-07 | N2 | 2240h | 2240h | CAMEL4-HODP |  |  |  |  |  |
| 1551 | 84.11 | GPRS Any Time Interrogation | 240d | 2001-07-09 A | 2002-06-07 A |  | 100% |  | 2001-07-09 | 2002-06-07 | 240d |  | finish no earlier than 2002-06-07 | N2 | 1920h | 1920h | CAMEL4-ATI |  |  |  |  |  |
| 1552 | 84.12 | Transfer of IMEI (with SW version) to CSE | 240d | 2001-07-09 A | 2002-06-07 A |  | 100% |  | 2001-07-09 | 2002-06-07 | 240d |  | finish no earlier than 2002-06-07 | N2 | 1920h | 1920h | CAMEL4-ATI |  |  |  |  |  |
| 1553 | 84.13 | Handling of partial implementations of CAMEL4 | 131d | 2002-03-08 A | 2002-09-06 A |  | 100% |  | 2002-03-08 | 2002-09-06 | 131d |  | finish no earlier than 2002-06-07 | N2 | 1048h | 1048h | CAMEL4-SUB |  |  |  |  |  |
| 1554 | 85 | **Rel-5 MExE enhancements** | 250d | 2001-03-26 A | 2002-03-08 A |  | 100% |  | 2001-03-26 | 2002-03-08 | 250d |  |  | T2 | 2880h | 2880h | MEXE5 |  |  | Rel-5 | Friedhelm |  |
| 1555 | 85.1 | MExE Rel-5 Improvements and Investigations | 110d | 2001-03-26 A | 2002-03-08 A |  | 100% |  | 2001-03-26 | 2002-03-08 | 110d |  | finish no earlier than 2001-12-17 | T2 | 880h | 880h | MEXE5-ENHANC | Motorola | Mark Cataldo (mcatald1@email.mot.com) |  |  | 22.057, 23.057 |
| 1556 | 86 | **Wideband Telephony Service - AMR** | 1035d | 2000-01-01 A | 2003-12-19 |  | 83% | 179.73d | 2000-01-01 | 2003-12-19 | 1035d | 1625d |  | S4 | 83992h | 65964.1h | AMRWB | Siemens | Imre.Varga@mch.siemens.de | Rel-5 | Paolo |  |
| 1557 | 86.1 | **Specification** | 704d | 2000-01-01 A | 2002-09-12 |  | 99% | 0.4d | 2000-01-01 | 2002-09-12 | 704d | 1956d |  | S4 | 22512h | 22482h |  |  |  | Rel-5 |  |  |
| 1558 | 86.1.1 | Stage 1 | 125d | 2001-10-01 A | 2002-03-22 A |  | 100% |  | 2001-10-01 | 2002-03-22 | 125d |  | finish no earlier than 2002-03-22 | S1 | 1000h | 1000h |  |  |  | Rel-5 |  |  |
| 1559 | 86.1.2 | **Stage 2** | 76d | 2000-01-03 A | 2000-04-17 A |  | 100% |  | 2000-01-03 | 2000-04-17 | 76d |  |  | S4 | 1224h | 1224h |  |  |  | Rel-5 |  |  |
| 1560 | 86.1.2.1 | Design Constraints | 26d | 2000-01-03 A | 2000-02-07 A |  | 100% |  | 2000-01-03 | 2000-02-07 | 26d |  |  | S4 | 208h | 208h |  |  |  | Rel-5 |  |  |
| 1561 | 86.1.2.2 | General Description | 51d | 2000-02-07 A | 2000-04-17 A | 1560 | 100% |  | 2000-02-07 | 2000-04-17 | 51d |  | start no earlier than 2000-09-25 | S4 | 408h | 408h |  |  |  | Rel-5 |  |  |
| 1562 | 86.1.3 | Feasibility Study | 26d | 2000-04-28 A | 2000-06-02 A | 1561 | 100% |  | 2000-04-28 | 2000-06-02 | 26d |  | finish no earlier than 2000-06-02 | S4 | 208h | 208h |  |  |  | Rel-5 |  | 26.901 |
| 1563 | 86.1.4 | N1 Aspects | 66d | 2001-09-21 A | 2001-12-21 A |  | 100% |  | 2001-09-21 | 2001-12-21 | 66d |  | finish no earlier than 2001-12-21 | N1 | 528h | 528h |  |  |  | Rel-5 |  |  |
| 1564 | 86.1.5 | N4 work | 83d | 2002-02-13 A | 2002-06-07 A |  | 100% |  | 2002-02-13 | 2002-06-07 | 83d |  | finish no earlier than 2002-06-07 | N4 | 664h | 664h |  |  |  | Rel-5 |  |  |

Notes:
- 1549: Added on May 29, 2001
- 1553: stage2 and stage3 CRs for approval at CN#17
- 1562: S4,TD SP-000024: TR 26.901 v.4.0.0
- 1563: Some of N1 tasks: Indication of supported codecs by the MS, Bearer cap negociation, codec indication to MS... / One common set of codec negotiation procedures will be specified as in ID1657.
- 1564: CN4#11 30/11/01: No inputs to CN4 at this meeting / 14/02/02 work started 50% reached / 17 May work is done 100%

| ID | WBS | Task | Type | Duration | Start | Finish | Predecessors | Complete | Remaining | Baseline start | Baseline finish | Baseline duration | Total slack | Constraint | Resources | Work | Actual work | Text6 | Text1 | Text3 | Text4 | Text5 | Text8 |
| --- | --- | --- | --- | --- | --- | --- | --- | --- | --- | --- | --- | --- | --- | --- | --- | --- | --- | --- | --- | --- | --- | --- | --- |
| 1565 | 86.1.6 | **Codec issues** |  | 704d | 2000-01-03 A | 2002-09-12 |  | 99% | 0.54d | 2000-01-03 | 2002-09-12 | 704d | 1956d |  | S4 | 11504h | 11496h | Rel-5 |  |  |  |  |  |
| 1566 | 86.1.6.1 | Codec qualification |  | 86d | 2000-02-01 A | 2000-05-30 A |  | 100% |  | 2000-02-01 | 2000-05-30 | 86d |  | finish no earlier than 2000-05-31 | S4 | 688h | 688h | Rel-5 |  |  |  |  |  |
| 1567 | 86.1.6.2 | Codec selection tests |  | 102d | 2000-06-01 A | 2000-10-20 A | 1566 | 100% |  | 2000-06-01 | 2000-10-20 | 102d |  | finish no earlier than 2000-10-20 | S4 | 816h | 816h | Rel-5 |  |  |  |  |  |
| 1568 | 86.1.6.3 | Codec selection |  | 5d | 2000-10-23 A | 2000-10-27 A | 1567 | 100% |  | 2000-10-23 | 2000-10-27 | 5d |  | finish no earlier than 2000-10-27 | S4 | 40h | 40h | Rel-5 |  |  |  |  |  |
| 1569 | 86.1.6.4 | TFO AMR-WB |  | 63d | 2001-12-18 A | 2002-03-14 A |  | 100% |  | 2001-12-18 | 2002-03-14 | 63d |  | finish no earlier than 2002-03-14 | S4 | 504h | 504h | Rel-5 | AMRWB-TFO |  |  |  |  |
| 1570 | 86.1.6.5 | Other codec issues (verif., caracterisation) |  | 441d | 2000-09-29 A | 2002-06-07 A |  | 100% |  | 2000-09-29 | 2002-06-07 | 441d |  | finish no earlier than 2002-06-07 | S4 | 3528h | 3528h | Rel-5 |  | 26.976 |  |  |  |
| 1571 | 86.1.6.6 | AMR-WB and narrrowband interworking |  | 121d | 2001-09-27 A | 2002-03-14 A |  | 100% |  | 2001-09-27 | 2002-03-14 | 121d |  | finish no earlier than 2002-03-14 | S4 | 968h | 968h | Rel-5 | AMRWB-IWG |  |  |  |  |
| 1572 | 86.1.6.7 | Interworking with fixed broadband networks |  | 121d | 2001-09-27 A | 2002-03-14 A |  | 100% |  | 2001-09-27 | 2002-03-14 | 121d |  | finish no earlier than 2002-03-14 | S4 | 968h | 968h | Rel-5 |  |  |  |  |  |
| 1573 | 86.1.6.8 | Tones and announcements |  | 121d | 2001-09-27 A | 2002-03-14 A |  | 100% |  | 2001-09-27 | 2002-03-14 | 121d |  | finish no earlier than 2002-03-14 | S4 | 968h | 968h | Rel-5 |  |  |  |  |  |
| 1574 | 86.1.6.9 | WB Conferencing and WB Voice Group calls (deleted) |  | 1d | 2000-01-03 | 2000-01-03 |  |  |  | 2000-01-03 | 2000-01-03 | 1d | 2659d | finish no earlier than 2000-01-03 | S1 | 8h |  | Rel-5 |  |  |  |  |  |
| 1575 | 86.1.6.10 | Billing, accounting and call detail record aspects |  | 251d | 2001-09-27 A | 2002-09-12 A |  | 100% |  | 2001-09-27 | 2002-09-12 | 251d |  | finish no earlier than 2002-09-12 | S5 | 2008h | 2008h | Rel-5 |  | 32.2xy | T-Mobile | Karl-Heinz.Nenner@T-MOBILE.DE |  |
| 1576 | 86.1.7 | Start Testing | milestone | 0d | 2002-02-25 | 2002-02-25 |  |  |  | 2002-02-25 | 2002-02-25 | 0d | 2100d | start no earlier than 2002-02-25 | MLST |  |  | Rel-5 |  |  |  |  |  |
| 1577 | 86.1.8 | **Conformance tests (CRs to 34 series)** |  | 73d | 2000-01-01 A | 2000-04-12 A | 1576 | 100% |  | 2000-01-01 | 2000-04-12 | 73d |  |  | T1 | 1752h | 1752h | Rel-5 |  |  |  |  |  |
| 1578 | 86.1.8.1 | **Terminal Acoustic Characteristics** |  | 73d | 2000-01-01 A | 2000-04-12 A |  | 100% |  | 2000-01-01 | 2000-04-12 | 73d |  |  | S4 | 1168h | 1168h | Rel-5 |  |  |  |  |  |
| 1579 | 86.1.8.1.1 | Definition |  | 21d | 2000-01-01 A | 2000-01-31 A |  | 100% |  | 2000-01-01 | 2000-01-31 | 21d |  | finish no earlier than 2000-01-28 | S4 | 168h | 168h | Rel-5 |  | 26.131 |  |  |  |
| 1580 | 86.1.8.1.2 | Test specification |  | 52d | 2000-02-01 A | 2000-04-12 A | 1579 | 100% |  | 2000-02-01 | 2000-04-12 | 52d |  | finish no earlier than 2000-03-13 | S4 | 416h | 416h | Rel-5 |  | 26.132 |  |  |  |
| 1581 | 86.2 | Floating-point ANSI-C code for the AMR-WB speech codec |  | 123d | 2001-09-25 A | 2002-03-14 A |  | 100% |  | 2001-09-25 | 2002-03-14 | 123d |  | finish no earlier than 2002-03-14 | S4 | 984h | 984h | Rel-5 | AMRWB-FP | 26.204 | Nokia | janne.m.vainio@nokia.com |  |
| 1582 | 86.3 | **Support of AMR-WB in GERAN: GMSK and 8PSK WB FR / HR** |  | 650d | 2000-01-03 A | 2002-06-28 A |  | 100% |  | 2000-01-03 | 2002-06-28 | 650d |  |  | GP | 23480h | 23480h | Rel-5 | GAMRWB |  |  |  | Paolo |
| 1583 | 86.3.1 | Channel coding in 45.003 |  | 590d | 2000-01-03 A | 2002-04-05 A |  | 100% |  | 2000-01-03 | 2002-04-05 | 590d |  |  | GP | 4720h | 4720h | Rel-5 |  |  |  |  |  |
| 1584 | 86.3.2 | Signalling for the A interface |  | 390d | 2000-01-03 A | 2001-06-29 A |  | 100% |  | 2000-01-03 | 2001-06-29 | 390d |  | finish no earlier than 2001-06-29 | GP | 3120h | 3120h | Rel-5 |  |  |  |  |  |
| 1585 | 86.3.3 | Signalling for Iu |  | 650d | 2000-01-03 A | 2002-06-28 A |  | 100% |  | 2000-01-03 | 2002-06-28 | 650d |  | finish no earlier than 2002-06-28 | GP | 5200h | 5200h | Rel-5 |  |  |  |  |  |
| 1586 | 86.3.4 | Receiver performance in TS 45.005 |  | 325d | 2001-04-02 A | 2002-06-28 A |  | 100% |  | 2001-04-02 | 2002-06-28 | 325d |  | finish no earlier than 2002-06-28 | GP | 2600h | 2600h | Rel-5 |  |  |  |  |  |
| 1587 | 86.3.5 | Link Adaptation in 45.009 |  | 330d | 2001-03-26 A | 2002-06-28 A |  | 100% |  | 2001-03-26 | 2002-06-28 | 330d |  | finish no earlier than 2002-06-28 | GP | 2640h | 2640h | Rel-5 |  |  |  |  |  |
| 1588 | 86.4 | **GERAN MS conformance test for AMR-WB** |  | 1035d | 2000-01-03 | 2003-12-19 |  |  |  | 2000-01-03 | 2003-12-19 | 1035d | 1625d |  | GP | 16560h |  | Rel-5 |  |  |  |  | Paolo |
| 1589 | 86.4.1 | MS test |  | 1035d | 2000-01-03 | 2003-12-19 |  |  |  | 2000-01-03 | 2003-12-19 | 1035d | 1625d | finish no earlier than 2003-12-19 | GP | 8280h |  | Rel-5 |  |  |  |  |  |

Notes:
- 1570: ANSI C-Code , Test Sequences, Speech Transcoding Functions, Error Concealment of lost frames, Source Controlled Bit-Rate Operation, Voice Activity Detector, Frame Structure
- 1583: 50098 -> 50298
- 1588: Not started

| ID | WBS | Task | Duration | Start | Finish | Complete | Remaining | Baseline start | Baseline finish | Baseline duration | Total slack | Constraint | Resources | Work | Actual work | Text6 | Text8 | Text1 | Text3 | Text4 | Text5 |
| --- | --- | --- | --- | --- | --- | --- | --- | --- | --- | --- | --- | --- | --- | --- | --- | --- | --- | --- | --- | --- | --- |
| 1590 | 86.5 | **GERAN BTS conformance test for AMR-WB** | 761d | 2000-01-03 A | 2002-12-02 A | 100% |  | 2000-01-03 | 2002-12-02 | 761d |  |  | GP | 12176h | 12176h | Rel-5 | Paolo |  |  |  |  |
| 1591 | 86.5.1 | BTS test | 761d | 2000-01-03 A | 2002-12-02 A | 100% |  | 2000-01-03 | 2002-12-02 | 761d |  | finish no earlier than 2002-12-02 | GP | 6088h | 6088h | Rel-5 |  |  |  |  |  |
| 1592 | 11 | **Terminal interfaces** | 223d | 2001-05-14 A | 2002-03-20 A | 100% |  | 2001-05-14 | 2002-03-20 | 223d |  |  | T2 | 3568h | 3568h | Rel-5 | Friedhelm | TI |  |  |  |
| 1593 | 87 | Terminal local model enhancements | 223d | 2001-05-14 A | 2002-03-20 A | 100% |  | 2001-05-14 | 2002-03-20 | 223d |  | finish no earlier than 2002-03-20 | T2 | 1784h | 1784h | Rel-5 |  | TLM5 | 23.227 |  |  |
| 1594 | 88 | **Rel-5 Location Services enhancements** | 845d | 2000-04-03 A | 2003-06-27 | 81% | 162.63d | 2000-04-03 | 2003-06-27 | 845d | 1750d |  | S2 | 174419h | 151268h | Rel-5 | Alain | LCS1 |  | Nokia | Jan Kall |
| 1595 | 88.1 | **UE positioning** | 315d | 2001-01-15 A | 2002-03-29 A | 100% |  | 2001-01-15 | 2002-03-29 | 315d |  |  | RP | 5560h | 5560h | NA |  | LCS1-UEpos |  |  |  |
| 1596 | 88.1.1 | UE positioning enhancements for 1.28 Mcps TDD | 255d | 2001-04-09 A | 2002-03-29 A | 100% |  | 2001-04-09 | 2002-03-29 | 255d |  | finish no earlier than 2002-03-29 | R2 | 2040h | 2040h | Rel-5 |  | LCS-128Pos |  | CATT | Xiaohua Mei |
| 1597 | 88.1.2 | Open SMLC-SRNC Interface within the UTRAN to support A-GPS Positioning | 195d | 2001-01-15 A | 2001-10-12 A | 100% |  | 2001-01-15 | 2001-10-12 | 195d |  |  | R2 | 1560h | 1560h | Rel-5 |  | LCS-INTF |  | Qualcomm | Kirk Burroughs |
| 1598 | 88.2 | **Event based and Periodic LCS** | 535d | 2000-05-22 A | 2002-06-07 | 88% | 62.67d | 2000-05-22 | 2002-06-07 | 535d | 2025d |  | S1 | 6288h | 5551.48h | Rel-5 |  | LCS1-EBP |  |  |  |
| 1599 | 88.2.1 | Stage 1 | 130d | 2000-05-22 A | 2000-11-17 A | 100% |  | 2000-05-22 | 2000-11-17 | 130d |  | finish no earlier than 2000-07-21 | S1 | 1040h | 1040h |  |  |  | 22.071 | Pacific Bell Wireless | Randolph Wohlert (rwohlert@tri.sbc.com) |
| 1600 | 88.2.2 | Stage 2 specification | 60d | 2000-11-06 A | 2001-01-26 | 51% | 29.4d | 2000-11-06 | 2001-01-26 | 60d | 2380d | finish no earlier than 2001-01-26 | S2 | 480h | 244.8h |  |  |  |  |  |  |
| 1601 | 88.2.3 | Impact on MAP | 61d | 2002-03-15 A | 2002-06-07 A | 100% |  | 2002-03-15 | 2002-06-07 | 61d |  | finish no earlier than 2002-06-07 | N4 | 488h | 488h |  |  |  |  |  |  |
| 1602 | 88.3 | **Location Services for GERAN in A/Gb Mode** | 485d | 2000-04-03 A | 2002-02-08 A | 100% |  | 2000-04-03 | 2002-02-08 | 485d |  |  | GP | 24032h | 24032h | Rel-5 | Paolo | LCS-GERAN |  |  |  |
| 1603 | 88.3.1 | GERAN LCS Stage 2 (first release) | 485d | 2000-04-03 A | 2002-02-08 A | 100% |  | 2000-04-03 | 2002-02-08 | 485d |  | finish no earlier than 2002-02-08 | GP; S2; G1; G2 | 13152h | 13152h |  |  |  |  |  |  |
| 1604 | 88.3.2 | Gb interface support for LCS | 370d | 2000-04-03 A | 2001-08-31 A | 100% |  | 2000-04-03 | 2001-08-31 | 370d |  | finish no earlier than 2001-08-31 | GP | 2960h | 2960h |  |  |  |  |  |  |
| 1605 | 88.3.3 | L3 protocol support for LCS | 305d | 2000-04-03 A | 2001-06-01 A | 100% |  | 2000-04-03 | 2001-06-01 | 305d |  | finish no earlier than 2001-06-01 | GP | 2440h | 2440h |  |  |  |  |  |  |
| 1606 | 88.3.4 | Stage 3 specifications | 305d | 2000-04-03 A | 2001-06-01 A | 100% |  | 2000-04-03 | 2001-06-01 | 305d |  | finish no earlier than 2001-06-01 | GP | 2440h | 2440h |  |  |  |  |  |  |
| 1607 | 88.4 | **Location Services for GERAN in Iu Mode** | 585d | 2000-04-03 A | 2002-06-28 A | 100% |  | 2000-04-03 | 2002-06-28 | 585d |  |  | GP | 78498.7h | 78498.7h | Rel-5 | Paolo |  |  |  |  |
| 1608 | 88.4.1 | GERAN LCS Stage 2 | 585d | 2000-04-03 A | 2002-06-28 A | 100% |  | 2000-04-03 | 2002-06-28 | 585d |  | finish no earlier than 2002-06-28 | GP; R2; R3; S2; G1; G2 | 22880.9h | 22880.9h |  |  |  |  |  |  |
| 1609 | 88.4.2 | Iu-ps interface support for LCS | 585d | 2000-04-03 A | 2002-06-28 A | 100% |  | 2000-04-03 | 2002-06-28 | 585d |  | finish no earlier than 2002-06-28 | GP; R2; R3; S2; G1; G2 | 19000.9h | 19000.9h |  |  |  |  |  |  |
| 1610 | 88.4.3 | Iu-cs interface support for LCS | 585d | 2000-04-03 A | 2002-06-28 A | 100% |  | 2000-04-03 | 2002-06-28 | 585d |  | finish no earlier than 2002-06-28 | GP; R2; R3; S2; G1; G2 | 19000.9h | 19000.9h |  |  |  |  |  |  |
| 1611 | 88.4.4 | Iur-g interface support for LCS | 62.5d | 2002-01-23 A | 2002-04-19 A | 100% |  | 2002-01-23 | 2002-04-19 | 62.5d |  | finish no earlier than 2002-04-19 | GP; R2; R3; S2; G1; G2 | 3000h | 3000h |  |  |  |  |  |  |
| 1612 | 88.4.5 | RRC protocol support for LCS | 75d | 2001-08-20 A | 2001-11-30 A | 100% |  | 2001-08-20 | 2001-11-30 | 75d |  | finish no earlier than 2001-11-30 | GP; R2; R3; S2; G1; G2 | 3600h | 3600h |  |  |  |  |  |  |
| 1613 | 88.4.6 | Additional impacts on Broadcast of LCS data on packet channels | 77.5d | 2001-08-20 A | 2001-12-05 A | 100% |  | 2001-08-20 | 2001-12-05 | 77.5d |  | finish no earlier than 2001-12-05 | GP; R2; R3; S2; G1; G2 | 3000h | 3000h |  |  |  |  |  |  |
| 1614 | 88.4.7 | Stage 3 specifications | 69.5d | 2002-03-25 A | 2002-06-28 A | 100% |  | 2002-03-25 | 2002-06-28 | 69.5d |  | finish no earlier than 2002-06-28 | GP; R2; R3; S2; G1; G2 | 3336h | 3336h |  |  |  |  |  |  |

Notes:
- 1597: Finished at RP#13
- 1599: Evaluate Event based and Periodic LCS to be included in R00, corresponding Stage 1 description
- 1601: Possible impact on UTRAN of LCS quality level request / 17 May No stage 2 for event-based & periodic LCS. Work 100% completefor current stage 2
- 1611: FFS

| ID | WBS | Task | Duration | Start | Finish | Predecessors | Complete | Remaining | Baseline start | Baseline finish | Baseline duration | Total slack | Constraint | Resources | Work | Actual work | Text1 | Text6 | Text8 | Text3 | Text4 | Text5 |
| --- | --- | --- | --- | --- | --- | --- | --- | --- | --- | --- | --- | --- | --- | --- | --- | --- | --- | --- | --- | --- | --- | --- |
| 1615 | 88.5 | **GERAN MS Conformance test for LCS** | 280d | 2002-06-03 A | 2003-06-27 |  | 60% | 112d | 2002-06-03 | 2003-06-27 | 280d | 1750d |  | GP | 11200h | 6720h | LCS-GERAN-MSconf |  |  |  |  |  |
| 1616 | 88.5.1 | Develop LCS MS test case work plan (Release 98/99/4) | 280d | 2002-06-03 A | 2003-06-27 |  | 60% | 112d | 2002-06-03 | 2003-06-27 | 280d | 1750d | finish no earlier than 2003-06-27 | G4; G5 | 4480h | 2688h |  |  |  |  |  |  |
| 1617 | 88.5.2 | Develop LCS MS test cases | 280d | 2002-06-03 A | 2003-06-27 |  | 60% | 112d | 2002-06-03 | 2003-06-27 | 280d | 1750d | finish no earlier than 2003-06-27 | G4; G5 | 4480h | 2688h |  |  |  |  |  |  |
| 1618 | 88.6 | **GERAN BTS Conformance test for LCS** | 280d | 2002-06-03 | 2003-06-27 |  |  |  | 2002-06-03 | 2003-06-27 | 280d | 1750d |  | GP | 11200h |  | LCS-GERAN-BTSconf |  |  |  |  |  |
| 1619 | 88.6.1 | Develop LCS BTS test case work plan (Release 98/99/4) | 280d | 2002-06-03 | 2003-06-27 |  |  |  | 2002-06-03 | 2003-06-27 | 280d | 1750d | finish no earlier than 2003-06-27 | G4; G5 | 4480h |  |  |  |  |  |  |  |
| 1620 | 88.6.2 | Develop LCS BTS test cases | 280d | 2002-06-03 | 2003-06-27 |  |  |  | 2002-06-03 | 2003-06-27 | 280d | 1750d | finish no earlier than 2003-06-27 | G4; G5 | 4480h |  |  |  |  |  |  |  |
| 1621 | 88.7 | LCS interoperation stage 2 aspects | 480d | 2000-08-28 A | 2002-06-28 |  | 17% | 400.8d | 2000-08-28 | 2002-06-28 | 480d | 2010d |  | S2 | 3840h | 633.6h |  |  |  |  |  |  |
| 1622 | 88.8 | **LCS interoperability aspects to GERAN** | 480d | 2000-08-28 A | 2002-06-28 A |  | 100% |  | 2000-08-28 | 2002-06-28 | 480d |  |  | GP | 19632h | 19632h | LCS-GERAN | Rel-5 | Paolo |  |  |  |
| 1623 | 88.8.1 | Co-ordinated development of GSM LCS Phase 2 and UMTS LCS, S2 and GERAN | 480d | 2000-08-28 A | 2002-06-28 A |  | 100% |  | 2000-08-28 | 2002-06-28 | 480d |  | finish no earlier than 2002-06-28 | GP; S2; S5; R2; R3; G2; G1 | 15792h | 15792h | LCS-GERAN |  |  |  |  |  |
| 1624 | 88.9 | FS on LCS support in the IMS | 90d | 2001-02-12 A | 2002-01-18 |  | 75% | 22.5d | 2001-02-12 | 2002-01-18 | 90d | 2125d | start no earlier than 2001-02-12 | S1 | 720h | 540h |  |  |  |  |  |  |
| 1625 | 88.10 | Charging and OAM&P for LCS enhancements | 201d | 2001-09-21 A | 2002-06-28 A |  | 100% |  | 2001-09-21 | 2002-06-28 | 201d |  | finish no earlier than 2002-06-28 | S5 | 1608h | 1608h | LCS1-OAM | Rel-5 |  | 32-series | VoiceStream, Motorola | Albert.Yuhan@voicestream.com; Michael.Truss@MOTOROLA.COM |
| 1626 | 88.11 | New security aspects of LCS (not identified) | 446d | 2000-04-14 A | 2001-12-28 A |  | 100% |  | 2000-04-14 | 2001-12-28 | 446d |  | finish no earlier than 2001-12-28 | S3 | 3568h | 3568h | LCS1-SEC | Rel-5 |  |  | Nokia | valtteri.niemi@nokia.com |
| 1627 | 88.12 | Specification for the Le Interface | 45d | 2002-01-14 A | 2002-03-15 A |  | 100% |  | 2002-01-14 | 2002-03-15 | 45d |  | start no earlier than 2002-01-14 | S2 | 360h | 360h | LCS1-Le | Rel-5 |  |  |  |  |
| 1628 | 88.13 | CHECK STATUS - Inter-GMLC interface | 153d | 2002-05-30 | 2002-12-30 |  |  |  | 2002-05-30 | 2002-12-30 | 153d | 1879d | finish no earlier than 2002-12-30 | S2 | 1224h |  |  |  |  |  |  |  |
| 1629 | 89 | **Rel-5 Security enhancements** | 615d | 2000-02-21 A | 2002-06-28 |  | 99% | 4.24d | 2000-02-21 | 2002-06-28 | 615d | 2010d |  | S3 | 29974.9h | 28371.3h | SEC1 | Rel-5 | Maurice |  | Vodafone | Peter.Howard@vodafone.com |
| 1630 | 89.1 | **Network domain security** | 615d | 2000-02-21 A | 2002-06-28 |  | 99% | 4.24d | 2000-02-21 | 2002-06-28 | 615d | 2010d |  | S3 | 25054.9h | 23451.3h | SEC1-NDS | Rel-5 |  |  | Telenor | Geir-myrdahl.koien@telenor.com |
| 1631 | 89.1.1 | **Control plane protection in core network (e.g., GTP, CAP, MAP/IP, provided by IPsec)** | 541d | 2000-05-12 A | 2002-06-07 |  | 99% | 0d | 2000-05-12 | 2002-06-07 | 541d | 0d |  | S3 | 7118.9h | 5722.98h |  |  |  |  |  |  |
| 1632 | 89.1.1.1 | Main aspects | 290d | 2000-05-12 A | 2001-06-21 A |  | 100% |  | 2000-05-12 | 2001-06-21 | 290d |  | finish no earlier than 2001-06-21 | S3 | 2320h | 2320h |  |  |  |  |  |  |
| 1633 | 89.1.1.2 | Integration of GTP signalling security architecture | 191d | 2001-09-14 A | 2002-06-07 A |  | 100% |  | 2001-09-14 | 2002-06-07 | 191d |  | finish no earlier than 2002-06-07 | N4 | 1528h | 1528h |  |  |  |  |  |  |
| 1634 | 89.1.2 | **User plane protection in core network (e.g., provided by IPsec)** | 615d | 2000-02-21 A | 2002-06-28 |  | 98% | 11.41d | 2000-02-21 | 2002-06-28 | 615d | 2010d |  | S3 | 9360.02h | 9186.3h |  |  |  |  |  |  |
| 1635 | 89.1.2.1 | Main aspects | 349d | 2000-02-21 A | 2001-06-21 A |  | 100% |  | 2000-02-21 | 2001-06-21 | 349d |  | finish no earlier than 2001-06-21 | S3 | 2792h | 2792h |  |  |  |  |  |  |
| 1636 | 89.1.2.2 | Integration of GTP signalling security architecture | 206d | 2001-09-14 A | 2002-06-28 |  | 95% | 10.3d | 2001-09-14 | 2002-06-28 | 206d | 2010d | finish no earlier than 2002-06-28 | N4 | 1648h | 1565.6h |  |  |  |  |  |  |
| 1637 | 89.1.3 | IP network layer security (NDS/IP) | 457d | 2000-06-15 A | 2002-03-15 A |  | 100% |  | 2000-06-15 | 2002-03-15 | 457d |  | finish no earlier than 2002-03-15 | S3 | 3656h | 3656h | SEC1-NDS-IP |  |  | 33.210 | Telenor | Geir-myrdahl.koien@telenor.com |
| 1638 | 90 | **Intra Domain Connection of RAN Nodes to Multiple CN Nodes** | 455d | 2000-10-02 A | 2002-06-28 A |  | 100% |  | 2000-10-02 | 2002-06-28 | 455d |  |  | S2 | 15136h | 15136h | IUFLEX | Rel-5 | Alain | 23.236 | Ericsson | Stephen Terrill |
| 1639 | 90.1 | Overall System Architecture | 188d | 2001-01-03 A | 2001-09-21 A |  | 100% |  | 2001-01-03 | 2001-09-21 | 188d |  | finish no earlier than 2001-06-01 | S2 | 1504h | 1504h |  |  |  |  |  |  |
| 1640 | 90.2 | Stage 3: RAN node selecting CN node | 130d | 2001-09-24 A | 2002-03-22 A | 1639 | 100% |  | 2001-09-24 | 2002-03-22 | 130d |  | finish no earlier than 2002-03-22 | R3 | 1040h | 1040h |  |  |  |  | Vodafone | Brendan McWilliams |
| 1641 | 90.3 | N1 work | 205d | 2001-09-17 A | 2002-06-28 A |  | 100% |  | 2001-09-17 | 2002-06-28 | 205d |  | start no earlier than 2001-09-17 | N1 | 1640h | 1640h |  |  |  | 24.008 and check 29.018 |  |  |
| 1642 | 90.4 | N4 work | 375d | 2000-10-02 A | 2002-03-08 A |  | 100% |  | 2000-10-02 | 2002-03-08 | 375d |  | finish no earlier than 2002-03-15 | N4 | 3000h | 3000h |  |  |  |  |  |  |

Notes:
- 1615: On-going
- 1618: Not started
- 1626: 14/09/00: End date 28/12/01 WI may need to be split to improve on this date. S3#17 15% complete. No progress since S3#17
- 1629: Added BB UE authentication and rapporteur added. TO BE DELETED
- 1630: S3#17: All due in Rel5. (WI Update at S3#18). Replaced by NDS-IP and NDS-MAP. TO BE DELETED OR MOVED TO HISTORY FILE
- 1632: TO BE DELETED
- 1633: Waiting for input from SA3! / 14/02/2002 requirements are not clear/not received / 17 May 100% complete
- 1634: TO BE DELETED
- 1635: ??
- 1636: 14/02/2002 requirements are not clear/not received
- 1637: TS 33.210 will be presented for info at SA#14 and is scheduled for approval at SA#15. 2002/12: All IPsec RFCs are stable STD Track RFCs. WID updated SA#17
- 1638: No clear indication on the end date. Put to Rel5 by AS.
- 1640: Not identified
- 1642: DAB 12.12.01 - % complete to 66% / 14/02/02 Work completed

| ID | WBS | Task | Duration | Start | Finish | Complete | Baseline start | Baseline finish | Baseline duration | Total slack | Constraint | Resources | Work | Actual work | Text1 | Text4 | Text5 | Text6 | Text8 | Text3 |
| --- | --- | --- | --- | --- | --- | --- | --- | --- | --- | --- | --- | --- | --- | --- | --- | --- | --- | --- | --- | --- |
| 1643 | 90.5 | **GERAN work for Intra Domain Connection of RAN Nodes to Multiple CN Nodes** | 101d | 2002-02-08 A | 2002-06-28 A | 100% | 2002-02-08 | 2002-06-28 | 101d |  |  | GP | 4848h | 4848h | IDCRAN-GERAN | Ericsson | ingemar.backlund@era.ericsson.se | Rel-5 |  |  |
| 1644 | 90.5.1 | Stage 2 (changes to ) | 101d | 2002-02-08 A | 2002-06-28 A | 100% | 2002-02-08 | 2002-06-28 | 101d |  | finish no earlier than 2002-06-28 | G1 | 808h | 808h |  |  |  |  |  |  |
| 1645 | 90.5.2 | 43.051 Introduction of support for IDNNS in GERAN Iu mode | 101d | 2002-02-08 A | 2002-06-28 A | 100% | 2002-02-08 | 2002-06-28 | 101d |  | finish no earlier than 2002-06-28 | G1 | 808h | 808h |  |  |  |  |  |  |
| 1646 | 90.5.3 | Stage 3 (changes to ) | 101d | 2002-02-08 A | 2002-06-28 A | 100% | 2002-02-08 | 2002-06-28 | 101d |  | finish no earlier than 2002-06-28 | G2 | 808h | 808h |  |  |  |  |  |  |
| 1647 | 90.5.4 | 48.016 Use of Gb interface concepts when a network applies IDNNS | 101d | 2002-02-08 A | 2002-06-28 A | 100% | 2002-02-08 | 2002-06-28 | 101d |  | finish no earlier than 2002-06-28 | G2 | 808h | 808h |  |  |  |  |  |  |
| 1648 | 90.5.5 | 48.018 Include MSC/VLR identity in CS IMSI paging | 101d | 2002-02-08 A | 2002-06-28 A | 100% | 2002-02-08 | 2002-06-28 | 101d |  | finish no earlier than 2002-06-28 | G2 | 808h | 808h |  |  |  |  |  |  |
| 1649 | 91 | **GERAN improvements 3 (new transport layer on interface A)** | 446d | 2001-04-06 | 2002-12-20 |  | 2001-04-06 | 2002-12-20 | 446d | 1885d |  | GP | 14272h |  | GEIMP3 |  |  | Rel-5 | Paolo |  |
| 1650 | 91.1 | **Evolution of the transport for A** | 446d | 2001-04-06 | 2002-12-20 |  | 2001-04-06 | 2002-12-20 | 446d | 1885d |  | GP | 10704h |  | GEIMP3-EtA |  |  |  | Paolo |  |
| 1651 | 91.1.1 | Definition of a new A/Ater interface Transport Layer option based on the Iu Interface Transport Layer | 446d | 2001-04-06 | 2002-12-20 |  | 2001-04-06 | 2002-12-20 | 446d | 1885d | finish no earlier than 2002-12-20 | GP | 3568h |  |  |  |  |  |  |  |
| 1652 | 91.1.2 | Adaptation of the Layer 3 BSSMAP procedures as required | 446d | 2001-04-06 | 2002-12-20 |  | 2001-04-06 | 2002-12-20 | 446d | 1885d | finish no earlier than 2002-12-20 | GP | 3568h |  |  |  |  |  |  |  |
| 1653 | 92 | **Rel-5 Charging and OAM&P** | 264d | 2001-09-10 A | 2002-09-12 A | 100% | 2001-09-10 | 2002-09-12 | 264d |  |  | S5 | 9976h | 9976h | OAM | VoiceStream, Motorola | Albert.Yuhan@voicestream.com; Michael.Truss@MOTOROLA.COM | Rel-5 | Adrian | 32-series |
| 1654 | 92.1 | Rel5 Principles, high level Requirements and Architecture | 205d | 2001-09-17 A | 2002-06-28 A | 100% | 2001-09-17 | 2002-06-28 | 205d |  | finish no earlier than 2002-06-28 | S5 | 1640h | 1640h | OAM-AR/PR | Motorola | Michael.Truss@MOTOROLA.COM | Rel-5 |  | 32.101, 32.102 |
| 1655 | 92.2 | Rel5 Performance Management | 259d | 2001-09-17 A | 2002-09-12 A | 100% | 2001-09-17 | 2002-09-12 | 259d |  | finish no earlier than 2002-09-12 | S5 | 2072h | 2072h | OAM-PM | Nortel | toche@NORTELNETWORKS.COM | Rel-5 |  | 32.4xy, 52.402 |
| 1656 | 92.3 | Rel5 Charging Management | 264d | 2001-09-10 A | 2002-09-12 A | 100% | 2001-09-10 | 2002-09-12 | 264d |  | finish no earlier than 2002-09-12 | S5 | 2112h | 2112h | OAM-CH | T-Mobile | Karl-Heinz.Nenner@T-MOBILE.DE | Rel-5 |  | 32.2xy |
| 1657 | 92.4 | Rel5 Network Infrastructure Management | 255d | 2001-09-21 A | 2002-09-12 A | 100% | 2001-09-21 | 2002-09-12 | 255d |  | finish no earlier than 2002-09-12 | S5 | 2040h | 2040h | OAM-NIM | Ericsson | Thomas.Tovinger@emw.ericsson.se | Rel-5 |  | 32.6xy, 32.3xy |
| 1658 | 93 | **GERAN enhancements for streaming services 1 (RLC enhancements)** | 430d | 2000-11-06 A | 2002-06-28 A | 100% | 2000-11-06 | 2002-06-28 | 430d |  |  | GP | 8944h | 8944h |  |  |  | Rel-5 | Paolo |  |
| 1659 | 93.1 | Concept | 258d | 2000-11-06 A | 2001-10-31 A | 100% | 2000-11-06 | 2001-10-31 | 258d |  | finish no earlier than 2001-10-31 | GP | 2064h | 2064h |  |  |  |  |  |  |
| 1660 | 93.2 | RLC protocol enhancement (SDU Discard) | 430d | 2000-11-06 A | 2002-06-28 A | 100% | 2000-11-06 | 2002-06-28 | 430d |  | finish no earlier than 2002-06-28 | GP | 3440h | 3440h |  |  |  |  |  |  |
| 1661 | 94 | **GERAN enhancements for streaming services 2 (usage of ECSD)** | 430d | 2000-11-06 A | 2002-06-28 A | 100% | 2000-11-06 | 2002-06-28 | 430d |  |  | GP | 19840h | 19840h |  | Ericsson | Frank Muller | Rel-5 | Paolo |  |
| 1662 | 94.1 | Usage of ECSD Concept | 380d | 2000-11-06 A | 2002-04-19 A | 100% | 2000-11-06 | 2002-04-19 | 380d |  | finish no earlier than 2002-04-19 | GP | 3040h | 3040h |  |  |  |  |  |  |
| 1663 | 94.2 | Stage 2 | 380d | 2000-11-06 A | 2002-04-19 A | 100% | 2000-11-06 | 2002-04-19 | 380d |  | finish no earlier than 2002-04-19 | GP | 3040h | 3040h |  |  |  |  |  |  |
| 1664 | 94.3 | Stage 3 | 430d | 2000-11-06 A | 2002-06-28 A | 100% | 2000-11-06 | 2002-06-28 | 430d |  | finish no earlier than 2002-06-28 | GP | 3440h | 3440h |  |  |  |  |  |  |
| 1665 | 94.4 | RLC PDU formats | 430d | 2000-11-06 A | 2002-06-28 A | 100% | 2000-11-06 | 2002-06-28 | 430d |  | finish no earlier than 2002-06-28 | GP | 3440h | 3440h |  |  |  |  |  |  |
| 1666 | 94.5 | MAC header | 430d | 2000-11-06 A | 2002-06-28 A | 100% | 2000-11-06 | 2002-06-28 | 430d |  | finish no earlier than 2002-06-28 | GP | 3440h | 3440h |  |  |  |  |  |  |

Notes:
- 1643: Accept changes Gb over IP
- 1647: Closed, accept changes for Gb over IP
- 1649: TERMINATED - NOT STANDARDIZED
- 1650: TERMINATED - NOT STANDARDIZED
- 1651: TERMINATED - NOT STANDARDIZED
- 1652: TERMINATED - NOT STANDARDIZED
- 1661: AWS, Nokia, Ericsson, Nortel, Siemens, Motorola, Vodafone

| ID | WBS | Task | Duration | Start | Finish | Predecessors | Complete | Remaining | Baseline start | Baseline finish | Baseline duration | Total slack | Constraint | Resources | Work | Actual work | Text1 | Text4 | Text5 | Text6 | Text8 |
| --- | --- | --- | --- | --- | --- | --- | --- | --- | --- | --- | --- | --- | --- | --- | --- | --- | --- | --- | --- | --- | --- |
| 1667 | 95 | **GERAN/UTRAN interface evolution 1 (evolution of Iu PS)** | 476d | 2000-09-01 A | 2002-06-28 A |  | 100% |  | 2000-09-01 | 2002-06-28 | 476d |  |  | GP; R3 | 17825.6h | 17825.6h | GERUEV1 | SBC | Marc Grant | Rel-5 | Paolo |
| 1668 | 95.1 | **Evolution of Iu ps** | 476d | 2000-09-01 A | 2002-06-28 A |  | 100% |  | 2000-09-01 | 2002-06-28 | 476d |  |  | GP; R3 | 12205.6h | 12205.6h | GERUEV1-IuPS |  |  |  |  |
| 1669 | 95.1.1 | Identification of GERAN requirements on Iu ps | 326d | 2000-09-01 A | 2001-11-30 A |  | 100% |  | 2000-09-01 | 2001-11-30 | 326d |  | finish no earlier than 2001-11-30 | GP; R3 | 4185.6h | 4185.6h |  |  |  |  |  |
| 1670 | 95.1.2 | Update of specifications | 150d | 2001-12-03 A | 2002-06-28 A | 1669 | 100% |  | 2001-12-03 | 2002-06-28 | 150d |  | finish no earlier than 2002-06-28 | GP; R3 | 2400h | 2400h |  |  |  |  |  |
| 1671 | 96 | **GERAN/UTRAN interface evolution 2 (evolution of Iu CS)** | 476d | 2000-09-01 A | 2002-06-28 A |  | 100% |  | 2000-09-01 | 2002-06-28 | 476d |  |  | GP; R3 | 23025.6h | 23025.6h | GERUEV2 |  |  | Rel-5 | Paolo |
| 1672 | 96.1 | **Evolution of Iu cs** | 476d | 2000-09-01 A | 2002-06-28 A |  | 100% |  | 2000-09-01 | 2002-06-28 | 476d |  |  | GP; R3 | 17845.6h | 17845.6h | GERUEV2-IuCS | Lucent | Krishna Balachandran |  | Paolo |
| 1673 | 96.1.1 | Identification of GERAN requirements on Iu cs | 426d | 2000-09-01 A | 2002-04-19 A |  | 100% |  | 2000-09-01 | 2002-04-19 | 426d |  | finish no earlier than 2002-04-19 | GP; R3 | 5049.6h | 5049.6h |  |  |  |  |  |
| 1674 | 96.1.2 | Update of specifications | 476d | 2000-09-01 A | 2002-06-28 A |  | 100% |  | 2000-09-01 | 2002-06-28 | 476d |  | finish no earlier than 2002-06-28 | GP; R3 | 7616h | 7616h |  |  |  |  |  |
| 1675 | 97 | **End to End QoS for PS Domain including IMS** | 480d | 2000-08-28 A | 2002-06-28 |  | 97% | 13.22d | 2000-08-28 | 2002-06-28 | 480d | 2010d |  | S2 | 9856.02h | 9584.5h | E2EQoS | Ericsson | Johnson.oyama@era.ericcson.se | Rel-5 | Alain |
| 1676 | 97.1 | E2E QoSConcept and Architecture | 178d | 2001-01-03 A | 2001-09-07 A |  | 100% |  | 2001-01-03 | 2001-09-07 | 178d |  | finish no earlier than 2001-09-07 | S2 | 1424h | 1424h |  |  |  |  |  |
| 1677 | 97.2 | E2E QoS interworking | 465d | 2000-08-28 A | 2002-06-07 |  | 95% | 23.25d | 2000-08-28 | 2002-06-07 | 465d | 2025d | finish no earlier than 2002-06-07 | N3 | 3720h | 3534h | E2EQoS-IW | Lucent | Daisuke Yokota (yokota@lucent.com) |  |  |
| 1678 | 97.3 | QoS Management (Provisioning and Monitoring) | 201d | 2001-09-21 A | 2002-06-28 A |  | 100% |  | 2001-09-21 | 2002-06-28 | 201d |  | finish no earlier than 2002-06-28 | S5 | 1608h | 1608h | E2EQoS-OAM | VoiceStream, Motorola | Albert.Yuhan@voicestream.com; Michael.Truss@MOTOROLA.COM | Rel-5 |  |
| 1679 | 98 | **Messaging enhancements Rel-5** | 467d | 2001-06-15 A | 2003-03-31 |  | 93% | 34.87d | 2001-06-15 | 2003-03-31 | 467d | 1814d |  | T2 | 19000h | 16103.4h | MESS5 |  |  | Rel-5 | Friedhelm |
| 1680 | 98.1 | **Multimedia Messaging (MMS) enhancements** | 467d | 2001-06-15 A | 2003-03-31 |  | 91% | 43.88d | 2001-06-15 | 2003-03-31 | 467d | 1814d |  | T2 | 11688h | 10589.8h | MESS5-MMS | Siemens | Josef.Laumen@SAL.SIEMENS.DE |  |  |
| 1681 | 98.1.1 | Definition of service requirements | 196d | 2001-06-15 A | 2002-03-15 A |  | 100% |  | 2001-06-15 | 2002-03-15 | 196d |  | finish no earlier than 2002-03-15 | S1 | 1568h | 1568h | MESS5-SR | Siemens | Josef.Laumen@SAL.SIEMENS.DE | Rel-5 |  |
| 1682 | 98.1.2 | Technical realization | 256d | 2001-06-15 A | 2002-06-07 A |  | 100% |  | 2001-06-15 | 2002-06-07 | 256d |  | finish no earlier than 2002-06-07 | T2 | 2048h | 2048h |  | Siemens | Josef.Laumen@SAL.SIEMENS.DE |  |  |
| 1683 | 98.1.3 | WAP Forum dependency: MM1 stage 3 | 467d | 2001-06-15 A | 2003-03-31 |  | 80% | 93.4d | 2001-06-15 | 2003-03-31 | 467d | 1814d | finish no earlier than 2003-03-31 | T2 | 3736h | 2988.8h |  |  |  |  |  |
| 1684 | 98.1.4 | MMS formats and codecs | 75d | 2001-12-03 A | 2002-03-15 A |  | 100% |  | 2001-12-03 | 2002-03-15 | 75d |  | finish no earlier than 2002-03-15 | S4 | 600h | 600h |  |  |  |  |  |
| 1685 | 98.2 | **Enhanced Messaging Service (EMS) enhancements** | 191d | 2001-06-15 A | 2002-03-08 |  | 99% | 0d | 2001-06-15 | 2002-03-08 | 191d | 0d |  | T2 | 3584h | 2064h | MESS5-EMS | Ericsson | Alan.Baldwin@EML.ERICSSON.SE |  |  |
| 1686 | 98.2.1 | Definition of service requirements | 66d | 2001-06-15 A | 2001-09-14 A |  | 100% |  | 2001-06-15 | 2001-09-14 | 66d |  | finish no earlier than 2001-09-14 | S1 | 528h | 528h |  | Ericsson | Alan.Baldwin@EML.ERICSSON.SE |  |  |
| 1687 | 98.2.2 | Technical realization | 191d | 2001-06-15 A | 2002-03-08 A |  | 100% |  | 2001-06-15 | 2002-03-08 | 191d |  | finish no earlier than 2002-03-08 | T2 | 1528h | 1528h |  | Ericsson | Alan.Baldwin@EML.ERICSSON.SE |  |  |
| 1688 | 99 | **GERAN Inter BSC NACC improvements over the Gb Interface** | 215d | 2001-09-03 A | 2002-06-28 A |  | 100% |  | 2001-09-03 | 2002-06-28 | 215d |  |  | GP | 11184h | 11184h | GERNACC |  |  | Rel-5 | Paolo |
| 1689 | 99.1 | **Modification of core network protocols for GERAN Inter BSC NACC over Gb Interface** | 165d | 2001-09-03 A | 2002-04-19 A |  | 100% |  | 2001-09-03 | 2002-04-19 | 165d |  |  | N4; S2 | 7048h | 7048h | GERNACC-Cnmod |  |  |  |  |
| 1690 | 99.1.1 | Stage 2 - Concept | 43d | 2001-09-03 A | 2001-10-31 A |  | 100% |  | 2001-09-03 | 2001-10-31 | 43d |  | finish no earlier than 2001-10-31 | N4; S2 | 688h | 688h |  |  |  |  |  |
| 1691 | 99.1.2 | Stage 2 - 23.060 change - Definition of Inter BSC NACC | 165d | 2001-09-03 A | 2002-04-19 A |  | 100% |  | 2001-09-03 | 2002-04-19 | 165d |  | finish no earlier than 2002-04-19 | N4; S2 | 2640h | 2640h |  |  |  |  |  |
| 1692 | 99.1.3 | Stage 3 (changes to TS 29.060) | 135d | 2001-09-03 A | 2002-03-08 A |  | 100% |  | 2001-09-03 | 2002-03-08 | 135d |  | finish no earlier than 2002-03-08 | N4 | 1080h | 1080h |  |  |  |  |  |

Notes:
- 1667: SBC, Motorola, Nokia, Ericsson, Nortel
- 1672: Lucent, Ericsson, AWS, Nortel
- 1676: Text3: 23.207
- 1677: [DAB - 30/07/02] - % complete to 95% (if we exclude Diffserv) / Text3: 29.208, 29.207, 27.060, 29.061, 24.008, 24.228, , 24.229, 29.060, 29.163
- 1678: Text3: 32-series
- 1679: support of UAProf, so this in my opinion is 100% complete
- 1681: Text3: 22.140
- 1682: stage 3 MM7 is missing / Text3: 23.140
- 1684: Text3: 26.140
- 1685: Text3: 23.040
- 1687: Text3: 23.040
- 1692: IP 30/11/01: Input awaited from GERAN2 to CN4 / 17 May Work complete 100%

| ID | WBS | Task | Duration | Start | Finish | Complete | Remaining | Baseline start | Baseline finish | Baseline duration | Total slack | Constraint | Resources | Work | Actual work | Text1 | Text6 | Text8 | Text3 | Text4 | Text5 |
| --- | --- | --- | --- | --- | --- | --- | --- | --- | --- | --- | --- | --- | --- | --- | --- | --- | --- | --- | --- | --- | --- |
| 1693 | 99.2 | **Modification of Gb protocols for GERAN Inter BSC NACC over Gb Interface** | 151d | 2001-11-30 A | 2002-06-28 A | 100% |  | 2001-11-30 | 2002-06-28 | 151d |  |  | GP | 2416h | 2416h | GERNACC-Gbmod |  |  |  |  |  |
| 1694 | 99.2.1 | Stage 3 (changes to TS 48.018) | 151d | 2001-11-30 A | 2002-06-28 A | 100% |  | 2001-11-30 | 2002-06-28 | 151d |  | finish no earlier than 2002-06-28 | GP | 1208h | 1208h |  |  |  |  |  |  |
| 1695 | 100 | **Enhanced Power Control** | 540d | 2001-11-26 A | 2003-12-19 |  | 537.46d | 2001-11-26 | 2003-12-19 | 540d | 1625d |  | GP | 12840h | 60.28h | EPC | Rel-5 |  |  |  |  |
| 1696 | 100.1 | Realization of Enhanced power control and signaling support | 5d | 2001-11-26 A | 2001-11-30 A | 100% |  | 2001-11-26 | 2001-11-30 | 5d |  | finish no earlier than 2001-11-30 | GP | 40h | 40h |  |  |  |  |  |  |
| 1697 | 100.2 | GERAN MS Conformance test for Enhanced Power Control | 530d | 2001-12-10 | 2003-12-19 |  |  | 2001-12-10 | 2003-12-19 | 530d | 1625d | finish no earlier than 2003-12-19 | GP | 4240h |  |  |  |  |  |  |  |
| 1698 | 100.3 | GERAN BTS Conformance test for Enhanced Power Control | 530d | 2001-12-10 | 2003-12-19 |  |  | 2001-12-10 | 2003-12-19 | 530d | 1625d | finish no earlier than 2003-12-19 | GP | 4240h |  |  |  |  |  |  |  |
| 1699 | 101 | **8PSK AMR HR** | 530d | 2001-12-10 A | 2003-12-19 | 73% | 143.32d | 2001-12-10 | 2003-12-19 | 530d | 1625d |  | GP | 21080h | 15693.5h | 8PSK-AH | Rel-5 | Paolo |  |  |  |
| 1700 | 101.1 | **Definition of channel coding, performance requirements and signaling support** | 145d | 2001-12-10 A | 2002-06-28 A | 100% |  | 2001-12-10 | 2002-06-28 | 145d |  |  | GP | 10440h | 10440h |  |  |  |  |  |  |
| 1701 | 101.1.1 | Concept | 145d | 2001-12-10 A | 2002-06-28 A | 100% |  | 2001-12-10 | 2002-06-28 | 145d |  | finish no earlier than 2002-06-28 | GP | 1160h | 1160h |  |  |  |  |  |  |
| 1702 | 101.1.2 | Changes to 44.018 | 145d | 2001-12-10 A | 2002-06-28 A | 100% |  | 2001-12-10 | 2002-06-28 | 145d |  | finish no earlier than 2002-06-28 | G2 | 1160h | 1160h |  |  |  |  |  |  |
| 1703 | 101.1.3 | Changes to 45.001 | 145d | 2001-12-10 A | 2002-06-28 A | 100% |  | 2001-12-10 | 2002-06-28 | 145d |  | finish no earlier than 2002-06-28 | G1 | 1160h | 1160h |  |  |  |  |  |  |
| 1704 | 101.1.4 | Changes to 45.002 | 145d | 2001-12-10 A | 2002-06-28 A | 100% |  | 2001-12-10 | 2002-06-28 | 145d |  | finish no earlier than 2002-06-28 | G1 | 1160h | 1160h |  |  |  |  |  |  |
| 1705 | 101.1.5 | Changes to 45.003 | 145d | 2001-12-10 A | 2002-06-28 A | 100% |  | 2001-12-10 | 2002-06-28 | 145d |  | finish no earlier than 2002-06-28 | G1 | 1160h | 1160h |  |  |  |  |  |  |
| 1706 | 101.1.6 | Changes to 45.005 | 145d | 2001-12-10 A | 2002-06-28 A | 100% |  | 2001-12-10 | 2002-06-28 | 145d |  | finish no earlier than 2002-06-28 | G1 | 1160h | 1160h |  |  |  |  |  |  |
| 1707 | 101.1.7 | Changes to 24.008 | 145d | 2001-12-10 A | 2002-06-28 A | 100% |  | 2001-12-10 | 2002-06-28 | 145d |  | finish no earlier than 2002-06-28 | G2 | 1160h | 1160h |  |  |  |  |  |  |
| 1708 | 101.1.8 | Changes to 48.058 | 145d | 2001-12-10 A | 2002-06-28 A | 100% |  | 2001-12-10 | 2002-06-28 | 145d |  | finish no earlier than 2002-06-28 | G2 | 1160h | 1160h |  |  |  |  |  |  |
| 1709 | 101.2 | GERAN MS Conformance test for 8PSK HR | 530d | 2001-12-10 | 2003-12-19 |  |  | 2001-12-10 | 2003-12-19 | 530d | 1625d | finish no earlier than 2003-12-19 | GP | 4240h |  |  |  |  |  |  |  |
| 1710 | 101.3 | GERAN BTS Conformance test for 8PSK HR | 270d | 2001-12-10 A | 2002-12-20 A | 100% |  | 2001-12-10 | 2002-12-20 | 270d |  | finish no earlier than 2002-12-20 | GP | 2160h | 2160h |  |  |  |  |  |  |
| 1711 | 102 | Service Change and UDI Fallback | 175d | 2001-10-08 A | 2002-06-07 A | 100% |  | 2001-10-08 | 2002-06-07 | 175d |  | finish no earlier than 2002-06-07 | N3 | 1400h | 1400h | SCUDIF | Rel-5 | David | 29.007, 27.001, 24.008 | Ericsson | Rune.Werner.Wiik@ericsson.no |
| 1712 | 103 | **Rel-5 USIM toolkit enhancements** | 865d | 2000-06-05 A | 2003-09-26 | 51% | 425.77d | 2000-06-05 | 2003-09-26 | 865d | 1685d |  | T3 | 24352h | 13591.2h | USAT1 | Rel-5 | Claus |  |  |  |
| 1713 | 103.1 | Test specification for USIM toolkit security mechanims | 349d | 2002-05-28 | 2003-09-26 |  |  | 2002-05-28 | 2003-09-26 | 349d | 1685d | finish no earlier than 2003-09-26 | T3 | 2792h |  |  | Rel-5 |  |  | Gemplus | Sophie Viallet |
| 1714 | 103.2 | **Protocol Standardisation of a SIM Toolkit Interpreter** | 688d | 2000-06-05 A | 2003-01-22 | 64% | 250.88d | 2000-06-05 | 2003-01-22 | 688d | 1862d |  | T3 | 12512h | 7949.41h | USAT1-Interpr | Rel-5 |  | 27.103 | G & D | Michael Meyer |
| 1715 | 103.2.1 | Stage 1 | 205d | 2000-06-05 A | 2001-03-16 A | 100% |  | 2000-06-05 | 2001-03-16 | 205d |  | finish no earlier than 2001-03-16 | T3 | 1640h | 1640h |  |  |  |  |  |  |
| 1716 | 103.2.2 | Stage 2 and 3 | 308d | 2001-01-03 A | 2002-03-08 A | 100% |  | 2001-01-03 | 2002-03-08 | 308d |  | finish no earlier than 2002-03-08 | T3 | 2464h | 2464h |  |  |  |  |  |  |
| 1717 | 103.2.3 | Test specification | 363d | 2001-09-03 A | 2003-01-22 | 12% | 319.44d | 2001-09-03 | 2003-01-22 | 363d | 1862d | finish no earlier than 2003-01-22 | T3 | 2904h | 348.48h |  |  |  |  | Gemplus | Gérald MAUNIER |

Notes:
- 1696: Ready
- 1697: Not started
- 1698: Not started
- 1699: Completed for Rel-5
- 1711: [DAB - 23/05/03] - 100 % complete some issues with CAMEL
- 1714: 28/5/2001: T3-19 proposed that since the stage 2 and 3 will not be presented to TP-12 for approval as expected, the WI will be moved to rel-5, with completion expected at TP-13.
- 1715: 5/10/2001: Stage one comepeted at TP-12.
- 1716: 5/10/2001: TS 31.112 and 31.113 approved at TP-13. TS 31.114 to be presented to TP-14.
- 1717: 5/10/2001: Work started on test specification

| ID | WBS | Task | Duration | Start | Finish | Complete | Remaining | Baseline start | Baseline finish | Baseline duration | Total slack | Constraint | Resources | Work | Actual work | Text1 | Text6 | Text4 | Text5 | Text8 |
| --- | --- | --- | --- | --- | --- | --- | --- | --- | --- | --- | --- | --- | --- | --- | --- | --- | --- | --- | --- | --- |
| 1718 | 103.4 | **(U)SIM API** | 133d | 2002-03-20 A | 2002-09-20 A | 100% |  | 2002-03-20 | 2002-09-20 | 133d |  |  | T3 | 2128h | 2128h | USAT1-API | NA |  |  |  |
| 1719 | 103.4.1 | Java API Test specification | 133d | 2002-03-20 A | 2002-09-20 A | 100% |  | 2002-03-20 | 2002-09-20 | 133d |  | finish no earlier than 2002-09-20 | T3 | 1064h | 1064h |  |  | Microelectrónica Española | Mario Pérez |  |
| 1720 | 104 | **small Technical Enhancements and Improvements for Rel5** | 2348d? | 2000-01-03 A | 2008-12-31 A | 100% |  | 2000-01-03 | 2008-12-31 | 2348d? |  |  | All | 18784h | 18784h | TEI5 | Rel-5 |  |  |  |
| 1721 | 1.410.1 | Small Technical Enhancements and Improvements for Rel-5 Conformance Testing | 2348d? | 2000-01-03 A | 2008-12-31 A | 100% |  | 2000-01-03 | 2008-12-31 | 2348d? |  | finish no earlier than 2008-12-31 | R5 | 18784h | 18784h | TEI5_Test | Rel-5 |  |  | Stoyan Baev |
| 1722 | 105 | Technical Report on UE Functionality Split (Work stopped) | 86d | 2000-01-03 | 2000-05-01 |  |  | 2000-01-03 | 2000-05-01 | 86d | 2574d |  | S1 | 688h |  | UESPLIT | Rel-5 | Motorola | sanjay.gupta@motorola.com | Michael |
| 1723 | 106 | **User Equipment Management** | 267d | 2001-06-21 A | 2002-06-28 | 99% | 0d | 2001-06-21 | 2002-06-28 | 267d | 0d |  | S5 | 3752h | 3752h | UEM | Rel-5 | Vodafone | john.mudge@vf.vodafone.co.uk | Adrian |
| 1724 | 106.1 | FS on User Equipment (UE) Management | 267d | 2001-06-21 A | 2002-06-28 A | 100% |  | 2001-06-21 | 2002-06-28 | 267d |  | finish no earlier than 2002-06-28 | S5 | 2136h | 2136h | OAM-UEM | Rel-5 | Vodafone | john.mudge@VF.VODAFONE.CO.UK | Adrian |
| 1725 | 107 | **Flow control supporting an MS with multiple data flows with different QoS over the Gb interface** | 50d | 2002-06-24 A | 2002-08-30 A | 100% |  | 2002-06-24 | 2002-08-30 | 50d |  |  | GP | 1288h | 1288h | FlowCon | Rel-5 | Ericsson | ingemar.backlund@era.ericsson.se |  |
| 1726 | 107.1 | **Update of stage 2 specifications** | 50d | 2002-06-24 A | 2002-08-30 A | 100% |  | 2002-06-24 | 2002-08-30 | 50d |  |  | GP | 808h | 808h |  |  |  |  |  |
| 1727 | 107.1.1 | Concept document 23.060 (changes to) | 46d | 2002-06-28 A | 2002-08-30 A | 100% |  | 2002-06-28 | 2002-08-30 | 46d |  | finish no earlier than 2002-08-30 | S2 | 368h | 368h |  |  |  |  |  |
| 1728 | 107.1.2 | Flow Control | 5d | 2002-06-24 A | 2002-06-28 A | 100% |  | 2002-06-24 | 2002-06-28 | 5d |  | finish no earlier than 2002-06-28 | GP | 40h | 40h |  |  |  |  |  |
| 1729 | 107.2 | **Modification of BSSGP protocol** | 5d | 2002-06-24 A | 2002-06-28 A | 100% |  | 2002-06-24 | 2002-06-28 | 5d |  |  | GP | 80h | 80h |  |  | Ericsson | ingemar.backlund@era.ericsson.se |  |
| 1730 | 107.2.1 | Stage 3 (changes to 48.018) | 5d | 2002-06-24 A | 2002-06-28 A | 100% |  | 2002-06-24 | 2002-06-28 | 5d |  | finish no earlier than 2002-06-28 | G2 | 40h | 40h |  |  |  |  |  |
| 1731 | 108 | **Multiple TBF in A/Gb mode** | 421d | 2002-04-19 A | 2003-11-28 | 17% | 349.82d | 2002-04-19 | 2003-11-28 | 421d | 1640d |  | GP | 17480h | 2716.75h | MULTBF | Rel-5 | Ericsson | gunnar.mildh@era.ericsson.se |  |
| 1732 | 108.1 | **Multiple TBF in A/Gb mode** | 351d | 2002-04-19 A | 2003-08-22 | 26% | 258.09d | 2002-04-19 | 2003-08-22 | 351d | 1710d |  | GP | 8112h | 2147.3h | MULTBF-Agbmode |  |  |  |  |
| 1733 | 108.1.1 | Multiple TBF Concept paper | 351d | 2002-04-19 A | 2003-08-22 | 50% | 175.5d | 2002-04-19 | 2003-08-22 | 351d | 1710d | finish no earlier than 2003-08-22 | GP | 2808h | 1404h |  |  |  |  |  |
| 1734 | 108.1.2 | Multiple TBF Stage 2 (43.064) CRs | 156d | 2002-04-19 | 2002-11-22 |  |  | 2002-04-19 | 2002-11-22 | 156d | 1905d | finish no earlier than 2002-11-22 | G1 | 1248h |  |  |  |  |  |  |
| 1735 | 108.1.3 | Multiple TBF Stage 3 (44.060) CRs | 156d | 2002-04-19 | 2002-11-22 |  |  | 2002-04-19 | 2002-11-22 | 156d | 1905d | finish no earlier than 2002-11-22 | G2 | 1248h |  |  |  |  |  |  |
| 1736 | 108.2 | **Multiple TBF in A/Gb mode – MS testing** | 375d | 2002-06-24 | 2003-11-28 |  |  | 2002-06-24 | 2003-11-28 | 375d | 1640d |  | GP | 6000h |  |  |  | Ericsson | ingemar.backlund@era.ericsson.se |  |
| 1737 | 108.2.1 | MS conformance tests | 375d | 2002-06-24 | 2003-11-28 |  |  | 2002-06-24 | 2003-11-28 | 375d | 1640d | finish no earlier than 2003-11-28 | G4 | 3000h |  |  |  |  |  |  |
| 1738 | 109 | **Alignment of 3G functional split and Iu** | 922d | 2000-06-08 A | 2003-12-19 | 85% | 141.74d | 2000-06-08 | 2003-12-19 | 922d | 1625d |  | GP | 161582h | 124844h | GER3GAL | Rel-5 | Ericsson | Frank Muller | Paolo |
| 1739 | 109.1 | **GERAN user / control plane** | 540d | 2000-08-07 A | 2002-08-30 | 99% | 0d | 2000-08-07 | 2002-08-30 | 540d | 0d |  | GP | 36232h | 33672h | GER3GAL-GUCOPL |  | Ericsson | Frank Muller | Paolo |
| 1740 | 109.1.1 | **Alignment with UMTS bearer concept** | 540d | 2000-08-07 A | 2002-08-30 | 99% | 0d | 2000-08-07 | 2002-08-30 | 540d | 0d |  | GP | 24952h | 22392h |  |  |  |  |  |
| 1741 | 109.1.1.1 | Enhanced power control | 1d | 2001-08-31 A | 2001-08-31 A | 100% |  | 2001-08-31 | 2001-08-31 | 1d |  | finish no earlier than 2001-08-31 | GP | 8h | 8h |  |  |  |  |  |
| 1742 | 109.1.1.2 | Stage 2 | 235d | 2000-08-07 A | 2001-06-29 A | 100% |  | 2000-08-07 | 2001-06-29 | 235d |  | finish no earlier than 2001-06-29 | GP | 1880h | 1880h |  |  |  |  |  |
| 1743 | 109.1.1.3 | Adoption of the UTRAN PDCP | 295d | 2000-11-06 A | 2001-12-21 A | 100% |  | 2000-11-06 | 2001-12-21 | 295d |  | finish no earlier than 2001-12-21 | GP | 2360h | 2360h |  |  |  |  |  |
| 1744 | 109.1.1.4 | Development of RLC / MAC | 261d | 2001-08-31 A | 2002-08-30 A | 100% |  | 2001-08-31 | 2002-08-30 | 261d |  | finish no earlier than 2002-08-30 | GP | 2088h | 2088h |  |  |  |  |  |
| 1745 | 109.1.1.5 | Development of GERAN RRC | 266d | 2001-06-22 A | 2002-06-28 A | 100% |  | 2001-06-22 | 2002-06-28 | 266d |  | finish no earlier than 2002-06-28 | GP | 2128h | 2128h |  |  |  |  |  |
| 1746 | 109.1.1.6 | Ciphering and integrity protection concept paper | 166d | 2001-08-31 A | 2002-04-19 A | 100% |  | 2001-08-31 | 2002-04-19 | 166d |  | finish no earlier than 2002-04-19 | GP | 1328h | 1328h |  |  |  |  |  |
| 1747 | 109.1.1.7 | Multiple TBF or equivalent Concept paper | 116d | 2001-08-31 A | 2002-02-08 A | 100% |  | 2001-08-31 | 2002-02-08 | 116d |  | finish no earlier than 2002-02-08 | GP | 928h | 928h |  |  |  |  |  |
| 1748 | 109.1.1.8 | Paging concept | 166d | 2001-08-31 A | 2002-04-19 A | 100% |  | 2001-08-31 | 2002-04-19 | 166d |  | finish no earlier than 2002-04-19 | GP | 1328h | 1328h |  |  |  |  |  |
| 1749 | 109.1.1.9 | Dedicated Physical subchannels, includes traffic and control channels | 66d | 2001-08-31 A | 2001-11-30 A | 100% |  | 2001-08-31 | 2001-11-30 | 66d |  | finish no earlier than 2001-11-30 | GP | 528h | 528h |  |  |  |  |  |
| 1750 | 109.1.1.10 | Iu support and broadcast concept | 166d | 2001-08-31 A | 2002-04-19 A | 100% |  | 2001-08-31 | 2002-04-19 | 166d |  | finish no earlier than 2002-04-19 | GP | 1328h | 1328h |  |  |  |  |  |
| 1751 | 109.1.1.11 | Impact of using RLC instead of LAPDm concept | 116d | 2001-08-31 A | 2002-02-08 A | 100% |  | 2001-08-31 | 2002-02-08 | 116d |  | finish no earlier than 2002-02-08 | GP | 928h | 928h |  |  |  |  |  |
| 1752 | 109.1.1.12 | Contention resolution, mobile station identity, and access concept | 66d | 2001-08-31 A | 2001-11-30 A | 100% |  | 2001-08-31 | 2001-11-30 | 66d |  | finish no earlier than 2001-11-30 | GP | 528h | 528h |  |  |  |  |  |
| 1753 | 109.1.1.13 | PDCP concept | 166d | 2001-08-31 A | 2002-04-19 A | 100% |  | 2001-08-31 | 2002-04-19 | 166d |  | finish no earlier than 2002-04-19 | GP | 1328h | 1328h |  |  |  |  |  |
| 1754 | 109.1.1.14 | Downlink delayed TBF release | 261d | 2001-08-31 A | 2002-08-30 A | 100% |  | 2001-08-31 | 2002-08-30 | 261d |  | finish no earlier than 2002-08-30 | GP | 2088h | 2088h |  |  |  |  |  |
| 1755 | 109.1.1.15 | Add transparent RLC Concept | 116d | 2001-08-31 A | 2002-02-08 A | 100% |  | 2001-08-31 | 2002-02-08 | 116d |  | finish no earlier than 2002-02-08 | GP | 928h | 928h |  |  |  |  |  |
| 1756 | 109.1.1.16 | Handover concept | 116d | 2001-08-31 A | 2002-02-08 A | 100% |  | 2001-08-31 | 2002-02-08 | 116d |  | finish no earlier than 2002-02-08 | GP | 928h | 928h |  |  |  |  |  |

Notes:
- 1718: 8/3/2001: test spec is based on R99 core spec, so deleted from Workplan
- 1720: "Joker" WI, to be used for a Rel 5 CR not related to any feature and with very limited impact on the system
- 1721: "Joker" WI, to be used for small modifications applicable to Rel 5 conformance testing. Moved in from Stoyan/testing WP. / Text3: 34.108, 34.109, 34.121-1, 34.121-2, 34.122, 34.123-1, 34.123-2, 34.123-3, 34.171, 34.229-1, 34.229-2, 34.229-3
- 1723: az: Rel-5->NA (to cover also Rel-6)
- 1724: Text3: 32.802
- 1725: 50101 -> 50201
- 1726: 50102 -> 50202
- 1728: 50103 -> 50203
- 1732: Started
- 1736: 50106 -> 50206
- 1737: Not started
- 1738: AWS, Nokia, Ericsson, Nortel, Siemens, Vodafone
- 1739: AWS, Nokia, Ericsson, Nortel, Siemens, Vodafone
- 1743: Responsible is GERAN; RAN WG2 help may be needed.

| ID | WBS | Task | Duration | Start | Finish | Complete | Remaining | Baseline start | Baseline finish | Baseline duration | Total slack | Constraint | Resources | Work | Actual work | Text1 | Text4 | Text5 | Text8 |
| --- | --- | --- | --- | --- | --- | --- | --- | --- | --- | --- | --- | --- | --- | --- | --- | --- | --- | --- | --- |
| 1757 | 109.1.2 | **Physical layer alignment with UMTS bearer concept** | 280d | 2000-11-06 A | 2001-11-30 A | 100% |  | 2000-11-06 | 2001-11-30 | 280d |  |  | GP | 6960h | 6960h |  |  |  |  |
| 1758 | 109.1.2.1 | PDTCH/TCH in 45.003 | 155d | 2000-11-06 A | 2001-06-08 A | 100% |  | 2000-11-06 | 2001-06-08 | 155d |  | finish no earlier than 2001-06-08 | GP | 1240h | 1240h |  |  |  |  |
| 1759 | 109.1.2.2 | Control channels in 45.003 | 155d | 2000-11-06 A | 2001-06-08 A | 100% |  | 2000-11-06 | 2001-06-08 | 155d |  | finish no earlier than 2001-06-08 | GP | 1240h | 1240h |  |  |  |  |
| 1760 | 109.1.2.3 | Receiver performance in 45.005 for PDTCH/TCH and control channels | 280d | 2000-11-06 A | 2001-11-30 A | 100% |  | 2000-11-06 | 2001-11-30 | 280d |  | finish no earlier than 2001-11-30 | GP | 2240h | 2240h |  |  |  |  |
| 1761 | 109.2 | **Iu rg interface** | 430d | 2000-11-06 A | 2002-06-28 | 100% | 0d | 2000-11-06 | 2002-06-28 | 430d | 0d |  | GP; RP | 59660h | 56220h | GER3GAL-Iurg | Ericsson | Frank Muller | Paolo |
| 1762 | 109.2.1 | **Inter BSS interface** | 430d | 2000-11-06 A | 2002-06-28 A | 100% |  | 2000-11-06 | 2002-06-28 | 430d |  |  | GP; RP | 24080h | 24080h |  |  |  |  |
| 1763 | 109.2.1.1 | Identification of requirements | 430d | 2000-11-06 A | 2002-06-28 A | 100% |  | 2000-11-06 | 2002-06-28 | 430d |  | finish no earlier than 2002-06-28 | GP | 3440h | 3440h |  |  |  |  |
| 1764 | 109.2.1.2 | Stage 2 | 430d | 2000-11-06 A | 2002-06-28 A | 100% |  | 2000-11-06 | 2002-06-28 | 430d |  | finish no earlier than 2002-06-28 | GP | 3440h | 3440h |  |  |  |  |
| 1765 | 109.2.1.3 | Adoption of relevant parts from Iur | 430d | 2000-11-06 A | 2002-06-28 A | 100% |  | 2000-11-06 | 2002-06-28 | 430d |  | finish no earlier than 2002-06-28 | GP | 3440h | 3440h |  |  |  |  |
| 1766 | 109.2.1.4 | Complementation with GERAN specifics | 430d | 2000-11-06 A | 2002-06-28 A | 100% |  | 2000-11-06 | 2002-06-28 | 430d |  | finish no earlier than 2002-06-28 | GP | 3440h | 3440h |  |  |  |  |
| 1767 | 109.2.1.5 | Stage 3 | 430d | 2000-11-06 A | 2002-06-28 A | 100% |  | 2000-11-06 | 2002-06-28 | 430d |  | finish no earlier than 2002-06-28 | GP | 3440h | 3440h |  |  |  |  |
| 1768 | 109.2.2 | **Inter BSS-RNS interface** | 430d | 2000-11-06 A | 2002-06-28 A | 100% |  | 2000-11-06 | 2002-06-28 | 430d |  |  | GP; RP | 28700h | 28700h |  |  |  |  |
| 1769 | 109.2.2.1 | Identification of requirements | 430d | 2000-11-06 A | 2002-06-28 A | 100% |  | 2000-11-06 | 2002-06-28 | 430d |  | start no earlier than 2000-11-06 | GP; R3 | 6880h | 6880h |  |  |  |  |
| 1770 | 109.2.2.2 | Stage 2 | 430d | 2000-11-06 A | 2002-06-28 A | 100% |  | 2000-11-06 | 2002-06-28 | 430d |  | finish no earlier than 2002-06-28 | GP; R3 | 5744.8h | 5744.8h |  |  |  |  |
| 1771 | 109.2.2.3 | Adoption of relevant parts from Iur | 430d | 2000-11-06 A | 2002-06-28 A | 100% |  | 2000-11-06 | 2002-06-28 | 430d |  | finish no earlier than 2002-06-28 | GP; R3 | 6880h | 6880h |  |  |  |  |
| 1772 | 109.2.2.4 | Complementation with GERAN specifics | 107.5d | 2002-01-30 A | 2002-06-28 A | 100% |  | 2002-01-30 | 2002-06-28 | 107.5d |  | finish no earlier than 2002-06-28 | GP; R3 | 1720h | 1720h |  |  |  |  |
| 1773 | 109.2.2.5 | Stage 3 | 107.5d | 2002-01-30 A | 2002-06-28 A | 100% |  | 2002-01-30 | 2002-06-28 | 107.5d |  | finish no earlier than 2002-06-28 | GP; R3 | 1720h | 1720h |  |  |  |  |
| 1774 | 109.3 | **Voice over GERAN PS and CS concept** | 430d | 2000-11-06 A | 2002-06-28 A | 100% |  | 2000-11-06 | 2002-06-28 | 430d |  |  | GP; R3 | 33338.4h | 33338.4h |  |  |  | Paolo |
| 1775 | 109.3.1 | Architecture for A, Iu cs and Iu ps | 430d | 2000-11-06 A | 2002-06-28 A | 100% |  | 2000-11-06 | 2002-06-28 | 430d |  | finish no earlier than 2002-06-28 | GP; R3 | 6412.8h | 6412.8h |  |  |  |  |
| 1776 | 109.3.2 | Transcoder position/operation | 115d | 2000-11-06 A | 2001-04-13 A | 100% |  | 2000-11-06 | 2001-04-13 | 115d |  | finish no earlier than 2001-04-13 | GP | 920h | 920h |  |  |  |  |
| 1777 | 109.3.3 | Handover | 430d | 2000-11-06 A | 2002-06-28 A | 100% |  | 2000-11-06 | 2002-06-28 | 430d |  | finish no earlier than 2002-06-28 | GP; R3 | 6412.8h | 6412.8h |  |  |  |  |
| 1778 | 109.3.4 | RTP payload | 430d | 2000-11-06 A | 2002-06-28 A | 100% |  | 2000-11-06 | 2002-06-28 | 430d |  | finish no earlier than 2002-06-28 | GP; R3 | 6412.8h | 6412.8h |  |  |  |  |
| 1779 | 109.3.5 | Codec renegotiation concept | 365d | 2000-11-06 A | 2002-03-29 A | 100% |  | 2000-11-06 | 2002-03-29 | 365d |  | finish no earlier than 2002-03-29 | GP; R3 | 5840h | 5840h |  |  |  |  |
| 1780 | 109.3.6 | LA | 115d | 2000-11-06 A | 2001-04-13 A | 100% |  | 2000-11-06 | 2001-04-13 | 115d |  | finish no earlier than 2001-04-13 | GP | 920h | 920h |  |  |  |  |

Notes:
- 1761: AWS, Nokia, Ericsson, Nortel, Siemens, Vodafone

| ID | WBS | Task | Duration | Start | Finish | Complete | Remaining | Baseline start | Baseline finish | Baseline duration | Total slack | Constraint | Resources | Work | Actual work | Text8 | Text1 | Text4 | Text5 | Text6 | Text9 |
| --- | --- | --- | --- | --- | --- | --- | --- | --- | --- | --- | --- | --- | --- | --- | --- | --- | --- | --- | --- | --- | --- |
| 1781 | 109.4 | **GERAN MS Conformance test for GERAN interface evolution** | 660d | 2001-06-11 | 2003-12-19 |  |  | 2001-06-11 | 2003-12-19 | 660d | 1625d |  | GP | 10560h |  | Paolo |  |  |  |  |  |
| 1782 | 109.4.1 | MS test | 660d | 2001-06-11 | 2003-12-19 |  |  | 2001-06-11 | 2003-12-19 | 660d | 1625d | finish no earlier than 2003-12-19 | GP | 5280h |  |  |  |  |  |  |  |
| 1783 | 109.5 | **GERAN BSS Conformance test for GERAN interface evolution** | 922d | 2000-06-08 | 2003-12-19 |  |  | 2000-06-08 | 2003-12-19 | 922d | 1625d |  | GP | 14752h |  | Paolo |  |  |  |  |  |
| 1784 | 109.5.1 | BSS test | 922d | 2000-06-08 | 2003-12-19 |  |  | 2000-06-08 | 2003-12-19 | 922d | 1625d | finish no earlier than 2003-12-19 | GP | 7376h |  |  |  |  |  |  |  |
| 1785 | 110 | **GERAN support for IMS** | 690d | 2000-05-01 A | 2002-12-20 | 59% | 286.24d | 2000-05-01 | 2002-12-20 | 690d | 1885d |  | GP | 66591.8h | 38052.6h | Paolo | GERIMS | Nokia | Shkumbin Hamiti | Rel-5 |  |
| 1786 | 110.1 | **GERAN Header adaptation** | 690d | 2000-05-01 A | 2002-12-20 | 100% | 0d | 2000-05-01 | 2002-12-20 | 690d | 0d |  | GP; S2; RP | 27325.8h | 18525.8h | Paolo | GERIMS-HEADAPT | Nokia | Shkumbin Hamiti |  |  |
| 1787 | 110.1.1 | Definition of compression and removal modes for PDCP protocol | 22.1d | 2000-05-01 A | 2000-11-10 A | 100% |  | 2000-05-01 | 2000-11-10 | 22.1d |  | finish no earlier than 2000-09-01 | GP; S2; RP | 248.4h | 248.4h |  |  |  |  |  | 2332 |
| 1788 | 110.1.2 | Conceptual description in stage 2 | 393d | 2000-05-01 A | 2001-10-31 A | 100% |  | 2000-05-01 | 2001-10-31 | 393d |  | finish no earlier than 2001-10-31 | GP; S2; RP | 5989.93h | 5989.93h |  |  |  |  |  | 2333 |
| 1789 | 110.1.3 | Necessary changes on stage 3 regarding header removal | 439.8d | 2000-11-06 A | 2002-12-20 A | 100% |  | 2000-11-06 | 2002-12-20 | 439.8d |  | finish no earlier than 2002-12-20 | GP; S2; RP | 6767.47h | 6767.47h |  |  |  |  |  |  |
| 1790 | 110.2 | **GERAN Radio access bearer design for IMS** | 430d | 2000-11-06 A | 2002-06-28 | 89% | 46.49d | 2000-11-06 | 2002-06-28 | 430d | 2010d |  | GP; S2; RP | 21658h | 16713.3h | Paolo | GERIMS-RABDES | Nokia | Shkumbin Hamiti |  |  |
| 1791 | 110.2.1 | **MuM control signalling for conversational multimedia services** | 430d | 2000-11-06 A | 2002-06-28 | 89% | 46.49d | 2000-11-06 | 2002-06-28 | 430d | 2010d |  | GP; S2; RP | 12458h | 8507.9h |  |  |  |  |  |  |
| 1792 | 110.2.1.1 | Identification of requirements | 330d | 2000-11-06 A | 2002-02-08 A | 100% |  | 2000-11-06 | 2002-02-08 | 330d |  | finish no earlier than 2002-02-08 | GP; S2; RP | 5545.6h | 5545.6h |  |  |  |  |  |  |
| 1793 | 110.2.1.2 | Necessary modifications due to SIP | 40d | 2002-05-06 | 2002-06-28 |  |  | 2002-05-06 | 2002-06-28 | 40d | 2010d | finish no earlier than 2002-06-28 | GP; S2; RP | 960h |  |  |  |  |  |  |  |
| 1794 | 110.3 | **GERAN MS Conformance test for support of IMS** | 400d | 2001-06-11 | 2002-12-20 |  |  | 2001-06-11 | 2002-12-20 | 400d | 1885d |  | GP | 6400h |  | Paolo | GERIMS-MSconf | Nokia | Shkumbin Hamiti |  |  |
| 1795 | 110.3.1 | MS test | 400d | 2001-06-11 | 2002-12-20 |  |  | 2001-06-11 | 2002-12-20 | 400d | 1885d | finish no earlier than 2002-12-20 | G4 | 3200h |  |  |  |  |  |  |  |
| 1796 | 110.4 | **GERAN BTS Conformance test for support of IMS** | 400d | 2001-06-11 | 2002-12-20 |  |  | 2001-06-11 | 2002-12-20 | 400d | 1885d |  | GP | 6400h |  | Paolo | GERIMS-BTSconf | Nokia | Shkumbin Hamiti |  |  |
| 1797 | 110.4.1 | BTS test | 400d | 2001-06-11 | 2002-12-20 |  |  | 2001-06-11 | 2002-12-20 | 400d | 1885d | finish no earlier than 2002-12-20 | G3 | 3200h |  |  |  |  |  |  |  |
| 1798 | 1.417 | MS Conformance Testing of Dual Transfer Mode | 65d? | 2002-11-11 A | 2003-02-07 A | 100% |  | 2002-11-11 | 2003-02-07 | 65d? |  | finish no earlier than 2003-02-07 | G4; G5 | 1040h | 1040h |  | MSCTDTM | Vodafone | Dave Fox | NA |  |
| 1799 | 1.418 | **Handling of early UEs** | 910d? | 2000-01-03 A | 2003-06-27 A | 100% |  | 2000-01-03 | 2003-06-27 | 910d? |  |  | S2 | 4480h | 4480h | Alain | LATE_UE |  |  | Rel-5 |  |
| 1800 | 1.418.1 | Feasibility Study | 50d? | 2002-10-07 A | 2002-12-13 A | 100% |  | 2002-10-07 | 2002-12-13 | 50d? |  | finish no earlier than 2002-12-13 | S2 | 400h | 400h |  |  |  |  |  |  |
| 1801 | 1.418.2 | Stage 2 | 125d? | 2003-01-06 A | 2003-06-27 A | 100% |  | 2003-01-06 | 2003-06-27 | 125d? |  | start no earlier than 2003-01-06 | S2 | 1000h | 1000h |  |  |  |  |  |  |
| 1802 | 1.418.3 | FS for the Early Mobile Handling in UTRAN | 195d | 2002-09-09 A | 2003-06-06 A | 100% |  | 2002-09-09 | 2003-06-06 | 195d |  | finish no earlier than 2003-06-06 | R2 | 1560h | 1560h |  | FSEarlyUE | Vodafone | Alan Law | Rel-5 |  |
| 1803 | 1.418.4 | Note: Stage 3 RAN part not shown | 1d | 2000-01-03 A | 2000-01-03 A | 100% |  | 2000-01-03 | 2000-01-03 | 1d |  |  |  |  |  |  |  |  |  |  |  |
| 1804 | 1.419 | Release 4 Features | 1d? | 2000-01-03 | 2000-01-03 |  |  | 2000-01-03 | 2000-01-03 | 1d? | 2659d |  | CP,GP, RP,SP,TP | 8h |  |  |  |  |  | Rel-4 |  |

Notes:
- 1781: Not started
- 1782: Not started
- 1783: Not started
- 1784: Not started
- 1785: AWS, Nokia, Ericsson, Nortel, Siemens, Motorola
- 1786: AWS, Nokia, Ericsson, Nortel, Siemens, Motorola
- 1790: TERMINATED - NOT STANDARDIZED
- 1791: TERMINATED - NOT STANDARDIZED
- 1792: TERMINATED - NOT STANDARDIZED
- 1793: TERMINATED - NOT STANDARDIZED
- 1794: TERMINATED - NOT STANDARDIZED
- 1795: TERMINATED - NOT STANDARDIZED
- 1796: TERMINATED - NOT STANDARDIZED
- 1797: TERMINATED - NOT STANDARDIZED
- 1798: Needed to complete DTM (R99)

| ID | WBS | Task | Duration | Start | Finish | Predecessors | Complete | Remaining | Baseline start | Baseline finish | Baseline duration | Total slack | Constraint | Resources | Work | Actual work | Text1 | Text6 | Text8 | Text3 | Text4 | Text5 |
| --- | --- | --- | --- | --- | --- | --- | --- | --- | --- | --- | --- | --- | --- | --- | --- | --- | --- | --- | --- | --- | --- | --- |
| 1805 | 15 | **Miscelleneous UE Conformance Testing Activities** | 958d | 2001-04-02 A | 2004-12-01 |  | 50% | 483.11d | 2001-04-02 | 2004-12-01 | 958d | 1377d |  | T1 | 36360h | 18023.9h | MISTST1 | NA | Lidia |  |  |  |
| 1806 | 15.1 | Optimisation of Test Time, RF Aspects (FDD) | 508d | 2001-09-24 A | 2003-09-03 |  | 70% | 152.4d | 2001-09-24 | 2003-09-03 | 508d | 1702d | finish no earlier than 2003-09-03 | T1 | 4064h | 2844.8h | MISTST1-OpFDD | Rel Indep |  | 34.121 |  |  |
| 1807 | 15.2 | Optimisation of Test Time, RF Aspects (TDD) | 508d | 2001-09-24 A | 2003-09-03 |  | 70% | 152.4d | 2001-09-24 | 2003-09-03 | 508d | 1702d | finish no earlier than 2003-09-03 | T1 | 4064h | 2844.8h | MISTST1-OpTDD | Rel Indep |  | 34.122 |  |  |
| 1808 | 15.3 | Extensions to R99 Test cases | 139.4w | 2001-04-02 A | 2003-12-02 |  | 70% | 41.82w | 2001-04-02 | 2003-12-02 | 139.4w | 1638d | finish no earlier than 2003-12-02 | T1 | 5576h | 3903.2h | MISTST1-Ext |  |  | 34.123 p 1,2 |  |  |
| 1809 | 15.4 | Extension to R99 Test cases - TTCN | 439d | 2002-06-28 A | 2004-03-03 |  | 50% | 219.5d | 2002-06-28 | 2004-03-03 | 439d | 1572d | finish no earlier than 2004-03-03 | T1 | 3512h | 1756h |  |  |  |  |  |  |
| 1810 | 15.5 | Creation of R99 TCs for TDD - prose | 719d | 2001-10-01 A | 2004-07-01 |  | 50% | 359.5d | 2001-10-01 | 2004-07-01 | 719d | 1486d | finish no earlier than 2004-07-01 | T1 | 5752h | 2876h | MISTST1-TDD |  |  | 34.123-1 |  |  |
| 1811 | 15.6 | Creation of R99 TCs for TDD - TTCN | 587d | 2002-09-03 | 2004-12-01 |  |  |  | 2002-09-03 | 2004-12-01 | 587d | 1377d | finish no earlier than 2004-12-01 | T1 | 4696h |  |  |  |  |  |  |  |
| 1812 | 15.7 | Review all other work items for impact on new or exiting 34 series specs. | 25.8w | 2002-07-02 | 2002-12-27 |  |  |  | 2002-07-02 | 2002-12-27 | 25.8w | 1880d | finish no earlier than 2002-12-27 | T1 | 1032h |  | MISTST1 |  |  | 34.121,122,123,125 |  |  |
| 1813 | 46 | **Facsimile** | 89d | 2000-02-22 A | 2000-06-23 A |  | 100% |  | 2000-02-22 | 2000-06-23 | 89d |  |  | S1 | 4376h | 4376h | FAX | Rel-4 | Alain |  |  |  |
| 1814 | 46.1 | **Real Time Fax** | 89d | 2000-02-22 A | 2000-06-23 A |  | 100% |  | 2000-02-22 | 2000-06-23 | 89d |  |  | S2 | 3664h | 3664h | FAX-RT |  |  |  |  |  |
| 1815 | 46.1.1 | Terminal capabilities, AT commands | 89d | 2000-02-22 A | 2000-06-23 A |  | 100% |  | 2000-02-22 | 2000-06-23 | 89d |  | finish no earlier than 2000-06-23 | T2 | 712h | 712h |  |  |  | 21.904, 27.007 |  |  |
| 1816 | 46.1.2 | Signalling aspects (e.g. ICM) | 89d | 2000-02-22 A | 2000-06-23 A |  | 100% |  | 2000-02-22 | 2000-06-23 | 89d |  | start no earlier than 2000-02-22 | N1 | 712h | 712h |  |  |  |  |  |  |
| 1817 | 46.1.3 | Service provision | 89d | 2000-02-22 A | 2000-06-23 A |  | 100% |  | 2000-02-22 | 2000-06-23 | 89d |  | finish no earlier than 2000-06-23 | N3 | 712h | 712h |  |  |  | 23.146 |  |  |
| 1818 | 46.1.4 | Review whether service/stage 1 aspects need to be aligned | 51d | 2000-04-14 A | 2000-06-23 A |  | 100% |  | 2000-04-14 | 2000-06-23 | 51d |  | finish no earlier than 2000-12-14 | S1 | 408h | 408h |  |  |  |  |  |  |
| 1819 | 46.1.5 | Review whether architecture/stage 2 aspects need to be aligned | 51d | 2000-04-14 A | 2000-06-23 A |  | 100% |  | 2000-04-14 | 2000-06-23 | 51d |  | finish no earlier than 2000-12-14 | S2 | 408h | 408h |  |  |  |  |  |  |
| 1820 | 47 | Transparent End-to-End PS mobile streaming application | 253d | 2000-04-03 A | 2001-03-21 A |  | 100% |  | 2000-04-03 | 2001-03-21 | 253d |  | finish no earlier than 2000-12-29 | S4 | 2024h | 2024h | PSTREAM | Rel-4 | Paolo | 26.233, 26.234 |  |  |
| 1821 | 48 | **Multimedia Messaging** | 277d | 2000-02-22 A | 2001-03-14 |  | 99% | 0d | 2000-02-22 | 2001-03-14 | 277d | 0d |  | T2 | 12208h | 10661.6h | MMS | Rel-4 | Friedhelm | 22.140, 23.140 | Siemens | Josef.Laumen@SAL.SIEMENS.DE |
| 1822 | 48.1 | Definition of service requirements | 72d | 2000-02-22 A | 2000-05-31 A |  | 100% |  | 2000-02-22 | 2000-05-31 | 72d |  | start no earlier than 2000-02-22 | S1 | 576h | 576h | MMS |  |  |  |  |  |
| 1823 | 48.2 | Review of definition of service requirements | 205d | 2000-06-01 A | 2001-03-14 A | 1822 | 100% |  | 2000-06-01 | 2001-03-14 | 205d |  | finish no earlier than 2000-09-08 | T2 | 1640h | 1640h |  |  |  | 22.140, 23.140 | Siemens |  |
| 1824 | 48.3 | **Technical Realisation** | 243d | 2000-04-10 A | 2001-03-14 A |  | 100% |  | 2000-04-10 | 2001-03-14 | 243d |  |  | T2 | 7776h | 7776h |  |  |  | 22.140, 23.140 | Siemens | Josef.Laumen@SAL.SIEMENS.DE |
| 1825 | 48.3.1 | Review of definition of reference Achitecture model | 243d | 2000-04-10 A | 2001-03-14 A |  | 100% |  | 2000-04-10 | 2001-03-14 | 243d |  | finish no earlier than 2001-03-14 | T2 | 1944h | 1944h |  |  |  | 22.140, 23.140 | Siemens | Josef.Laumen@SAL.SIEMENS.DE |
| 1826 | 48.3.2 | "Fulfill Requirements of Stage 1" | 243d | 2000-04-10 A | 2001-03-14 A |  | 100% |  | 2000-04-10 | 2001-03-14 | 243d |  | finish no earlier than 2001-03-14 | T2 | 1944h | 1944h |  |  |  | 22.140, 23.140 | Siemens | Josef.Laumen@SAL.SIEMENS.DE |
| 1827 | 48.3.3 | Definition of MMS primitives in Stage 2 | 243d | 2000-04-10 A | 2001-03-14 A |  | 100% |  | 2000-04-10 | 2001-03-14 | 243d |  | finish no earlier than 2001-03-14 | T2 | 1944h | 1944h |  |  |  | 22.140, 23.140 | Siemens | Josef.Laumen@SAL.SIEMENS.DE |
| 1828 | 49 | **Transcoder-Free Operation** | 325d | 2000-01-03 A | 2001-03-30 A |  | 100% |  | 2000-01-03 | 2001-03-30 | 325d |  |  | N4 | 13040h | 13040h | TrFO | Rel-4 | Kimmo |  |  |  |
| 1829 | 49.1 | **OoBTC solution** | 325d | 2000-01-03 A | 2001-03-30 A |  | 100% |  | 2000-01-03 | 2001-03-30 | 325d |  |  | N4 | 8440h | 8440h | TRFO-OOBTC |  |  |  | NEC | Tosshiyuki Tamura (tamurato@elsf.ncos.nec.co.jp) |
| 1830 | 49.1.1 | implementation in UTRAN | 145d | 2000-09-11 A | 2001-03-30 A |  | 100% |  | 2000-09-11 | 2001-03-30 | 145d |  | finish no earlier than 2001-03-30 | R3 | 1160h | 1160h | TRFO-OOBTC-UTRAN |  |  | 25.401, 25.410, 25.413, 25.415, 23.153 | Siemens | Alexander Vesely |
| 1831 | 49.1.2 | Impact on architecture, Principles and Terminology | 210d | 2000-01-03 A | 2000-10-20 A |  | 100% |  | 2000-01-03 | 2000-10-20 | 210d |  | finish no earlier than 2000-10-20 | S2 | 1680h | 1680h |  |  |  |  |  |  |
| 1832 | 49.1.3 | Codec Negotiation between UE and MSC | 125d | 2000-08-14 A | 2001-02-02 A |  | 100% |  | 2000-08-14 | 2001-02-02 | 125d |  | finish no earlier than 2001-02-02 | N1 | 1000h | 1000h |  |  |  | 24.008, 23.009, 23.108, (29.002) | Motorola | Andrew Howell |
| 1833 | 49.1.4 | Codec Negotiation inter MSC | 125d | 2000-07-03 A | 2000-12-22 A |  | 100% |  | 2000-07-03 | 2000-12-22 | 125d |  | finish no earlier than 2000-12-22 | N4 | 1000h | 1000h |  |  |  |  |  |  |
| 1834 | 49.1.5 | Bearer establishment inter MSC | 125d | 2000-07-03 A | 2000-12-22 A |  | 100% |  | 2000-07-03 | 2000-12-22 | 125d |  | finish no earlier than 2000-12-22 | N4 | 1000h | 1000h |  |  |  | 23.153 |  |  |

Notes:
- 1806: It is believed that the current R99 test spec. can be optimised for faster overall test times
- 1807: It is believed that the current R99 test spec. can be optimised for faster overall test times
- 1808: Further test coverage of the R99 specification to cover supplementry services
- 1812: Can't start until most core specs are stable
- 1814: postponed from R99 to R00, SP-000169
- 1826: e.g. minimum set of media formats, media format conversion, personalization of MMS.
- 1828: Lead given to CN4 from CN / [DAB 28/11/00]
- 1830: moved according to NP-000575
- 1831: e.g. study cascading TrFO/TFO/TrFO
- 1832: the link to NP-000085has been deleted because refering to a R99 status sheet / One common set of codec negotiation procedures will be specified as in ID1656.
- 1833: Bearer establishment inter MSC. TS 23.153 R99 part complete. capabilities moved to annex + list of open issues
- 1834: Bearer establishment inter MSC. TS 23.153 R99 part complete. capabilities moved to annex. / See NP-000127 / Open issues: / Handling of Conference Calls; / Handling of Multi Party Supplementary Services; / Handling of Handover UMTS to GSM; / Handling of Sending a ...

| ID | WBS | Task | Type | Duration | Start | Finish | Complete | Remaining | Baseline start | Baseline finish | Baseline duration | Total slack | Constraint | Resources | Work | Actual work | Text1 | Text6 | Text8 | Text4 | Text5 |
| --- | --- | --- | --- | --- | --- | --- | --- | --- | --- | --- | --- | --- | --- | --- | --- | --- | --- | --- | --- | --- | --- |
| 1835 | 49.2 | **Speech Transcoder: Location and Control at the UMTS Core Network Border** |  | 125d | 2000-04-10 A | 2000-09-29 A | 100% |  | 2000-04-10 | 2000-09-29 | 125d |  |  | S2 | 2000h | 2000h | TRFO-STLC |  |  |  |  |
| 1836 | 49.2.1 | Transcoder at Edge |  | 125d | 2000-04-10 A | 2000-09-29 A | 100% |  | 2000-04-10 | 2000-09-29 | 125d |  | finish no earlier than 2000-09-29 | NP | 1000h | 1000h |  |  |  |  |  |
| 1837 | 50 | **GERAN improvements 1 (Gb over IP)** |  | 225d | 2000-05-09 A | 2001-03-19 A | 100% |  | 2000-05-09 | 2001-03-19 | 225d |  |  | GP | 6472h | 6472h | GEIMP1 | Rel-4 | Paolo |  |  |
| 1838 | 50.1 | **Gb over IP (Ip-fication of Gb)** |  | 225d | 2000-05-09 A | 2001-03-19 A | 100% |  | 2000-05-09 | 2001-03-19 | 225d |  |  | GP | 4672h | 4672h | GbIP |  | Paolo |  |  |
| 1839 | 50.1.1 | Concept |  | 134d | 2000-05-09 A | 2000-11-10 A | 100% |  | 2000-05-09 | 2000-11-10 | 134d |  |  | GP | 1072h | 1072h |  |  |  |  |  |
| 1840 | 50.1.2 | Changes to 08.16, 08.18 |  | 225d | 2000-05-09 A | 2001-03-19 A | 100% |  | 2000-05-09 | 2001-03-19 | 225d |  |  | GP | 1800h | 1800h |  |  |  |  |  |
| 1841 | 51 | **GERAN improvements 2 (NACC)** |  | 815d | 2000-11-06 A | 2003-12-19 | 80% | 159.32d | 2000-11-06 | 2003-12-19 | 815d | 1625d |  | GP | 24616h | 13616h | GEIMP2 | Rel-4 | Paolo |  |  |
| 1842 | 51.1 | **Gb enhancements** |  | 155d | 2000-11-06 A | 2001-06-08 A | 100% |  | 2000-11-06 | 2001-06-08 | 155d |  |  | GP | 7440h | 7440h | Gben |  | Paolo |  |  |
| 1843 | 51.1.1 | **Intra BSC NACC (Network Assisted Cell Change)** |  | 155d | 2000-11-06 A | 2001-06-08 A | 100% |  | 2000-11-06 | 2001-06-08 | 155d |  |  | GP | 6200h | 6200h |  |  |  |  |  |
| 1844 | 51.1.1.1 | Concept |  | 155d | 2000-11-06 A | 2001-06-08 A | 100% |  | 2000-11-06 | 2001-06-08 | 155d |  | finish no earlier than 2001-06-08 | GP | 1240h | 1240h |  |  |  |  |  |
| 1845 | 51.1.1.2 | Changes in 03.64 |  | 155d | 2000-11-06 A | 2001-06-08 A | 100% |  | 2000-11-06 | 2001-06-08 | 155d |  | finish no earlier than 2001-06-08 | GP | 1240h | 1240h |  |  |  |  |  |
| 1846 | 51.1.1.3 | Changes in 04.60 |  | 155d | 2000-11-06 A | 2001-06-08 A | 100% |  | 2000-11-06 | 2001-06-08 | 155d |  | finish no earlier than 2001-06-08 | GP | 1240h | 1240h |  |  |  |  |  |
| 1847 | 51.1.1.4 | Changes in 44.008 |  | 155d | 2000-11-06 A | 2001-06-08 A | 100% |  | 2000-11-06 | 2001-06-08 | 155d |  | finish no earlier than 2001-06-08 | GP | 1240h | 1240h |  |  |  |  |  |
| 1848 | 51.2 | Start Testing | milestone | 0d | 2001-06-04 | 2001-06-04 |  |  | 2001-06-04 | 2001-06-04 | 0d | 2290d | start no earlier than 2001-06-04 |  |  |  |  |  |  |  |  |
| 1849 | 51.3 | **MS conformance test for Intra BSC NACC** |  | 536d | 2001-11-30 A | 2003-12-19 | 50% | 268d | 2001-11-30 | 2003-12-19 | 536d | 1625d |  | GP | 10656h | 5328h | GEIMP2-Msconf |  |  |  |  |
| 1850 | 51.3.1 | Changes in 51.010 |  | 398d | 2001-11-30 A | 2003-12-19 | 50% | 199d | 2001-11-30 | 2003-12-19 | 398d | 1625d | finish no earlier than 2003-12-19 | G5; G4 | 6368h | 3184h |  |  |  |  |  |
| 1851 | 52 | **GERAN improvements 4 (Delayed TBF)** |  | 105d | 2001-01-15 A | 2001-06-08 A | 100% |  | 2001-01-15 | 2001-06-08 | 105d |  |  | GP | 3960h | 3960h | GEIMP4 | Rel-4 | Paolo |  |  |
| 1852 | 52.1 | **Gb enhancements 2** |  | 105d | 2001-01-15 A | 2001-06-08 A | 100% |  | 2001-01-15 | 2001-06-08 | 105d |  |  | GP | 3120h | 3120h | GEIMP4-Gben2 |  |  |  |  |
| 1853 | 52.1.1 | stage 2 |  | 105d | 2001-01-15 A | 2001-06-08 A | 100% |  | 2001-01-15 | 2001-06-08 | 105d |  | finish no earlier than 2001-06-08 | GP | 840h | 840h |  |  |  |  |  |
| 1854 | 52.1.2 | **Stage 3 (changes in 44.060)** |  | 60d | 2001-01-15 A | 2001-04-06 A | 100% |  | 2001-01-15 | 2001-04-06 | 60d |  |  | G2 | 1440h | 1440h |  |  |  |  |  |
| 1855 | 52.1.2.1 | Definition of enhanced countdown procedure |  | 60d | 2001-01-15 A | 2001-04-06 A | 100% |  | 2001-01-15 | 2001-04-06 | 60d |  | finish no earlier than 2001-04-06 | G2 | 480h | 480h |  |  |  |  |  |
| 1856 | 52.1.2.2 | Definition of enhanced TBF release procedure |  | 60d | 2001-01-15 A | 2001-04-06 A | 100% |  | 2001-01-15 | 2001-04-06 | 60d |  | finish no earlier than 2001-04-06 | G2 | 480h | 480h |  |  |  |  |  |
| 1857 | 52.1.2.3 | Definition of USF=FREE type polling mechanism on PDCH |  | 60d | 2001-01-15 A | 2001-04-06 A | 100% |  | 2001-01-15 | 2001-04-06 | 60d |  | finish no earlier than 2001-04-06 | G2 | 480h | 480h |  |  |  |  |  |
| 1858 | 53 | **Low Chip Rate TDD option** |  | 880d | 2000-07-19 A | 2003-12-02 | 76% | 208.03d | 2000-07-19 | 2003-12-02 | 880d | 1638d |  | R1 | 25872h | 19687.3h | LCRTDD | Rel-4 | Tsukasa | CWTS | G. Yang |
| 1859 | 53.1 | Physical layer |  | 183d | 2000-07-19 A | 2001-03-30 A | 100% |  | 2000-07-19 | 2001-03-30 | 183d |  | finish no earlier than 2001-03-30 | R1 | 1464h | 1464h | LCRTDD-Phys |  |  | CWTS | G. Yang |
| 1860 | 53.2 | Layer 2 and layer 3 protocol aspects |  | 183d | 2000-07-19 A | 2001-03-30 A | 100% |  | 2000-07-19 | 2001-03-30 | 183d |  | finish no earlier than 2001-03-30 | R2 | 1464h | 1464h | LCRTDD-L23 |  |  | CWTS | Y. Liu |
| 1861 | 53.3 | RF radio transmission/reception, system performance requirements and conformance testing |  | 165d | 2000-08-14 A | 2001-03-30 A | 100% |  | 2000-08-14 | 2001-03-30 | 165d |  | finish no earlier than 2001-03-30 | R4 | 1320h | 1320h | LCRTDD-RF |  |  | CWTS | D. Zhang |
| 1862 | 53.4 | UE radio access capability |  | 165d | 2000-08-14 A | 2001-03-30 A | 100% |  | 2000-08-14 | 2001-03-30 | 165d |  | finish no earlier than 2001-03-30 | R2 | 1320h | 1320h | LCRTDD-UErac |  |  | CWTS | Y. Liu |
| 1863 | 53.5 | Iub/Iur protocol aspects |  | 165d | 2000-08-14 A | 2001-03-30 A | 100% |  | 2000-08-14 | 2001-03-30 | 165d |  | finish no earlier than 2001-03-30 | R3 | 1320h | 1320h | LCRTDD-IubIur |  |  | CWTS | Y. Liu |

Notes:
- 1835: WI description and Tdoc S2-99352 / Speech Transcoder: Location and Control at the UMTS Core Network Border
- 1836: WI description and Tdoc S2-99352...
- 1849: Started
- 1850: 50099 -> 50299

| ID | WBS | Task | Type | Duration | Start | Finish | Predecessors | Complete | Remaining | Baseline start | Baseline finish | Baseline duration | Total slack | Free slack | Constraint | Resources | Work | Actual work | Text8 | Text3 | Text1 | Text4 | Text5 | Text6 |
| --- | --- | --- | --- | --- | --- | --- | --- | --- | --- | --- | --- | --- | --- | --- | --- | --- | --- | --- | --- | --- | --- | --- | --- | --- |
| 1864 | 53.6 | **Low chiprate TDD interworking with GERAN** |  | 101d | 2000-09-01 A | 2001-01-19 A | 1863 | 100% |  | 2000-09-01 | 2001-01-19 | 101d |  |  |  |  |  |  | Paolo |  |  |  |  |  |
| 1865 | 53.6.1 | Handover and Cell Selection / Reselection to UTRA 1.28 Mcps TDD |  | 101d | 2000-09-01 A | 2001-01-19 A |  | 100% |  | 2000-09-01 | 2001-01-19 | 101d |  |  | finish no earlier than 2001-01-19 |  |  |  |  |  |  |  |  |  |
| 1866 | 53.7 | Start Testing | milestone | 0d | 2001-09-03 | 2001-09-03 | 1864 |  |  | 2001-09-03 | 2001-09-03 | 0d | 1948.11d | 10d | start no earlier than 2001-09-03 | MLST |  |  |  |  |  |  |  |  |
| 1867 | 53.8 | **Conformance Test Aspects - Low Chip Rate TDD** |  | 577d | 2001-09-17 A | 2003-12-02 | 1866 | 52% | 276.89d | 2001-09-17 | 2003-12-02 | 577d | 1638d |  |  | T1 | 12088h | 6287.32h |  | 0% |  |  |  |  |
| 1868 | 53.8.1 | Testing Layer 2 and layer 3 protocol aspects |  | 468d | 2001-09-17 A | 2003-07-02 |  | 60% | 187.2d | 2001-09-17 | 2003-07-02 | 468d | 1747d |  | finish no earlier than 2003-07-02 | T1 | 3744h | 2246.4h |  | 34.123-1, 34.123-2 |  |  |  |  |
| 1869 | 53.8.2 | Testing Layer 2 and layer 3 protocol aspects - TTCN |  | 261d | 2002-12-03 | 2003-12-02 |  |  |  | 2002-12-03 | 2003-12-02 | 261d | 1638d |  | finish no earlier than 2003-12-02 | T1 | 2088h |  |  | 34.123-3 |  |  |  |  |
| 1870 | 53.8.3 | Testing RF Radio Transmission and Reception |  | 205d | 2001-09-17 A | 2002-06-28 A |  | 100% |  | 2001-09-17 | 2002-06-28 | 205d |  |  | finish no earlier than 2002-06-28 | T1 | 1640h | 1640h |  |  |  |  |  |  |
| 1871 | 54 | **Enable bearer independent CS architecture** |  | 565d | 2000-01-03 A | 2002-03-01 |  | 80% | 114.5d | 2000-01-03 | 2002-03-01 | 565d | 2095d |  |  | S2 | 20176h | 17180h | Kimmo |  | CSSPLIT | Siemens | Alexander Milinski | Rel-4 |
| 1872 | 54.1 | **Enable bearer-independent call control** |  | 424d | 2000-01-03 A | 2001-08-16 A |  | 100% |  | 2000-01-03 | 2001-08-16 | 424d |  |  |  | N4 | 12336h | 12336h |  |  |  | Ericsson | Heinz-Peter.Keutmann@eed.ericsson.se |  |
| 1873 | 54.1.1 | Architecture and Stage 2 description |  | 180d | 2000-01-03 A | 2000-09-08 A |  | 100% |  | 2000-01-03 | 2000-09-08 | 180d |  |  | finish no earlier than 2000-09-08 | S2 | 1440h | 1440h |  | 23.002 |  |  |  |  |
| 1874 | 54.1.2 | Standardisation of protocols (control & user planes) over Nb interface |  | 64d | 2001-01-02 A | 2001-03-30 A |  | 100% |  | 2001-01-02 | 2001-03-30 | 64d |  |  | finish no earlier than 2001-03-30 | N3 | 512h | 512h |  |  |  |  |  |  |
| 1875 | 54.1.3 | Standardisation of protocols over reference points between MSC server and Gateway MSC server |  | 130d | 2000-09-25 A | 2001-03-23 A |  | 100% |  | 2000-09-25 | 2001-03-23 | 130d |  |  | finish no earlier than 2001-03-23 | N4 | 1040h | 1040h |  |  |  |  |  |  |
| 1876 | 54.1.4 | Standardisation of detailed stage 2 description |  | 180d | 2000-07-17 A | 2001-03-23 A |  | 100% |  | 2000-07-17 | 2001-03-23 | 180d |  |  | finish no earlier than 2001-03-23 | N4 | 1440h | 1440h |  |  |  |  |  |  |
| 1877 | 54.1.5 | **Bearer control between MSC server and MGW** |  | 250d | 2000-09-01 A | 2001-08-16 A |  | 100% |  | 2000-09-01 | 2001-08-16 | 250d |  |  |  | N4 | 4512h | 4512h |  |  |  |  |  |  |
| 1878 | 54.1.5.1 | stage 3 - protocol issues |  | 250d | 2000-09-01 A | 2001-08-16 A |  | 100% |  | 2000-09-01 | 2001-08-16 | 250d |  |  | finish no earlier than 2001-08-16 | N4 | 2000h | 2000h |  |  |  |  |  |  |
| 1879 | 54.1.5.2 | stage 3 - parameter value issues |  | 64d | 2001-01-02 A | 2001-03-30 A |  | 100% |  | 2001-01-02 | 2001-03-30 | 64d |  |  | finish no earlier than 2001-03-30 | N3 | 512h | 512h |  |  |  |  |  |  |
| 1880 | 54.2 | Lawful interception |  | 155d | 2000-08-21 A | 2001-03-23 A |  | 100% |  | 2000-08-21 | 2001-03-23 | 155d |  |  | finish no earlier than 2001-03-23 | S3 | 1240h | 1240h |  |  |  |  |  |  |
| 1881 | 54.3 | Start Testing | milestone | 0d | 2001-03-05 | 2001-03-05 |  |  |  | 2001-03-05 | 2001-03-05 | 0d | 2095d | 0d | start no earlier than 2001-03-05 | MLST |  |  |  |  |  |  |  |  |
| 1882 | 54.4 | Conformance Test Aspects - Enable bearer independent CS architecture |  | 260d | 2001-03-05 | 2002-03-01 | 1881 |  |  | 2001-03-05 | 2002-03-01 | 260d | 2095d |  |  | T1 | 2080h |  |  | 0% | CSSPLIT-TEST |  |  |  |
| 1883 | 55 | **MExE enhancements Rel-4** |  | 510d | 2000-01-03 A | 2001-12-14 A |  | 100% |  | 2000-01-03 | 2001-12-14 | 510d |  |  |  | T2 | 19024h | 19024h | Friedhelm |  | MEXE |  |  | Rel-4 |
| 1884 | 55.1 | **MExE Security Analysis Activity** |  | 474d | 2000-02-22 A | 2001-12-14 A |  | 100% |  | 2000-02-22 | 2001-12-14 | 474d |  |  |  | S3 | 8464h | 8464h |  |  | MEXE-SEC | BT | colin.blanchard@bt.com |  |
| 1885 | 55.1.1 | Stage 3 |  | 370d | 2000-07-17 A | 2001-12-14 A |  | 100% |  | 2000-07-17 | 2001-12-14 | 370d |  |  | finish no earlier than 2001-12-14 | S3 | 2960h | 2960h |  |  | MEXE1-SEC |  |  |  |
| 1886 | 55.1.2 | Terminal aspects |  | 214d | 2000-02-22 A | 2000-12-15 A |  | 100% |  | 2000-02-22 | 2000-12-15 | 214d |  |  | finish no earlier than 2000-12-15 | T2 | 1712h | 1712h |  |  |  |  |  |  |
| 1887 | 55.2 | **MExE Rel4 Improvements and Investigations** |  | 250d | 2000-01-03 A | 2000-12-15 A |  | 100% |  | 2000-01-03 | 2000-12-15 | 250d |  |  |  | T2 | 6480h | 6480h |  | 22.057, 23.057 | MEXE-ENHANC | Motorola | Mark Cataldo (mcatald1@email.mot.com) |  |
| 1888 | 55.2.1 | 3rd MExE classmark |  | 250d | 2000-01-03 A | 2000-12-15 A |  | 100% |  | 2000-01-03 | 2000-12-15 | 250d |  |  | finish no earlier than 2000-12-15 | T2 | 2000h | 2000h |  | 22.057, 23.057 |  | Motorola | Mark Cataldo (mcatald1@email.mot.com) |  |
| 1889 | 55.2.2 | FS on Secure download mechanism and capabilities to support SDR concepts |  | 225d | 2000-02-07 A | 2000-12-15 A |  | 100% |  | 2000-02-07 | 2000-12-15 | 225d |  |  | finish no earlier than 2000-12-15 | T2 | 1800h | 1800h |  | 22.057, 23.057 |  | Motorola | Mark Cataldo (mcatald1@email.mot.com) |  |
| 1890 | 55.2.3 | FS on Support of MP3/MPEG4 content |  | 225d | 2000-02-07 A | 2000-12-15 A |  | 100% |  | 2000-02-07 | 2000-12-15 | 225d |  |  | finish no earlier than 2000-12-15 | T2 | 1800h | 1800h |  | 22.057, 23.057 |  | Motorola | Mark Cataldo (mcatald1@email.mot.com) |  |

Notes:
- 1868: duration set to 6 months (was 0)
- 1870: duration set to 6 months (was 0), finish date set
- 1872: DAB 12.12.01 should be 100% hence closed
- 1873: R00 stage 2 at least 80 % complete in TSGS #8 21.-23.6.2000
- 1880: Requirements capture: S3#14 (Aug 00), Feature specification: S3#15 (Sep 00), Definition of architecture. Should be included in general LI work mentioned above.
- 1884: Presentation to S3 of threats and countermeasures analysis: S3#15, Feature specification: S3#16. S3#18: WID updated
- 1885: Analysis undertaken by T2. No additional analysis needed for Rel-4
- 1888: Additional features for MExE R2000

| ID | WBS | Task | Duration | Start | Finish | Complete | Remaining | Baseline start | Baseline finish | Baseline duration | Total slack | Constraint | Resources | Work | Actual work | Text1 | Text6 | Text8 | Text3 | Text4 | Text5 |
| --- | --- | --- | --- | --- | --- | --- | --- | --- | --- | --- | --- | --- | --- | --- | --- | --- | --- | --- | --- | --- | --- |
| 1891 | 56 | **Tandem Free aspects for 3G and between 2G and 3G systems** | 344d | 2000-02-22 A | 2001-06-15 A | 100% |  | 2000-02-22 | 2001-06-15 | 344d |  |  | S4 | 9696h | 9696h | TFO | Rel-4 | Paolo |  |  |  |
| 1892 | 56.1 | **Tandem Free AMR** | 344d | 2000-02-22 A | 2001-06-15 A | 100% |  | 2000-02-22 | 2001-06-15 | 344d |  |  | S4 | 6944h | 6944h | TFO-AMR |  |  |  |  |  |
| 1893 | 56.1.1 | Specification | 284d | 2000-02-22 A | 2001-03-23 A | 100% |  | 2000-02-22 | 2001-03-23 | 284d |  | start no earlier than 2000-02-22 | S4 | 2272h | 2272h |  |  |  | 28.062 |  |  |
| 1894 | 56.1.2 | **Impact on:** | 115d | 2001-01-08 A | 2001-06-15 A | 100% |  | 2001-01-08 | 2001-06-15 | 115d |  |  | NP | 1920h | 1920h |  |  |  |  |  |  |
| 1895 | 56.1.2.1 | CN | 60d | 2001-03-26 A | 2001-06-15 A | 100% |  | 2001-03-26 | 2001-06-15 | 60d |  | finish no earlier than 2001-06-15 | NP | 480h | 480h |  |  |  |  |  |  |
| 1896 | 56.1.2.2 | GERAN | 65d | 2001-01-08 A | 2001-04-06 A | 100% |  | 2001-01-08 | 2001-04-06 | 65d |  | finish no earlier than 2001-04-06 | GP | 520h | 520h |  |  |  |  |  |  |
| 1897 | 57 | **Advanced Speech Call Items enhancements_REL-4** | 334d | 2000-12-03 A | 2002-03-14 A | 100% |  | 2000-12-03 | 2002-03-14 | 334d |  |  | N1 | 5925.6h | 5925.6h | ASCI | Rel-4 | Per |  | Nortel | sonia.garapaty@nortelnetworks.com |
| 1898 | 57.1 | Stage 2 | 326.7d | 2000-12-03 A | 2002-03-14 A | 100% |  | 2000-12-03 | 2002-03-14 | 326.7d |  | finish no earlier than 2002-03-14 | N4 | 2613.6h | 2613.6h |  |  | Kimmo | 23.067, 24.067 | Sagem | Vivien Perlic |
| 1899 | 57.2 | Stages 2 and 3 on A interface | 80d | 2000-12-03 A | 2001-03-23 A | 100% |  | 2000-12-03 | 2001-03-23 | 80d |  | finish no earlier than 2001-03-23 | N1 | 640h | 640h |  |  | Per | 44.068, 44.069, 24.008 | Nortel | sonia.garapaty@nortelnetworks.com |
| 1900 | 58 | **700 MHz spectrum support** | 775d | 2000-01-03 A | 2002-12-20 A | 100% |  | 2000-01-03 | 2002-12-20 | 775d |  |  | GP | 25000h | 25000h | 700SS | Rel-4 | Paolo |  |  |  |
| 1901 | 58.1 | **GERAN support for the 700 MHz band** | 275d | 2000-01-03 A | 2001-01-19 A | 100% |  | 2000-01-03 | 2001-01-19 | 275d |  |  | GP | 8800h | 8800h |  |  |  |  |  |  |
| 1902 | 58.1.1 | Signalling support | 275d | 2000-01-03 A | 2001-01-19 A | 100% |  | 2000-01-03 | 2001-01-19 | 275d |  | finish no earlier than 2001-01-19 | GP | 2200h | 2200h |  |  |  |  |  |  |
| 1903 | 58.1.2 | Physical layer definitions | 275d | 2000-01-03 A | 2001-01-19 A | 100% |  | 2000-01-03 | 2001-01-19 | 275d |  | finish no earlier than 2001-01-19 | GP | 2200h | 2200h |  |  |  |  |  |  |
| 1904 | 58.1.3 | Receiver performance and RF budget | 275d | 2000-01-03 A | 2001-01-19 A | 100% |  | 2000-01-03 | 2001-01-19 | 275d |  | finish no earlier than 2001-01-19 | GP | 2200h | 2200h |  |  |  |  |  |  |
| 1905 | 58.2 | **GERAN MS Conformance test for 700 MHz band** | 175d | 2001-04-02 A | 2001-11-30 A | 100% |  | 2001-04-02 | 2001-11-30 | 175d |  |  | GP | 2800h | 2800h |  |  |  |  |  |  |
| 1906 | 58.2.1 | MS test | 175d | 2001-04-02 A | 2001-11-30 A | 100% |  | 2001-04-02 | 2001-11-30 | 175d |  | finish no earlier than 2001-11-30 | GP | 1400h | 1400h |  |  |  |  |  |  |
| 1907 | 58.3 | **GERAN BTS Conformance test for 700 MHz band** | 450d | 2001-04-02 A | 2002-12-20 A | 100% |  | 2001-04-02 | 2002-12-20 | 450d |  |  | GP | 7200h | 7200h |  |  | Paolo |  |  |  |
| 1908 | 58.3.1 | BTS test | 450d | 2001-04-02 A | 2002-12-20 A | 100% |  | 2001-04-02 | 2002-12-20 | 450d |  | finish no earlier than 2002-12-20 | GP | 3600h | 3600h |  |  |  |  |  |  |
| 1909 | 59 | Operator Determined Barring for Packet Oriented Services | 208d | 2000-06-01 A | 2001-03-19 A | 100% |  | 2000-06-01 | 2001-03-19 | 208d |  | finish no earlier than 2001-03-19 | NP | 1664h | 1664h | ODB | Rel-4 |  |  | NEC | Toshiyuki Tamura (tamurato@nsf.ncos.nec.co.jp) |
| 1910 | 60 | **UMTS QoS Architecture for PS Domain** | 758d | 2000-01-03 A | 2002-11-27 | 61% | 295.18d | 2000-01-03 | 2002-11-27 | 758d | 1902d |  | S2 | 54256h | 20605.3h | QoSPS | Rel-4 |  |  | Ericsson | Ina.widegren@era.ericsson.se |
| 1911 | 60.1 | Architecture | 153d | 2000-06-05 A | 2001-01-03 A | 100% |  | 2000-06-05 | 2001-01-03 | 153d |  | finish no earlier than 2001-01-03 | S2 | 1224h | 1224h |  |  |  | 23.107 |  |  |
| 1912 | 60.2 | Charging and OAM&P for QoS Management | 201d | 2001-09-21 A | 2002-06-28 A | 100% |  | 2001-09-21 | 2002-06-28 | 201d |  | finish no earlier than 2002-06-28 | S5 | 1608h | 1608h | QoSPS-OAM |  |  | 32-series | VoiceStream, Motorola | Albert.Yuhan@voicestream.com; Michael.Truss@MOTOROLA.COM |
| 1913 | 60.3 | **RAB Quality of Service (re)Negotiation over Iu** | 155d | 2000-08-21 A | 2001-03-23 | 99% | 0d | 2000-08-21 | 2001-03-23 | 155d | 0d |  | R3 | 3648h | 2501.6h | QoSPS-MAPEND-RABQoS |  |  | 25.413 | Ericsson | A. Molander |
| 1914 | 60.3.1 | RAB Quality of Service Negotiation over Iu | 155d | 2000-08-21 A | 2001-03-23 A | 100% |  | 2000-08-21 | 2001-03-23 | 155d |  | finish no earlier than 2001-03-23 | R3 | 1240h | 1240h | QoSPS-MAPEND-RABQoS-Negot |  |  |  | Ericsson | A. Molander |
| 1915 | 60.3.2 | RAB Quality of Service Negotiation over Iu during relocation | 16d | 2001-03-02 A | 2001-03-23 A | 100% |  | 2001-03-02 | 2001-03-23 | 16d |  | start no earlier than 2001-03-02 | R3 | 128h | 128h | QoSPS-MAPEND-RABQoS-NegotReloc |  |  |  |  |  |
| 1916 | 60.3.3 | RAB Quality of Service Re-Negotiation over Iu | 130d | 2000-09-25 A | 2001-03-23 A | 100% |  | 2000-09-25 | 2001-03-23 | 130d |  | finish no earlier than 2001-03-23 | R3 | 1040h | 1040h | QoSPS-MAPEND-RABQoS-ReNegot |  |  |  | Motorola | S. Irwin |

Notes:
- 1891: RAN and CN to verify no problems for GSM terminals roaming in 3G R99
- 1892: RAN and CN to verify UMTS_AMR_2 support
- 1894: "Implementation" changed to "Impact on:" by A. Sultan (for better wording)
- 1895: RAN and CN to verify UMTS_AMR_2 support
- 1896: End date Modified from June to March to have it in Rel4
- 1897: Approved in TSGN_10
- 1898: CN4#11 30/11/02: no inputs received in CN4
- 1909: Completed WI missing from the P-plan Added for tracking

| ID | WBS | Task | Duration | Start | Finish | Complete | Remaining | Baseline start | Baseline finish | Baseline duration | Total slack | Constraint | Resources | Work | Actual work | Text1 | Text8 | Text4 | Text5 | Text3 | Text6 |
| --- | --- | --- | --- | --- | --- | --- | --- | --- | --- | --- | --- | --- | --- | --- | --- | --- | --- | --- | --- | --- | --- |
| 1917 | 60.4 | **GERAN QoS Aspects - Handovers: maintenance of real-time QoS while moving between cells in the PLMN including inter-SGSN and SRNS relocation or possibly other mechanisms** | 500d | 2000-01-03 A | 2001-11-30 | 99% | 0d | 2000-01-03 | 2001-11-30 | 500d | 0d |  | GP | 14440h | 10544h | GERQoS | Paolo |  |  |  |  |
| 1918 | 60.4.1 | **Handover Concept for the PS domain** | 500d | 2000-01-03 A | 2001-11-30 | 99% | 0d | 2000-01-03 | 2001-11-30 | 500d | 0d |  | GP | 10440h | 6544h |  |  |  |  |  |  |
| 1919 | 60.4.1.1 | Stable RT handover report 25.936 including header removal | 13d | 2000-01-03 A | 2000-01-19 A | 100% |  | 2000-01-03 | 2000-01-19 | 13d |  | start no earlier than 2000-01-03 | GP | 104h | 104h |  |  |  |  |  |  |
| 1920 | 60.4.1.2 | Update of stage 2 | 292d | 2000-01-03 A | 2001-02-13 A | 100% |  | 2000-01-03 | 2001-02-13 | 292d |  | finish no earlier than 2001-02-13 | GP | 2336h | 2336h |  |  |  |  |  |  |
| 1921 | 60.4.1.3 | Update of relevant stage 3 specs -> RRC | 500d | 2000-01-03 A | 2001-11-30 A | 100% |  | 2000-01-03 | 2001-11-30 | 500d |  | finish no earlier than 2001-11-30 | G2 | 4000h | 4000h |  |  |  |  |  |  |
| 1922 | 60.5 | **GERAN MS Conformance test for inter-system and intra-system Packet data real-time Handover** | 324d | 2001-08-31 | 2002-11-27 |  |  | 2001-08-31 | 2002-11-27 | 324d | 1902d |  | G4; R3 | 25920h |  | GERQoS-Mstest |  |  |  |  |  |
| 1923 | 60.5.1 | **Handover for the PS domain** | 324d | 2001-08-31 | 2002-11-27 |  |  | 2001-08-31 | 2002-11-27 | 324d | 1902d |  | G4; R3 | 20736h |  |  |  |  |  |  |  |
| 1924 | 60.5.1.1 | Stable RT handover report 25.936 including header removal | 324d | 2001-08-31 | 2002-11-27 |  |  | 2001-08-31 | 2002-11-27 | 324d | 1902d | finish no earlier than 2002-11-27 | G4; R3 | 5184h |  |  |  |  |  |  |  |
| 1925 | 60.5.1.2 | Update of stage 2 | 324d | 2001-08-31 | 2002-11-27 |  |  | 2001-08-31 | 2002-11-27 | 324d | 1902d | finish no earlier than 2002-11-27 | G4; R3 | 5184h |  |  |  |  |  |  |  |
| 1926 | 60.5.1.3 | Update of relevant stage 3 specs | 324d | 2001-08-31 | 2002-11-27 |  |  | 2001-08-31 | 2002-11-27 | 324d | 1902d | finish no earlier than 2002-11-27 | G4; R3 | 5184h |  |  |  |  |  |  |  |
| 1927 | 60.6 | PS-domain handover for real-time services | 155d | 2000-08-28 A | 2001-03-30 A | 100% |  | 2000-08-28 | 2001-03-30 | 155d |  | finish no earlier than 2001-03-30 | R3 | 1240h | 1240h | QoSPS-PSdoRTS |  | Nokia | A. Lansisalmi |  |  |
| 1928 | 60.7 | RAB QoS Renegotiation at Relocation | 58d | 2001-01-03 | 2001-03-23 |  |  | 2001-01-03 | 2001-03-23 | 58d | 2340d | finish no earlier than 2001-03-23 | R3 | 464h |  |  |  |  |  | 25.851, 25.946 |  |
| 1929 | 61 | **small Technical Enhancements and Improvements for Rel4** | 2177d? | 2000-01-03 A | 2008-05-06 A | 100% |  | 2000-01-03 | 2008-05-06 | 2177d? |  |  | Generic | 21440h | 21440h | TEI4 |  |  |  |  | Rel-4 |
| 1930 | 1.436.1 | Small Technical Enhancements and Improvements for Rel-4 Conformance Testing | 503d? | 2000-01-03 A | 2008-05-06 A | 100% |  | 2000-01-03 | 2008-05-06 | 503d? |  | finish no earlier than 2008-12-31 | R5 | 4024h | 4024h | TEI4_Test | Stoyan Baev |  |  |  | Rel-4 |
| 1931 | 62 | **Rel-4 Evolutions of the transport in the UTRAN** | 525d | 2000-08-21 A | 2002-08-23 | 69% | 162.5d | 2000-08-21 | 2002-08-23 | 525d | 1970d |  | RP | 8600.02h | 6501.38h | ETRAN | Joern | Alcatel | Francois Courau |  | NA |
| 1932 | 62.1 | QoS optimisation for AAL2 connections over Iub and Iur interfaces | 160d | 2000-08-21 A | 2001-03-30 A | 100% |  | 2000-08-21 | 2001-03-30 | 160d |  | finish no earlier than 2001-03-30 | R3 | 1280h | 1280h | ETRAN-QoSAAL2 |  | Japan Telecom | T. Yoshimura |  | Rel-4 |
| 1933 | 62.2 | Transport bearer modification procedure on Iub, Iur, and Iu | 130d | 2000-10-02 A | 2001-03-30 A | 100% |  | 2000-10-02 | 2001-03-30 | 130d |  | finish no earlier than 2001-03-30 | R3 | 1040h | 1040h | ETRAN-MigrMod |  | Japan Telecom | T. Yoshimura |  | Rel-4 |
| 1934 | 62.3 | **Conformance Test Aspects of Rel-4 evolutions of the transport in UTRAN** | 130d | 2002-02-25 | 2002-08-23 |  |  | 2002-02-25 | 2002-08-23 | 130d | 1970d |  | T1 | 2080h |  |  |  |  |  |  |  |
| 1935 | 62.3.1 | Testing RAB support enhancements | 130d | 2002-02-25 | 2002-08-23 |  |  | 2002-02-25 | 2002-08-23 | 130d | 1970d | finish no earlier than 2002-08-23 | T1 | 1040h |  | CT-RABS? |  |  |  | 34.108, 34. 121, 34.122, 34.123 p 1,2, 34.123 pt 3 |  |
| 1936 | 63 | **Rel-4 Evolutions of the transport in the CN** | 215d | 2000-05-29 A | 2001-03-23 A | 100% |  | 2000-05-29 | 2001-03-23 | 215d |  |  | N4 | 7968h | 7968h | CNTRSP | Kimmo |  |  |  | NA |
| 1937 | 63.1 | **IP Transport of CN protocols (e.g., CAP, MAP)** | 77d | 2000-12-07 A | 2001-03-23 A | 100% |  | 2000-12-07 | 2001-03-23 | 77d |  |  | N4 | 2808h | 2808h | SS7IP |  |  |  |  | Rel-4 |
| 1938 | 63.1.1 | **Stage 3** | 77d | 2000-12-07 A | 2001-03-23 A | 100% |  | 2000-12-07 | 2001-03-23 | 77d |  |  | N4 | 2192h | 2192h |  |  |  |  |  |  |
| 1939 | 63.1.1.1 | CAP | 77d | 2000-12-07 A | 2001-03-23 A | 100% |  | 2000-12-07 | 2001-03-23 | 77d |  | finish no earlier than 2001-03-23 | N2 | 616h | 616h |  |  |  |  |  |  |
| 1940 | 63.1.1.2 | MAP | 77d | 2000-12-07 A | 2001-03-23 A | 100% |  | 2000-12-07 | 2001-03-23 | 77d |  | finish no earlier than 2001-03-23 | N4 | 616h | 616h |  |  |  |  |  |  |
| 1941 | 63.1.1.3 | BSSAP+ | 43d | 2001-01-15 A | 2001-03-14 A | 100% |  | 2001-01-15 | 2001-03-14 | 43d |  | finish no earlier than 2001-03-14 | N1 | 344h | 344h | SS7IP-BSSAP+ |  |  |  |  |  |

Notes:
- 1922: Still exist? To be clarified by GERAN4/5
- 1929: "Joker" WI, to be used for a Rel 4 CR not related to any feature and with very limited impact on the system
- 1930: "Joker" WI, to be used for small modifications applicable to Rel 4 conformance testing. Moved in from the Stoyan/Testing WP
- 1935: Requires supporting companies
- 1936: WI formulation assigned to N4
- 1937: AS: corrected to Rel4 as stated at SA#10

| ID | WBS | Task | Type | Duration | Start | Finish | Predecessors | Complete | Remaining | Baseline start | Baseline finish | Baseline duration | Total slack | Free slack | Constraint | Resources | Work | Actual work | Text4 | Text5 | Text6 | Text1 | Text8 | Text3 |
| --- | --- | --- | --- | --- | --- | --- | --- | --- | --- | --- | --- | --- | --- | --- | --- | --- | --- | --- | --- | --- | --- | --- | --- | --- |
| 1942 | 63.2 | **FS on Transport and control separation in the PS CN domain** |  | 215d | 2000-05-29 A | 2001-03-23 A |  | 100% |  | 2000-05-29 | 2001-03-23 | 215d |  |  |  | S2 | 3440h | 3440h | Ericsson | Juan-Antonio.Ibanez@eed.ericsson.se | Rel-4 |  |  |  |
| 1943 | 63.2.1 | Architectural impacts |  | 215d | 2000-05-29 A | 2001-03-23 A |  | 100% |  | 2000-05-29 | 2001-03-23 | 215d |  |  | finish no earlier than 2001-03-23 | S2 | 1720h | 1720h |  |  |  |  |  |  |
| 1944 | 64 | **Rel-4 Improvements of Radio Interface** |  | 700d | 2000-07-10 A | 2003-03-14 |  | 83% | 117.46d | 2000-07-10 | 2003-03-14 | 700d | 1825d |  |  | RP | 28624h | 23247.4h |  |  | NA | RInImp | Tsukasa |  |
| 1945 | 64.1 | UTRA repeater specification (master) |  | 183d | 2000-07-10 A | 2001-03-21 A |  | 100% |  | 2000-07-10 | 2001-03-21 | 183d |  |  | finish no earlier than 2001-03-21 | R4 | 1464h | 1464h | Mikom, Allgon | T. Kummetz, Mikom; Alf Ahlström, Allgon | Rel-4 | RInImp-REP |  |  |
| 1946 | 64.2 | DSCH power control improvement in soft handover |  | 140d | 2000-09-11 A | 2001-03-23 A |  | 100% |  | 2000-09-11 | 2001-03-23 | 140d |  |  | finish no earlier than 2001-03-23 | R1 | 1120h | 1120h | Nokia | A. Toskala | Rel-4 | RInImp-DSCHsho |  |  |
| 1947 | 64.3 | UMTS 1800 |  | 320d | 2000-09-25 A | 2001-12-14 A |  | 100% |  | 2000-09-25 | 2001-12-14 | 320d |  |  | finish no earlier than 2001-12-14 | R4 | 2560h | 2560h | Motorola | H. Benn | Rel indep | RInImp-UMTS18 |  |  |
| 1948 | 64.4 | UMTS 1900 |  | 195d | 2001-03-19 A | 2001-12-14 A |  | 100% |  | 2001-03-19 | 2001-12-14 | 195d |  |  | finish no earlier than 2001-12-14 | R4 | 1560h | 1560h | Motorola | Howard Benn | Rel indep | RInImp-UMTS19 | Cesar |  |
| 1949 | 64.5 | FS on High Speed downlink packet access |  | 155d | 2000-08-21 A | 2001-03-23 A |  | 100% |  | 2000-08-21 | 2001-03-23 | 155d |  |  | finish no earlier than 2001-03-23 | R2 | 1240h | 1240h | Motorola | A. Ghosh |  | RInImp-HSDPA |  |  |
| 1950 | 64.6 | FS on improved common DL channel for Cell-FACH state |  | 340d | 2000-09-11 A | 2001-12-28 A |  | 100% |  | 2000-09-11 | 2001-12-28 | 340d |  |  | finish no earlier than 2001-12-28 | R2 | 2720h | 2720h | GBT | J. Kwak |  | RInImp-DLCFACH |  |  |
| 1951 | 64.7 | **Conformance Test Spec. Rel-4 improvements in Radio Interface** |  | 375d | 2001-10-08 A | 2003-03-14 |  | 64% | 134.62d | 2001-10-08 | 2003-03-14 | 375d | 1825d |  |  | T1 | 12360h | 7923.08h |  |  |  |  |  |  |
| 1952 | 64.7.1 | Testing Improved usage of downlink resource in FDD for CCTrCHs of dedicated type |  | 140d | 2002-02-18 | 2002-08-30 |  |  |  | 2002-02-18 | 2002-08-30 | 140d | 1965d |  | finish no earlier than 2002-08-30 | T1 | 1120h |  |  |  |  |  |  |  |
| 1953 | 64.7.2 | Testing Terminal Power saving features |  | 140d | 2002-02-18 | 2002-08-30 |  |  |  | 2002-02-18 | 2002-08-30 | 140d | 1965d |  | finish no earlier than 2002-08-30 | T1 | 1120h |  |  |  |  |  |  |  |
| 1954 | 64.7.3 | Testing DSCH power control improvement in soft handover |  | 140d | 2002-02-18 | 2002-08-30 |  |  |  | 2002-02-18 | 2002-08-30 | 140d | 1965d |  | finish no earlier than 2002-08-30 | T1 | 1120h |  |  |  | Rel-4 |  |  |  |
| 1955 | 64.7.4 | Testing UMTS 1800 |  | 180d | 2001-10-08 A | 2002-06-14 A |  | 100% |  | 2001-10-08 | 2002-06-14 | 180d |  |  | finish no earlier than 2002-06-14 | T1 | 1440h | 1440h |  |  | Rel indep |  |  | 34.108, 34,121, 34.122, 34.123-1 |
| 1956 | 64.7.5 | Testing UMTS 1900 |  | 180d | 2001-10-08 A | 2002-06-14 A |  | 100% |  | 2001-10-08 | 2002-06-14 | 180d |  |  | finish no earlier than 2002-06-14 | T1 | 1440h | 1440h |  |  | Rel indep |  |  | 34.108, 34,121, 34.122, 34.123-1 |
| 1957 | 64.7.6 | Testing UMTS 1800 - TTCN |  | 195d | 2002-06-17 A | 2003-03-14 A |  | 100% |  | 2002-06-17 | 2003-03-14 | 195d |  |  | finish no earlier than 2003-03-14 | T1 | 1560h | 1560h |  |  | Rel indep |  |  | 34.123-3 |
| 1958 | 64.7.7 | Testing UMTS 1900 - TTCN |  | 195d | 2002-06-17 A | 2003-03-14 A |  | 100% |  | 2002-06-17 | 2003-03-14 | 195d |  |  | finish no earlier than 2003-03-14 | T1 | 1560h | 1560h |  |  | Rel indep |  |  | 34.123-3 |
| 1959 | 65 | **Rel-4 RAN improvements** |  | 938d? | 2000-08-14 A | 2004-03-17 |  | 17% | 783.05d? | 2000-08-14 | 2004-03-17 | 938d? | 1562d |  |  | RP | 29336h | 4185.38h |  |  | NA | RANimp | Cesar |  |
| 1960 | 65.1 | Node B synchronisation for TDD |  | 160d | 2000-08-14 A | 2001-03-23 A |  | 100% |  | 2000-08-14 | 2001-03-23 | 160d |  |  | finish no earlier than 2001-03-23 | R1 | 1280h | 1280h | Siemens | S. Oestreich | Rel-4 | RANimp-NBsync |  |  |
| 1961 | 65.2 | RAB support enhancement for Rel-4 |  | 155d | 2000-08-21 A | 2001-03-23 A |  | 100% |  | 2000-08-21 | 2001-03-23 | 155d |  |  | finish no earlier than 2001-03-23 | R2 | 1240h | 1240h | Ericsson | M. Israelsson, A. Krishnarajah | Rel-4 | RANimp-RABSE |  |  |
| 1962 | 65.3 | Start Testing | milestone | 0d | 2001-12-03 | 2001-12-03 |  |  |  | 2001-12-03 | 2001-12-03 | 0d | 207d | 21d | start no earlier than 2001-12-03 | MLST |  |  |  |  |  |  |  |  |
| 1963 | 65.4 | **Conformance Test Aspects - Rel-4 RAN Improvements** |  | 577d? | 2002-01-01 A | 2004-03-17 | 1962 | 2% | 564.28d? | 2002-01-01 | 2004-03-17 | 577d? | 1562d |  |  | T1 | 19312h | 425.77h |  |  |  |  |  | 0% |
| 1964 | 65.4.1 | Testing Radio access bearer support enhancments |  | 175d | 2002-01-01 | 2002-09-02 |  |  |  | 2002-01-01 | 2002-09-02 | 175d | 1964d |  | finish no earlier than 2002-09-02 | T1 | 1400h |  |  |  |  |  |  |  |
| 1965 | 65.4.2 | Testing RAB support enhancements-Robust Header Compression |  | 332d | 2002-05-28 | 2003-09-03 |  |  |  | 2002-05-28 | 2003-09-03 | 332d | 1702d |  | finish no earlier than 2003-09-03 | T1 | 2656h |  |  |  | Rel-4 | RABimp-RoCH |  | 34.123-1, -2 |
| 1966 | 65.4.3 | Testing RAB support enhancements-Robust Header Compression - TTCN |  | 472d | 2002-05-28 | 2004-03-17 |  |  |  | 2002-05-28 | 2004-03-17 | 472d | 1562d |  | finish no earlier than 2004-03-17 | T1 | 3776h |  |  |  | Rel-4 |  |  | 34.123-3 |
| 1967 | 65.4.4 | Testing of Extended Robut Header Compression |  | 270d | 2002-09-18 A | 2003-09-30 |  | 15% | 229.5d | 2002-09-18 | 2003-09-30 | 270d | 1683d |  | finish no earlier than 2003-09-30 | T1 | 2160h | 324h |  |  | Rel-4 | Ext-RoHC |  | 34.123-1, -2 |
| 1968 | 65.4.5 | Testing of Extended Robut Header Compression - TTCN |  | 325d | 2002-09-18 | 2003-12-16 |  |  |  | 2002-09-18 | 2003-12-16 | 325d | 1628d |  | finish no earlier than 2003-12-16 | T1 | 2600h |  |  |  | Rel-4 |  |  | 34.123-3 |
| 1969 | 1.440.4.6 | General changes to TS34.121 corresponding to release 4 |  | 263d? | 2003-03-03 | 2004-03-03 |  |  |  | 2003-03-03 | 2004-03-03 | 263d? | 1572d |  | finish no earlier than 2004-03-03 | T1 | 2104h |  |  |  | Rel-4 | RANimp-test |  | 34.108, 34.121 |

Notes:
- 1942: Rel4 added
- 1950: Stopped at RP#14
- 1952: start/finish dates set / Not started yet due to lack of supporting companies
- 1953: start/finish dates set / Not started yet due to lack of supporting companies
- 1954: start/finish dates set / Not started yet due to lack of supporting companies
- 1955: finish date set
- 1956: finish date set
- 1957: finish date set
- 1958: finish date set
- 1961: 29 Nov 2000: split into ROHC and non-ROHC part; 5 Mar 2001: splitting off of ROHC for Rel-4 agreed by R2
- 1962: UID changed
- 1964: duration set to 6 months (was 0) / Task not started due to lack of supporting companies
- 1965: UID changed
- 1966: UID changed

| ID | WBS | Task | Duration | Start | Finish | Complete | Remaining | Baseline start | Baseline finish | Baseline duration | Total slack | Constraint | Resources | Work | Actual work | Text1 | Text4 | Text5 | Text6 | Text8 | Text3 |
| --- | --- | --- | --- | --- | --- | --- | --- | --- | --- | --- | --- | --- | --- | --- | --- | --- | --- | --- | --- | --- | --- |
| 1970 | 66 | **Rel-4 Emergency call enhancements** | 627d | 2000-01-03 A | 2002-05-28 | 64% | 227.72d | 2000-01-03 | 2002-05-28 | 627d | 2033d |  | N1 | 7936h | 5161.18h | EMC1 | Ericsson | Mr Rouzbeh (EUSFARO@am1.ericsson.se) | NA | Per |  |
| 1971 | 66.1 | **For CS based calls** | 627d | 2000-01-03 A | 2002-05-28 | 64% | 227.72d | 2000-01-03 | 2002-05-28 | 627d | 2033d |  | N1 | 3600h | 2400h | EMC1-CS | Ericsson | Mr Rouzbeh (EUSFARO@am1.ericsson.se) | Rel-4 |  |  |
| 1972 | 66.1.1 | Distinction in CS domain of emergency call types to different emergency services | 40d | 2000-05-01 A | 2000-06-23 A | 100% |  | 2000-05-01 | 2000-06-23 | 40d |  | finish no earlier than 2000-06-23 | S1 | 320h | 320h |  |  |  | Rel-4 |  |  |
| 1973 | 66.1.2 | Distinction in CS domain of emergency calls to different emergency types | 22d | 2000-08-28 A | 2000-09-26 A | 100% |  | 2000-08-28 | 2000-09-26 | 22d |  | finish no earlier than 2000-09-22 | N1 | 176h | 176h |  |  |  | Rel-4 |  |  |
| 1974 | 66.1.3 | Conformance Test Aspects - Emergency call enhancements | 150d | 2000-01-03 | 2000-07-28 |  |  | 2000-01-03 | 2000-07-28 | 150d | 2510d |  | T1 | 1200h |  |  |  |  |  |  |  |
| 1975 | 66.1.4 | Testing CS based emergency calls | 67d | 2002-02-25 A | 2002-05-28 A | 100% |  | 2002-02-25 | 2002-05-28 | 67d |  | finish no earlier than 2002-05-28 | T1 | 536h | 536h |  |  |  |  |  | 34.123-1 |
| 1976 | 66.1.5 | Testing CS based emergency calls - TTCN | 134d | 2001-11-22 A | 2002-05-28 A | 100% |  | 2001-11-22 | 2002-05-28 | 134d |  | finish no earlier than 2002-05-28 | T1 | 1072h | 1072h |  |  |  |  |  | 34.123-3 |
| 1977 | 67 | **Rel-4 Terminal interfaces** | 314d | 2000-01-03 A | 2001-03-15 | 99% | 0d | 2000-01-03 | 2001-03-15 | 314d | 0d |  | T2 | 14272h | 12892.4h | TI |  |  | NA | Friedhelm |  |
| 1978 | 67.1 | **AT commands enhancements** | 313d | 2000-01-03 A | 2001-03-14 A | 100% |  | 2000-01-03 | 2001-03-14 | 313d |  |  | T2 | 5008h | 5008h | TI-ATC |  |  | Rel-4 |  | 27.007 |
| 1979 | 67.1.1 | Specification of AT commands for new services | 313d | 2000-01-03 A | 2001-03-14 A | 100% |  | 2000-01-03 | 2001-03-14 | 313d |  | finish no earlier than 2001-03-14 | T2 | 2504h | 2504h |  |  |  |  |  | 27.007 |
| 1980 | 67.2 | **Wide Area Data Synchronisation** | 313d | 2000-01-03 A | 2001-03-14 | 99% | 0d | 2000-01-03 | 2001-03-14 | 313d | 0d |  | T2 | 5008h | 4360.8h | TI-WADS |  |  | NA |  |  |
| 1981 | 67.2.1 | Continues evolution of Synchronisation protocol | 313d | 2000-01-03 A | 2001-03-14 A | 100% |  | 2000-01-03 | 2001-03-14 | 313d |  | finish no earlier than 2001-03-14 | T2 | 2504h | 2504h | TI-SYNC-EVOL |  |  | Rel-4 |  | 27.903, 27.103 |
| 1982 | 67.3 | Terminal local model | 218d | 2000-05-16 A | 2001-03-15 A | 100% |  | 2000-05-16 | 2001-03-15 | 218d |  | finish no earlier than 2001-03-15 | T2 | 1744h | 1744h | TLM | Ericsson | Olga.Tome@ECS.ERICSSON.SE | Rel-4 |  | 23.227 |
| 1983 | 68 | **Rel-4 Location Services enhancements** | 455d | 2000-04-03 A | 2001-12-28 | 99% | 0d | 2000-04-03 | 2001-12-28 | 455d | 0d |  | S2 | 26799.2h | 25357.5h | LCS1 | Nokia | Jan Kall | NA | Alain |  |
| 1984 | 68.1 | CBS interactions | 455d | 2000-04-03 A | 2001-12-28 A | 100% |  | 2000-04-03 | 2001-12-28 | 455d |  | finish no earlier than 2001-12-28 | T2 | 3640h | 3640h | LCS1-CBS |  |  | Rel-4 |  | 23.041 |
| 1985 | 68.2 | LCS support in the CS domain | 180d | 2000-05-15 A | 2001-01-19 A | 100% |  | 2000-05-15 | 2001-01-19 | 180d |  | finish no earlier than 2001-01-19 | S2 | 1440h | 1440h | LCS1-CS |  |  | Rel-4 |  |  |
| 1986 | 68.3 | **LCS support in the PS domain** | 435d | 2000-05-01 A | 2001-12-28 | 99% | 0d | 2000-05-01 | 2001-12-28 | 435d | 0d |  | S2 | 13560h | 12955.2h | LCS1-PS |  |  | Rel-4 |  |  |
| 1987 | 68.3.1 | Stage 1 | 40d | 2000-07-03 A | 2000-08-25 A | 100% |  | 2000-07-03 | 2000-08-25 | 40d |  | start no earlier than 2000-07-03 | S1 | 320h | 320h |  | Pacific Bell Wireless | Randolph Wohlert (rwohlert@tri.sbc.com) |  |  | 22.071 |
| 1988 | 68.3.2 | Stage 2 | 190d | 2000-05-01 A | 2001-01-19 A | 100% |  | 2000-05-01 | 2001-01-19 | 190d |  | finish no earlier than 2001-01-19 | S2 | 1520h | 1520h |  |  |  |  |  | 23.271 |
| 1989 | 68.3.3 | **Stage 3** | 355d | 2000-08-21 A | 2001-12-28 A | 100% |  | 2000-08-21 | 2001-12-28 | 355d |  |  | N1 | 8240h | 8240h |  |  |  |  |  |  |
| 1990 | 68.3.3.1 | Layer 3 LCS signaling UE (MS) -SGSN (UMTS PS and and GSM-GPRS) | 355d | 2000-08-21 A | 2001-12-28 A | 100% |  | 2000-08-21 | 2001-12-28 | 355d |  | finish no earlier than 2001-12-28 | N1 | 2840h | 2840h |  | Nokia | Janne Muhonen |  |  |  |
| 1991 | 68.3.3.2 | MAP impacts of LCS | 160d | 2000-08-21 A | 2001-03-30 A | 100% |  | 2000-08-21 | 2001-03-30 | 160d |  | finish no earlier than 2001-03-30 | N4 | 1280h | 1280h |  |  |  |  |  |  |
| 1992 | 68.3.3.3 | GTP signaling for LCS | 160d | 2000-08-21 A | 2001-03-30 A | 100% |  | 2000-08-21 | 2001-03-30 | 160d |  | finish no earlier than 2001-03-30 | N4 | 1280h | 1280h |  |  |  |  |  |  |
| 1993 | 68.4 | **UE positioning Rel-4** | 260d | 2000-04-03 A | 2001-03-30 A | 100% |  | 2000-04-03 | 2001-03-30 | 260d |  |  | RP | 4591.2h | 4591.2h | LCS1-UEpos |  |  | NA |  |  |
| 1994 | 68.4.1 | Iub/Iur interfaces for methods Rel 99 | 233.9d | 2000-04-03 A | 2001-03-30 A | 100% |  | 2000-04-03 | 2001-03-30 | 233.9d |  | finish no earlier than 2001-03-30 | R3 | 1871.2h | 1871.2h | LCS1-UEpos-IubIur | Ericsson | Yun-Chao Hu | Rel-4 |  |  |
| 1995 | 68.4.2 | UE positioning enhancements - IPDL for TDD | 150d | 2000-08-28 A | 2001-03-23 A | 100% |  | 2000-08-28 | 2001-03-23 | 150d |  | finish no earlier than 2001-03-23 | R2 | 1200h | 1200h | LCS1-UEpos-enh | Siemens | M. Beckmann | Rel-4 |  |  |

Notes:
- 1971: WI approved in TSG_10 / CN1#15: ID 2101 REMOVE-Emergency call recalling capability enhancement, no contributions
- 1973: Calls to different emergency services such as ambulance, fire brigade, police, etc. can be routed to respective different emergency centres. / NP-000447 is the stage 3 changes for CS call control protocol.
- 1974: UID changed
- 1979: goal not completely achieved because of missing input
- 1980: AS: Rel5 changed to Rel4 according to SA#10 decision, milestone on testing added
- 1985: Only MAP impact foreseen so far. To be further split if needed.
- 1987: To be also considered: External LCS client identity, and Privacy options when PDP-context and when no PDP-context is established
- 1988: AS: 23.271 completed at SA#10
- 1991: Missing work task
- 1993: UID changed
- 1994: 27/11: WG corrected; rapporteur corrected
- 1995: 5 Mar 2001: splitting off of IPDL for TDD for Rel-4 agreed by R2

| ID | WBS | Task | Duration | Start | Finish | Complete | Remaining | Baseline start | Baseline finish | Baseline duration | Total slack | Constraint | Resources | Work | Actual work | Text1 | Text6 | Text8 | Text3 | Text4 | Text5 |
| --- | --- | --- | --- | --- | --- | --- | --- | --- | --- | --- | --- | --- | --- | --- | --- | --- | --- | --- | --- | --- | --- |
| 1996 | 69 | **Rel-4 UICC/(U)SIM enhancements and interworking** | 175d | 2000-07-24 A | 2001-03-23 A | 100% |  | 2000-07-24 | 2001-03-23 | 175d |  |  | T3 | 2800h | 2800h | UICC1 | NA | Claus |  |  |  |
| 1997 | 69.1 | Common PCN Handset Specification (CPHS) | 175d | 2000-07-24 A | 2001-03-23 A | 100% |  | 2000-07-24 | 2001-03-23 | 175d |  | finish no earlier than 2001-03-23 | T3 | 1400h | 1400h | UICC1-CPHS | Rel-4 |  | 27.103 | One2One |  |
| 1998 | 70 | **Rel-4 (U)SIM toolkit enhancements** | 210d | 2000-06-05 A | 2001-03-23 A | 100% |  | 2000-06-05 | 2001-03-23 | 210d |  |  | T3 | 3360h | 3360h | USAT1 | NA | Claus |  |  |  |
| 1999 | 70.1 | USAT local link | 210d | 2000-06-05 A | 2001-03-23 A | 100% |  | 2000-06-05 | 2001-03-23 | 210d |  | finish no earlier than 2001-03-23 | T3 | 1680h | 1680h | USAT1-LocLnk | Rel-4 |  |  | Gemplus | Jean-Francois Rubon |
| 2000 | 71 | **Rel-4 Security enhancements** | 575d | 2000-01-03 A | 2002-03-15 | 87% | 74.38d | 2000-01-03 | 2002-03-15 | 575d | 2085d |  | S3 | 24144h | 20865.5h | SEC1 | NA | Maurice |  | Vodafone | Peter.Howard@vodafone.com |
| 2001 | 71.1 | Evolution of GSM CS algorithms (e.g. A5/3 development and deployment) | 271d | 2000-01-03 A | 2001-01-15 A | 100% |  | 2000-01-03 | 2001-01-15 | 271d |  | finish no earlier than 2001-01-15 | S3 | 2168h | 2168h | SEC1-CSALGO1 | Rel-4 |  |  |  |  |
| 2002 | 71.2 | **Evolution of GSM PS algorithms (e.g. GEA 2 deployment)** | 219d | 2000-02-22 A | 2000-12-22 A | 100% |  | 2000-02-22 | 2000-12-22 | 219d |  |  | S3 | 6024h | 6024h | SEC1-PSALGO1 | Rel-4 |  |  |  |  |
| 2003 | 71.2.1 | Main aspects | 199d | 2000-02-22 A | 2000-11-24 A | 100% |  | 2000-02-22 | 2000-11-24 | 199d |  | finish no earlier than 2000-11-24 | S3 | 1592h | 1592h |  |  |  |  |  |  |
| 2004 | 71.2.2 | Impact on GTP | 200d | 2000-03-20 A | 2000-12-22 A | 100% |  | 2000-03-20 | 2000-12-22 | 200d |  | finish no earlier than 2000-12-22 | N4 | 1600h | 1600h |  |  |  |  |  |  |
| 2005 | 71.2.3 | GEA capability indication in MS CM | 135d | 2000-06-19 A | 2000-12-22 A | 100% |  | 2000-06-19 | 2000-12-22 | 135d |  | finish no earlier than 2000-12-22 | N1 | 1080h | 1080h | SEC1-PSALGO1-GEACAP |  |  |  | Vodafone Airtouch | Duncan Mills |
| 2006 | 71.3 | **MAP application layer security** | 575d | 2000-01-03 A | 2002-03-15 | 76% | 135.92d | 2000-01-03 | 2002-03-15 | 575d | 2085d |  | S3 | 11352h | 8668.58h | SEC1-MAPAL | Rel-4 |  |  |  |  |
| 2007 | 71.3.1 | Main aspects | 199d | 2000-02-21 A | 2001-03-29 A | 100% |  | 2000-02-21 | 2001-03-29 | 199d |  | start no earlier than 2000-02-21 | S3 | 1592h | 1592h |  |  |  |  |  |  |
| 2008 | 71.3.2 | Other stage 3 aspects | 199d | 2000-02-22 A | 2000-11-24 A | 100% |  | 2000-02-22 | 2000-11-24 | 199d |  | finish no earlier than 2000-11-24 | N4 | 1592h | 1592h |  |  |  |  |  |  |
| 2009 | 71.3.3 | CHECK STATUS - Visibility and Configurability of security | 575d | 2000-01-03 A | 2002-03-15 | 60% | 230d | 2000-01-03 | 2002-03-15 | 575d | 2085d | finish no earlier than 2002-03-15 | S3 | 4600h | 2760h | SEC1-VCS | Rel-5 |  |  | France Telecom | Sebastien.nguyenngoc@rd.francetelecom.com |
| 2010 | 72 | **Rel-4 Charging and OAM&P** | 221d | 2000-12-01 A | 2001-10-05 A | 100% |  | 2000-12-01 | 2001-10-05 | 221d |  |  | S5 | 10472h | 10472h | OAM | NA | Adrian | 32-series | VoiceStream, Motorola | Albert.Yuhan@voicestream.com; Michael.Truss@MOTOROLA.COM |
| 2011 | 72.1 | Rel4 Principles, high level Requirements and Architecture | 145d | 2000-12-01 A | 2001-06-21 A | 100% |  | 2000-12-01 | 2001-06-21 | 145d |  | finish no earlier than 2001-06-21 | S5 | 1160h | 1160h | OAM-AR/PR | Rel-4 |  | 32.101, 32.102 | Motorola, Telia | Michael.Truss@MOTOROLA.COM; Tommy.R.Berggren@TELIA.SE |
| 2012 | 72.2 | Rel4 Performance Management | 216d | 2000-12-01 A | 2001-09-28 A | 100% |  | 2000-12-01 | 2001-09-28 | 216d |  | finish no earlier than 2001-06-21 | S5 | 1728h | 1728h |  | Rel-4 |  | 32.4xy, 52.402 | T-Mobile | karl-heinz.nenner@t-mobile.de |
| 2013 | 72.3 | Fault Management | 221d | 2000-12-01 A | 2001-10-05 A | 100% |  | 2000-12-01 | 2001-10-05 | 221d |  | finish no earlier than 2001-06-21 | S5 | 1768h | 1768h |  | Rel-4 |  | 32.111-1/4 | Lucent | Patrick JURÉ ( (pjure@LUCENT.COM) |
| 2014 | 72.4 | Configuration Management | 145d | 2000-12-01 A | 2001-06-21 A | 100% |  | 2000-12-01 | 2001-06-21 | 145d |  | finish no earlier than 2001-06-21 | S5 | 1160h | 1160h | OAM-CM | Rel-4 |  | 32.106-1/8 | Ericsson | Thomas.Tovinger@emw.ericsson.se |
| 2015 | 72.5 | Rel4 Charging Management | 216d | 2000-12-01 A | 2001-09-28 A | 100% |  | 2000-12-01 | 2001-09-28 | 216d |  | finish no earlier than 2001-06-21 | S5 | 1728h | 1728h | OAM-CH | Rel-4 |  | 32.2xy (Charging) | T-Mobile | karl-heinz.nenner@t-mobile.de |
| 2016 | 72.6 | UTRAN Operations and Maintenance procedures | 145d | 2000-12-01 A | 2001-06-21 A | 100% |  | 2000-12-01 | 2001-06-21 | 145d |  | finish no earlier than 2001-06-21 | S5 | 1160h | 1160h | UOAM | Rel-4 | Adrian | 32.800 | Mannesmann Mobilfunk | bert.boden@d2mannesmann.de |
| 2017 | 73 | **Global Text Telephony** | 2348d? | 2000-01-03 A | 2008-12-31 | 99% | 0d? | 2000-01-03 | 2008-12-31 | 2348d? | 0d |  | S2 | 46352h | 46311.3h | GTT | Rel Indep | Alain |  | Ericsson | gunnar.hellstrom@omnitor.se |
| 2018 | 73.1 | Stage 1 | 188d | 2000-06-28 A | 2001-03-16 A | 100% |  | 2000-06-28 | 2001-03-16 | 188d |  | finish no earlier than 2000-12-22 | S1 | 1504h | 1504h |  |  |  | 22.976, 22.226 |  |  |
| 2019 | 73.2 | Stage 2 | 205d | 2000-09-11 A | 2001-06-22 A | 100% |  | 2000-09-11 | 2001-06-22 | 205d |  |  | S2 | 1640h | 1640h |  |  |  | 23.226 |  |  |

Notes:
- 1997: 28/5/2001: CRs approved at TP-11. WI complete.
- 1999: 25/5/2001:CR was approved at TP-11. WI is complete
- 2000: Added BB UE authentication and rapporteur added. TO BE DELETED
- 2001: Algorithm development go-ahead at SA3#21. Scheduled for completion in August 2002?. Approved SA#17. DELETE ENTRY FROM REL-4?
- 2002: A5/3 development will consider new GEA algorithm based on Kasumi.
- 2003: Complete TSG#09 (09/2000). S3#17: Proposed for deletion. TO BE DELETED
- 2006: TO DELETE: REPLACED BY NDS-MAP and NDS-IP. TO BE DELETED, but replacement NDS-MAP was missing. Completed Auto Key Management -> Rel-6
- 2007: UID changed
- 2008: UID changed
- 2009: CR approved at SA3#21 awaiting comments from CN1.
- 2010: az: WID appr.SA#13.
- 2012: Changed Rapp email
- 2015: Changed Rapp email
- 2017: SP-000162 agreed WI. Rapporteur / Gunnar Hellström, Ericsson Radio Systems AB, / email: gunnar.hellstrom@omnitor.se tel: +46 708 204 288

| ID | WBS | Task | Type | Duration | Start | Finish | Predecessors | Complete | Remaining | Baseline start | Baseline finish | Baseline duration | Total slack | Constraint | Resources | Work | Actual work | Text1 | Text3 | Text6 | Text8 |
| --- | --- | --- | --- | --- | --- | --- | --- | --- | --- | --- | --- | --- | --- | --- | --- | --- | --- | --- | --- | --- | --- |
| 2020 | 73.3 | **Specification of Cellular Text telephone Modem** |  | 136d | 2000-09-11 A | 2001-03-19 A |  | 100% |  | 2000-09-11 | 2001-03-19 | 136d |  |  | S4 | 2704h | 2704h | GTT-CTM |  |  |  |
| 2021 | 73.3.1 | General description and C-code |  | 66d | 2000-09-11 A | 2000-12-11 A |  | 100% |  | 2000-09-11 | 2000-12-11 | 66d |  | finish no earlier than 2000-12-11 | S4 | 528h | 528h |  | 26.226, 26.230 |  |  |
| 2022 | 73.3.2 | Minimum Performance requirements |  | 136d | 2000-09-11 A | 2001-03-19 A |  | 100% |  | 2000-09-11 | 2001-03-19 | 136d |  | finish no earlier than 2001-03-19 | S4 | 1088h | 1088h |  | 26.231 |  |  |
| 2023 | 73.4 | Start Testing | milestone | 0d | 2002-02-18 A | 2002-02-18 A |  | 100% |  | 2002-02-18 | 2002-02-18 | 0d |  | start no earlier than 2002-02-18 | MLST |  |  |  |  |  |  |
| 2024 | 73.5 | **Conformance Test Aspects - Global Text telephony** |  | 2348d? | 2000-01-03 A | 2008-12-31 | 2023 | 99% | 0d? | 2000-01-03 | 2008-12-31 | 2348d? | 0d |  | T1 | 24176h | 24148.2h |  | 34.125 |  |  |
| 2025 | 1.448.5.1 | Small Technical Enhancements and Improvements for Rel-4 Conformance Testing |  | 674d? | 2000-01-03 A | 2008-12-31 A |  | 100% |  | 2000-01-03 | 2008-12-31 | 674d? |  | finish no earlier than 2008-12-31 | R5 | 5392h | 5392h | TEI4_Test |  | Rel-4 | Stoyan Baev |

Notes:
- 2024: Bearer services, new spec document? / This task requires supporting companies before it can start
- 2025: "Joker" WI, to be used for small modifications applicable to Rel 4 conformance testing
